# Bauablaufplan Borsdorf - Engelsdorf

Schedule from MS Project, 2000-05-01 to 2002-08-21, status date 2000-08-03, costs in DM, A marks actual dates.

## Calendars

- Standard: Mon-Fri 08:00-12:00, 13:00-19:00; Sat-Sun off. Exceptions (off unless hours are given): 2000-07-21 08:00-12:00, 13:00-19:00, 2000-08-02 08:00-12:00, 13:00-17:00, 2000-09-16 to 2000-09-17 08:00-12:00, 13:00-17:00, 2000-10-28 to 2000-10-29 08:00-12:00, 13:00-17:00, 2000-11-18 to 2000-11-19 08:00-12:00, 13:00-17:00, 2000-11-26 08:00-12:00, 13:00-17:00, 2000-12-09 to 2000-12-10 08:00-12:00, 13:00-17:00, 2000-12-22 to 2001-01-05, 2001-01-06 to 2001-01-07 08:00-12:00, 13:00-17:00, 2001-03-10 to 2001-03-11 08:00-12:00, 13:00-17:00, 2001-04-07 to 2001-04-08 08:00-12:00, 13:00-17:00, 2001-07-14 to 2001-07-15 08:00-12:00, 13:00-17:00, 2001-07-21 to 2001-07-22 08:00-12:00, 13:00-17:00, 2001-07-28 to 2001-07-29 08:00-12:00, 13:00-17:00, 2001-08-04 to 2001-08-05 08:00-12:00, 13:00-17:00, 2001-08-11 to 2001-08-12 08:00-12:00, 13:00-17:00, 2001-12-24 to 2001-12-25, 2002-01-05 to 2002-01-06 08:00-12:00, 13:00-17:00, 2002-02-10 08:00-12:00, 13:00-17:00, 2002-03-10 08:00-12:00, 13:00-17:00, 2002-05-26 08:00-12:00, 13:00-17:00, 2002-07-06 to 2002-07-07 08:00-12:00, 13:00-17:00, 2002-08-17 to 2002-08-18 08:00-12:00, 13:00-17:00.

## Resources

| Resource | Group | Rate | Cost per use |
| --- | --- | --- | --- |
| 1. Bauleiter Sicherungstechn. | Metz | 90 |  |
| 1.C-Monteur LST | Metz | 60 |  |
| 1.MonteurMU/Kab | KAB | 60 |  |
| Plan PT I Arnhold. 1.4. | Planer, Arnhold |  | 10000 |
| Plan PT II (Siemens) 1.4 | Planer, Siemens |  | 42930 |
| Projektleiter | Metz | 130 |  |
| Sekretariat Projektbüro | Metz | 60 |  |
| C-Monteur LST Inb.1 | Metz | 60 |  |
| C-Monteur LST Inb.2 | Metz | 60 |  |
| Monteur LST Inb. 1 | Metz | 60 |  |
| Monteur LST Inb. 2 | Metz | 60 |  |
| C-Monteur LST Inb.3 | Metz | 90 |  |
| Monteur LST Inb. 3 | Metz | 60 |  |
| Monteur LST Inb. 4 | Metz | 60 |  |
| Plan PT I Arnhold. 2.1. | Planer, Arnhold |  | 10000 |
| Plan PT II (Siemens) 2.1 | Planer, Siemens |  | 18832.5 |
| 2. Bauleiter Sicherungstechnik | Metz | 60 |  |
| Erstellung BZ 2.2. | BahSig |  | 84457.9 |
| Erstellung BZ 0.1. | BahSig |  | 84457.9 |
| Erstellung BZ 3. | BahSig |  | 84457.9 |
| Erstellung BZ 0.2. | BahSig |  | 84457.9 |
| Erstellung BZ 1.4. | BahSig |  | 84457.9 |
| Erstellung BZ 2.1. | BahSig |  | 84457.9 |
| Erstellung BZ 4. | BahSig |  | 84457.9 |
| Erstellung BZ 5.1. | BahSig |  | 55425.5 |
| Erstellung BZ 5.2. | BahSig |  | 55425.5 |
| Erstellung BZ 5.3. | BahSig |  | 55425.5 |
| Erstellung BZ 6.1. | BahSig |  | 55425.5 |
| Erstellung BZ 6.2. | BahSig |  | 55425.5 |
| Erstellung BZ 8. | BahSig |  | 55425.5 |
| Erstellung BZ 9. | BahSig |  | 55425.5 |
| Erstellung BZ 10. | BahSig |  | 55425.5 |
| Erstellung BZ 11. | BahSig |  | 55425.5 |
| Erstellung BZ 12. | BahSig |  | 55425.5 |
| Erstellung BZ 13.1. | BahSig |  | 55425.5 |
| Erstellung BZ 14. | BahSig |  | 55425.5 |
| Erstellung BZ 15.1. | BahSig |  | 55425.5 |
| Erstellung BZ 16 | BahSig |  | 55425.5 |
| Erstellung Restarbeiten | BahSig |  | 591206 |
| Plan PT I Arnhold. 2.2. | Planer, Arnhold |  | 10000 |
| Plan PT I Arnhold. 0.1. | Planer, Arnhold |  | 10000 |
| Plan PT I Arnhold. 3. | Planer, Arnhold |  | 10000 |
| Plan PT I Arnhold. 0.2. | Planer, Arnhold |  | 40000 |
| Plan PT I ETC 0.1. | Planer, ETC |  | 10000 |
| Erstellung BZ 15.2. | BahSig |  | 55425.5 |
| Plan PT I ETC 3. | Planer, ETC |  | 14300 |
| Plan PT I ETC 4. | Planer, ETC |  | 18300 |
| Plan PT I ETC 5.1. | Planer, ETC |  | 44200 |
| Plan PT I ETC 5.2. | Planer, ETC |  | 32300 |
| Plan PT I ETC 14. | Planer, ETC |  | 19200 |
| Plan PT I ETC 15.1. | Planer, ETC |  | 25800 |
| Plan PT I ETC 16. | Planer, ETC |  | 34200 |
| Plan PT II (Siemens) 2.2. | Planer, Siemens |  | 15547.5 |
| Plan PT II (Siemens) 0.1. | Planer, Siemens |  | 90157.5 |
| Plan PT II (Siemens) 3. | Planer, Siemens |  | 90157.5 |
| Plan PT II (Siemens) 0.2. | Planer, Siemens |  | 70132.5 |
| Plan PT II (Siemens) 4. | Planer, Siemens |  | 124718 |
| Plan PT II (Siemens) 5.1. | Planer, Siemens |  | 42345 |
| Plan PT II (Siemens) 5.2. | Planer, Siemens |  | 35010 |
| Plan PT II (Siemens) 14. | Planer, Siemens |  | 74180 |
| Plan PT II (Siemens) 15.1. | Planer, Siemens |  | 109845 |
| Plan PT II (Siemens) 15.2. | Planer, Siemens |  | 74992.5 |
| Plan PT II (Siemens) 16. | Planer, Siemens |  | 147848 |
| Erstellung BZ 13.2. | BahSig |  | 55425.5 |
| 2.C-Monteur LST | Metz | 60 |  |
| 3.C-Monteur LST | Metz | 60 |  |
| 4.C-Monteur LST | Metz | 60 |  |
| 2.MonteurMU/Kab | KAB | 60 |  |
| 3.MonteurMU/Kab | KAB | 60 |  |
| 4.MonteurMU/Kab | KAB | 60 |  |
| C-Monteur LST Inb.4 | Metz | 60 |  |
| Monteur LST Inb. 5 | Metz | 60 |  |
| Monteur LST Inb. 6 | Metz | 60 |  |
| Monteur LST Inb. 7 | Metz | 60 |  |
| Monteur LST Inb. 8 | Metz | 60 |  |
| 5.MonteurMU/Kab | KAB | 60 |  |
| 6.MonteurMU/Kab | KAB | 60 |  |
| 7.MonteurMU/Kab | KAB | 60 |  |

## Schedule

| ID | WBS | Task | Type | Duration | Start | Finish | Predecessors | Complete | Remaining | Baseline start | Baseline finish | Baseline duration | Total slack | Free slack | Constraint | Resources | Work | Actual work | Cost | Baseline cost | Actual cost |
| --- | --- | --- | --- | --- | --- | --- | --- | --- | --- | --- | --- | --- | --- | --- | --- | --- | --- | --- | --- | --- | --- |
| 1 | 1 | **Bauzustand 1.4.** |  | 130.5d | 2000-05-01 A | 2000-09-20 |  | 76% | 31.43d | 2000-05-01 | 2000-09-17 | 126.25d | 640d |  |  | Projektleiter [34.8%]; Sekretariat Projektbüro [80%]; 1. Bauleiter Sicherungstechn. [80%]; 2. Bauleiter Sicherungstechnik [40%] | 2654.73h | 446.21h | 274,506.21 | 51,000 | 34,728.6 |
| 2 | 1.1 | **Planung** |  | 117.25d | 2000-05-01 A | 2000-09-07 |  | 99% | 0d | 2000-05-01 | 2000-09-07 | 117.5d | 0d |  |  |  | 752h | 328h | 72,930 | 51,000 | 30,000 |
| 3 | 1.1.1 | **Außenanlagen (PT I)** |  | 81.25d | 2000-05-01 A | 2000-07-28 A |  | 100% |  | 2000-05-01 | 2000-07-28 | 81.25d |  |  |  | Plan PT I Arnhold. 1.4. | 320h | 320h | 30,000 | 27,000 | 30,000 |
| 4 | 1.1.1.1 | Ausarbeitung |  | 11.25d | 2000-05-01 A | 2000-05-11 A |  | 100% |  | 2000-05-01 | 2000-05-10 | 0d? |  |  |  |  |  |  |  |  |  |
| 5 | 1.1.1.2 | Plausibilitätsprüfung ÖRZ |  | 2.5d | 2000-05-18 A | 2000-05-19 A | 4 | 100% |  | 2000-05-12 | 2000-05-15 | 6.25d |  |  |  |  |  |  |  |  |  |
| 6 | 1.1.1.3 | fachtechnische Prüfung |  | 27.5d | 2000-05-19 A | 2000-06-19 A | 5 | 100% |  | 2000-05-15 | 2000-06-16 | 27.5d |  |  |  |  |  |  |  |  |  |
| 7 | 1.1.1.4 | Übergabe und Weiterleitung PBDE |  | 1.25d | 2000-06-23 A | 2000-06-24 A | 6 | 100% |  | 2000-06-21 | 2000-06-23 | 3.75d |  |  |  |  |  |  |  |  |  |
| 8 | 1.1.1.5 | Prüfung durch EBA |  | 26.25d | 2000-06-24 A | 2000-07-24 A | 7 | 100% |  | 2000-06-23 | 2000-07-24 | 26.25d |  |  |  |  |  |  |  |  |  |
| 9 | 1.1.1.6 | Weiterleitung und Übergabe PBDE |  | 6.25d | 2000-07-24 A | 2000-07-28 A | 8 | 100% |  | 2000-07-24 | 2000-07-28 | 6.25d |  |  |  |  |  |  |  |  |  |
| 10 | 1.1.1.7 | ETC (PT I EBA - freigegeben) | milestone | 0d | 2000-07-24 A | 2000-07-24 A | 8 | 100% |  | 2000-07-24 | 2000-07-24 | 0d |  |  |  |  |  |  |  |  |  |
| 11 | 1.1.1.8 | Ing. Büro Arnold (PT I EBA - freigegeben) | milestone | 0d | 2000-07-24 A | 2000-07-24 A | 8 | 100% |  | 2000-07-24 | 2000-07-24 | 0d |  |  |  |  |  |  |  |  |  |
| 12 | 1.1.2 | **Innenanlagen (PT II)** |  | 67.25d | 2000-06-26 A | 2000-09-07 |  | 99% | 0d | 2000-06-19 | 2000-09-07 | 73.75d | 0d |  |  | Plan PT II (Siemens) 1.4 | 432h | 8h | 42,930 | 24,000 |  |
| 13 | 1.1.2.1 | Ausarbeitung |  | 20d | 2000-06-26 A | 2000-07-17 A | 6 | 100% |  | 2000-06-19 | 2000-07-10 | 20d |  |  |  |  |  |  |  | 24,000 |  |
| 14 | 1.1.2.2 | fachtechnische Prüfung |  | 19.75d | 2000-07-12 A | 2000-08-02 A | 13 | 100% |  | 2000-07-18 | 2000-08-02 | 20d |  |  |  |  |  |  |  |  |  |
| 15 | 1.1.2.3 | Übergabe und Weiterleitung PBDE |  | 1.25d | 2000-08-04 A | 2000-08-06 A | 14 | 100% |  | 2000-08-04 | 2000-08-06 | 1.25d |  |  |  |  |  |  |  |  |  |
| 16 | 1.1.2.4 | Prüfung durch EBA |  | 26.25d | 2000-08-07 A | 2000-09-04 A | 15 | 100% |  | 2000-08-07 | 2000-09-04 | 26.25d |  |  |  |  |  |  |  |  |  |
| 17 | 1.1.2.5 | Weiterleitung und Übergabe PBDE |  | 3.75d | 2000-09-05 A | 2000-09-07 A | 16 | 100% |  | 2000-09-05 | 2000-09-07 | 3.75d |  |  |  |  |  |  |  |  |  |
| 18 | 1.1.2.6 | Siemens (PT II EBA - freigegeben) | milestone | 0d | 2000-09-04 A | 2000-09-04 A | 16 | 100% |  | 2000-09-04 | 2000-09-04 | 0d |  |  |  |  |  |  |  |  |  |
| 19 | 1.2 | **Innen- und Außenanlage** |  | 42.25d | 2000-07-28 A | 2000-09-13 |  | 8% | 38.82d | 2000-07-28 | 2000-09-13 | 51.25d | 648.25d |  |  | 1.C-Monteur LST; 1.MonteurMU/Kab; Erstellung BZ 1.4. | 816.17h | 118.22h | 116,148.21 |  | 4,728.6 |
| 20 | 1.2.1 | Materialisierung |  | 3.75d | 2000-07-28 A | 2000-08-01 A | 10, 11 | 100% |  | 2000-07-28 | 2000-08-01 | 1.25d |  |  |  |  |  |  |  |  |  |
| 21 | 1.2.2 | Kabel, Signale, Magnete usw. bestellen und liefern |  | 15d | 2000-08-04 A | 2000-08-21 | 20 |  | 15d | 2000-08-04 | 2000-08-21 | 0d? | 643.25d | 0d |  |  |  |  |  |  |  |
| 22 | 1.2.3 | Kabel ziehen |  | 2.5d | 2000-08-22 | 2000-08-23 | 21 |  |  | 2000-08-22 | 2000-08-23 | 6.25d | 643.25d | 0d |  |  |  |  |  |  |  |
| 23 | 1.2.4 | Kabelarbeiten |  | 2.5d | 2000-08-24 | 2000-08-25 | 22 |  |  | 2000-08-24 | 2000-08-25 | 17.5d | 643.25d | 0d |  |  |  |  |  |  |  |
| 24 | 1.2.5 | Magnete montieren |  | 1.25d | 2000-08-28 | 2000-08-28 | 23 |  |  | 2000-08-28 | 2000-08-28 | 2.5d | 663.25d |  |  |  |  |  |  |  |  |
| 25 | 1.2.6 | Signalmasten stellen |  | 2.5d | 2000-08-15 | 2000-08-16 | 20, 21SS+8.75d |  |  | 2000-08-15 | 2000-08-16 | 0d? | 659.5d | 6.25d |  |  |  |  |  |  |  |
| 26 | 1.2.7 | Signale verkabeln |  | 2.5d | 2000-08-24 | 2000-08-25 | 22, 25 |  |  | 2000-08-24 | 2000-08-25 | 0d? | 653.25d | 10d |  |  |  |  |  |  |  |
| 27 | 1.2.8 | Kabel auf Kabelendverschluß legen |  | 2.5d | 2000-08-28 | 2000-08-29 | 23 |  |  | 2000-08-28 | 2000-08-29 | 0d? | 643.25d | 0d |  |  |  |  |  |  |  |
| 28 | 1.2.9 | Versorgung 50 Hz verdrahten |  | 1.25d | 2000-08-30 | 2000-08-30 | 27 |  |  | 2000-08-30 | 2000-08-30 | 0d? | 643.25d | 0d |  |  |  |  |  |  |  |
| 29 | 1.2.10 | Relaisgruppen montieren und bestücken |  | 2.5d | 2000-08-31 | 2000-09-01 | 28 |  |  | 2000-08-31 | 2000-09-01 | 0d? | 643.25d | 0d |  |  |  |  |  |  |  |
| 30 | 1.2.11 | Zimmerkabel, Rangierverdrahtung |  | 3.75d | 2000-09-04 | 2000-09-06 | 29 |  |  | 2000-09-04 | 2000-09-06 | 0d? | 643.25d | 0d |  |  |  |  |  |  |  |
| 31 | 1.2.12 | Herstellen der Funktionsfähigkeit, Prüfen |  | 6.25d | 2000-09-07 | 2000-09-13 | 30, 26 |  |  | 2000-09-07 | 2000-09-13 | 0d? | 643.25d | 3.25d |  |  |  |  |  |  |  |
| 32 | 1.3 | Inbetriebnahme Bz 1.4. |  | 1.25d | 2000-09-16 | 2000-09-17 | 31 |  |  | 2000-09-16 | 2000-09-17 | 1.25d | 640d | 0d | finish no earlier than 2000-09-17 | C-Monteur LST Inb.1 [400%]; Monteur LST Inb. 1 [400%] | 32h |  | 1,920 |  |  |

| ID | WBS | Task | Type | Duration | Start | Finish | Predecessors | Complete | Remaining | Baseline start | Baseline finish | Baseline duration | Total slack | Free slack | Constraint | Resources | Work | Actual work | Cost | Baseline cost |
| --- | --- | --- | --- | --- | --- | --- | --- | --- | --- | --- | --- | --- | --- | --- | --- | --- | --- | --- | --- | --- |
| 33 | 1.4 | **Restarbeiten Bz 1.4.** |  | 3.75d | 2000-09-18 | 2000-09-20 |  |  |  | 2000-09-18 | 2000-09-20 | 0d? | 640d |  |  | C-Monteur LST Inb.1 [80%]; Monteur LST Inb. 1 [80%] | 48h |  | 2,880 |  |
| 34 | 1.4.1 | Erstellen von handrevidierten Unterlagen |  | 3.75d | 2000-09-18 | 2000-09-20 | 32 |  |  | 2000-09-18 | 2000-09-20 | 0d? | 640d |  |  |  |  |  |  |  |
| 35 | 2 | **Bauzustand 2.1.** |  | 150.5d | 2000-05-20 A | 2000-11-01 |  | 38% | 92.91d | 2000-05-20 | 2000-10-30 | 165.75d | 601.25d |  |  | Projektleiter [600%]; Sekretariat Projektbüro [40%]; 1. Bauleiter Sicherungstechn. [40%]; 2. Bauleiter Sicherungstechnik [50%] | 2385.8h | 72h | 210,080.84 |  |
| 36 | 2.1 | **Planung** |  | 126.25d | 2000-05-20 A | 2000-10-06 |  | 56% | 55.06d | 2000-05-20 | 2000-10-06 | 117.5d | 625.5d |  |  |  | 940h | 72h | 28,832.5 | 51,000 |
| 37 | 2.1.1 | **Außenanlagen (PT I)** |  | 78.5d | 2000-05-20 A | 2000-08-16 |  | 93% | 5.25d | 2000-05-20 | 2000-07-28 | 81.25d | 673.25d |  |  | Plan PT I Arnhold. 2.1. | 520h | 72h | 10,000 | 27,000 |
| 38 | 2.1.1.1 | Ausarbeitung |  | 8.75d | 2000-05-20 A | 2000-05-30 A |  | 100% |  | 2000-05-20 | 2000-05-31 | 11.25d |  |  |  |  |  |  |  | 27,000 |
| 39 | 2.1.1.2 | Plausibilitätsprüfung ÖRZ |  | 2.5d | 2000-06-06 A | 2000-06-07 A | 38 | 100% |  | 2000-06-06 | 2000-06-08 | 6.25d |  |  |  |  |  |  |  |  |
| 40 | 2.1.1.3 | fachtechnische Prüfung |  | 22.5d | 2000-06-07 A | 2000-06-30 A | 39 | 100% |  | 2000-06-08 | 2000-06-28 | 27.5d |  |  |  |  |  |  |  |  |
| 41 | 2.1.1.4 | Übergabe und Weiterleitung PBDE |  | 2.5d | 2000-07-04 A | 2000-07-05 A | 40 | 100% |  | 2000-06-30 | 2000-07-04 | 3.75d |  |  |  |  |  |  |  |  |
| 42 | 2.1.1.5 | Prüfung durch EBA |  | 33.5d | 2000-07-05 A | 2000-08-10 A | 41 | 100% |  | 2000-07-04 | 2000-08-04 | 26.25d |  |  |  |  |  |  |  |  |
| 43 | 2.1.1.6 | Weiterleitung und Übergabe PBDE |  | 5d | 2000-08-11 | 2000-08-16 | 42 |  |  | 2000-08-04 | 2000-08-10 | 6.25d | 673.25d |  |  |  |  |  |  |  |
| 44 | 2.1.1.7 | ETC (PT I EBA - freigegeben) | milestone | 0d | 2000-08-10 | 2000-08-10 | 42 |  |  | 2000-08-04 | 2000-08-04 | 0d | 605.75d | 0d |  |  |  |  |  |  |
| 45 | 2.1.1.8 | Ing. Büro Arnold (PT I EBA - freigegeben) | milestone | 0d | 2000-08-10 | 2000-08-10 | 42 |  |  | 2000-08-04 | 2000-08-04 | 0d | 605.75d | 0d |  |  |  |  |  |  |
| 46 | 2.1.2 | **Innenanlagen (PT II)** |  | 86.25d | 2000-07-05 A | 2000-10-06 |  | 24% | 65.21d | 2000-06-29 | 2000-10-06 | 73.75d | 625.5d |  |  | Plan PT II (Siemens) 2.1 | 420h |  | 18,832.5 | 24,000 |
| 47 | 2.1.2.1 | Ausarbeitung |  | 21.25d | 2000-07-05 A | 2000-07-27 |  | 99% | 0.21d | 2000-06-29 | 2000-07-26 | 20d | 0d |  |  |  |  |  |  | 24,000 |
| 48 | 2.1.2.2 | fachtechnische Prüfung |  | 30d | 2000-07-28 | 2000-08-31 | 47 |  |  | 2000-07-28 | 2000-08-30 | 20d | 0d |  |  |  |  |  |  |  |
| 49 | 2.1.2.3 | Übergabe und Weiterleitung PBDE |  | 3.75d | 2000-08-31 | 2000-09-05 | 48 |  |  | 2000-09-01 | 2000-09-04 | 1.25d | 0d |  |  |  |  |  |  |  |
| 50 | 2.1.2.4 | Prüfung durch EBA |  | 26.25d | 2000-09-05 | 2000-10-02 | 49 |  |  | 2000-09-04 | 2000-10-02 | 26.25d | 0d |  |  |  |  |  |  |  |
| 51 | 2.1.2.5 | Weiterleitung und Übergabe PBDE |  | 5d | 2000-10-02 | 2000-10-06 | 50 |  |  | 2000-10-02 | 2000-10-06 | 3.75d | 625.5d |  |  |  |  |  |  |  |
| 52 | 2.1.2.6 | Siemens (PT II EBA - freigegeben) | milestone | 0d | 2000-10-02 | 2000-10-02 | 50 |  |  | 2000-10-02 | 2000-10-02 | 0d | 0d |  |  |  |  |  |  |  |
| 53 | 2.2 | **Innen- und Außenanlage** |  | 41.25d | 2000-09-11 | 2000-10-24 |  |  |  | 2000-09-05 | 2000-10-18 | 51.25d | 605.75d |  |  | 1.C-Monteur LST [50%]; 1.MonteurMU/Kab [50%]; Erstellung BZ 2.1.; 2.MonteurMU/Kab [50%]; 3.MonteurMU/Kab [30%] | 573.8h |  | 110,725.94 |  |
| 54 | 2.2.1 | Materialisierung |  | 6.25d | 2000-09-11 | 2000-09-15 | 44FS+26.25d, 45FS+26.25d |  |  | 2000-09-05 | 2000-09-11 | 1.25d | 605.75d | 0d |  |  |  |  |  |  |
| 55 | 2.2.2 | Kabel, Signale, Magnete usw. bestellen und liefern |  | 17.5d | 2000-09-19 | 2000-10-09 | 54FS+3.75d |  |  | 2000-09-15 | 2000-10-03 | 0d? | 605.75d | 0d |  |  |  |  |  |  |
| 56 | 2.2.3 | Kabel ziehen |  | 6.25d | 2000-09-22 | 2000-09-29 | 55SS+3.75d |  |  | 2000-09-18 | 2000-09-25 | 6.25d | 605.75d | 0d |  |  |  |  |  |  |
| 57 | 2.2.4 | Kabelarbeiten |  | 6.25d | 2000-09-29 | 2000-10-06 | 56 |  |  | 2000-09-25 | 2000-10-02 | 17.5d | 620.75d | 0d |  |  |  |  |  |  |
| 58 | 2.2.5 | Magnete montieren |  | 5d | 2000-10-06 | 2000-10-12 | 57 |  |  | 2000-10-02 | 2000-10-06 | 2.5d | 620.75d |  |  |  |  |  |  |  |
| 59 | 2.2.6 | Signalmasten stellen |  | 6.25d | 2000-09-28 | 2000-10-05 | 54, 55SS+8.75d |  |  | 2000-09-22 | 2000-09-29 | 0d? | 613.25d | 0d |  |  |  |  |  |  |
| 60 | 2.2.7 | Signale verkabeln |  | 2.5d | 2000-10-05 | 2000-10-09 | 56, 59 |  |  | 2000-09-29 | 2000-10-03 | 0d? | 613.25d | 7.5d |  |  |  |  |  |  |
| 61 | 2.2.8 | Kabel auf Kabelendverschluß legen |  | 2.5d | 2000-09-29 | 2000-10-03 | 56 |  |  | 2000-09-25 | 2000-09-27 | 0d? | 605.75d | 0d |  |  |  |  |  |  |
| 62 | 2.2.9 | Versorgung 50 Hz verdrahten |  | 2.5d | 2000-10-03 | 2000-10-05 | 61 |  |  | 2000-09-27 | 2000-09-29 | 0d? | 605.75d | 0d |  |  |  |  |  |  |
| 63 | 2.2.10 | Relaisgruppen montieren und bestücken |  | 6.25d | 2000-10-05 | 2000-10-12 | 62 |  |  | 2000-09-29 | 2000-10-06 | 0d? | 605.75d | 0d |  |  |  |  |  |  |
| 64 | 2.2.11 | Zimmerkabel, Rangiervergrahtung |  | 3.75d | 2000-10-12 | 2000-10-17 | 63 |  |  | 2000-10-06 | 2000-10-11 | 0d? | 605.75d | 0d |  |  |  |  |  |  |
| 65 | 2.2.12 | Herstellen der Funktionsfähigkeit, Prüfen |  | 6.25d | 2000-10-17 | 2000-10-24 | 64, 60 |  |  | 2000-10-11 | 2000-10-18 | 0d? | 605.75d | 4.5d |  |  |  |  |  |  |
| 66 | 2.3 | Inbetriebnahme Bz 2.1. |  | 1.25d | 2000-10-28 | 2000-10-29 | 65 |  |  | 2000-10-28 | 2000-10-29 | 1.25d | 601.25d | 0d | start no earlier than 2000-10-28 | C-Monteur LST Inb.1; Monteur LST Inb. 1 | 20h |  | 1,200 |  |

| ID | WBS | Task | Type | Duration | Start | Finish | Predecessors | Complete | Remaining | Baseline start | Baseline finish | Baseline duration | Total slack | Free slack | Constraint | Resources | Work | Actual work | Cost | Baseline cost | Actual cost |
| --- | --- | --- | --- | --- | --- | --- | --- | --- | --- | --- | --- | --- | --- | --- | --- | --- | --- | --- | --- | --- | --- |
| 67 | 2.4 | **Restarbeiten Bz 2.1.** |  | 3.75d | 2000-10-29 | 2000-11-01 |  |  |  | 2000-10-29 | 2000-11-01 | 0d? | 601.25d |  |  | C-Monteur LST Inb.1; Monteur LST Inb. 1 | 52h |  | 3,120 |  |  |
| 68 | 2.4.1 | Erstellen von handrevidierten Unterlagen |  | 3.75d | 2000-10-29 | 2000-11-01 | 66 |  |  | 2000-10-29 | 2000-11-01 | 0d? | 601.25d |  |  |  |  |  |  |  |  |
| 69 | 3 | **Bauzustand 2.2** |  | 159.5d | 2000-06-14 A | 2000-12-01 |  | 11% | 141.63d | 2000-06-14 | 2000-11-29 | 165.75d | 571d |  |  | Projektleiter [1200%]; Sekretariat Projektbüro [48%]; 1. Bauleiter Sicherungstechn. [48%]; 2. Bauleiter Sicherungstechnik [33%] | 2699.2h | 278.16h | 223,608.37 |  | 8,930.35 |
| 70 | 3.1 | **Planung** |  | 116.25d | 2000-06-14 A | 2000-10-19 |  | 18% | 95.26d | 2000-06-14 | 2000-10-19 | 117.5d | 614.25d |  |  |  | 832h | 170.69h | 25,547.5 | 51,000 |  |
| 71 | 3.1.1 | **Außenanlagen (PT I)** |  | 62.5d | 2000-06-14 A | 2000-08-23 |  | 43% | 35.72d | 2000-06-14 | 2000-08-22 | 81.25d | 668d |  |  | Plan PT I Arnhold. 2.2. | 400h | 170.69h | 10,000 | 27,000 |  |
| 72 | 3.1.1.1 | Ausarbeitung |  | 5d | 2000-06-14 A | 2000-06-19 A |  | 100% |  | 2000-06-14 | 2000-06-19 | 11.25d |  |  |  |  |  |  |  | 27,000 |  |
| 73 | 3.1.1.2 | Plausibilitätsprüfung ÖRZ |  | 3.75d | 2000-06-20 A | 2000-06-22 A | 72 | 100% |  | 2000-06-20 | 2000-06-22 | 6.25d |  |  |  |  |  |  |  |  |  |
| 74 | 3.1.1.3 | fachtechnische Prüfung |  | 18.75d | 2000-06-22 A | 2000-07-12 | 73 | 99% | 0.19d | 2000-06-22 | 2000-07-12 | 27.5d | 584.25d | 0d | start no earlier than 2000-08-07 |  |  |  |  |  |  |
| 75 | 3.1.1.4 | Übergabe und Weiterleitung PBDE |  | 2.5d | 2000-07-14 | 2000-07-17 | 74FS+1.25d |  |  | 2000-07-14 | 2000-07-17 | 3.75d | 584.25d | 0d |  |  |  |  |  |  |  |
| 76 | 3.1.1.5 | Prüfung durch EBA |  | 30d | 2000-07-17 | 2000-08-18 | 75FS-1.25d |  |  | 2000-07-17 | 2000-08-17 | 26.25d | 584.25d | 0d |  |  |  |  |  |  |  |
| 77 | 3.1.1.6 | Weiterleitung und Übergabe PBDE |  | 3.75d | 2000-08-18 | 2000-08-23 | 76 |  |  | 2000-08-18 | 2000-08-22 | 6.25d | 668d |  |  |  |  |  |  |  |  |
| 78 | 3.1.1.7 | ETC (PT I EBA - freigegeben) | milestone | 0d | 2000-08-18 | 2000-08-18 | 76 |  |  | 2000-08-17 | 2000-08-17 | 0d | 584.25d | 0d |  |  |  |  |  |  |  |
| 79 | 3.1.1.8 | Ing. Büro Arnold (PT I EBA - freigegeben) | milestone | 0d | 2000-08-18 | 2000-08-18 | 76 |  |  | 2000-08-17 | 2000-08-17 | 0d | 584.25d | 0d |  |  |  |  |  |  |  |
| 80 | 3.1.2 | **Innenanlagen (PT II)** |  | 88.75d | 2000-07-14 | 2000-10-19 |  |  |  | 2000-07-14 | 2000-10-19 | 73.75d | 614.25d |  |  | Plan PT II (Siemens) 2.2. | 432h |  | 15,547.5 | 24,000 |  |
| 81 | 3.1.2.1 | Ausarbeitung |  | 26.25d | 2000-07-14 | 2000-08-14 | 74FS+1.25d |  |  | 2000-07-14 | 2000-08-11 | 20d | 614.25d | 0d |  |  |  |  |  | 24,000 |  |
| 82 | 3.1.2.2 | fachtechnische Prüfung |  | 23.75d | 2000-08-15 | 2000-09-11 | 81FS+1.25d |  |  | 2000-08-15 | 2000-09-08 | 20d | 614.25d | 0d |  |  |  |  |  |  |  |
| 83 | 3.1.2.3 | Übergabe und Weiterleitung PBDE |  | 3.75d | 2000-09-12 | 2000-09-15 | 82FS+1.25d |  |  | 2000-09-12 | 2000-09-14 | 1.25d | 614.25d | 0d |  |  |  |  |  |  |  |
| 84 | 3.1.2.4 | Prüfung durch EBA |  | 28.75d | 2000-09-14 | 2000-10-13 | 83FS-1.25d |  |  | 2000-09-14 | 2000-10-13 | 26.25d | 614.25d | 0d |  |  |  |  |  |  |  |
| 85 | 3.1.2.5 | Weiterleitung und Übergabe PBDE |  | 5d | 2000-10-13 | 2000-10-19 | 84 |  |  | 2000-10-13 | 2000-10-19 | 3.75d | 614.25d |  |  |  |  |  |  |  |  |
| 86 | 3.1.2.6 | Siemens (PT II EBA - freigegeben) | milestone | 0d | 2000-10-13 | 2000-10-13 | 84 |  |  | 2000-10-13 | 2000-10-13 | 0d | 619.25d |  |  |  |  |  |  |  |  |
| 87 | 3.2 | **Innen- und Außenanlage** |  | 48.75d | 2000-09-16 | 2000-11-06 |  |  |  | 2000-09-16 | 2000-11-07 | 51.25d | 584.25d |  |  | 1.C-Monteur LST [66.7%]; 1.MonteurMU/Kab [66.7%]; Erstellung BZ 2.2.; 2.MonteurMU/Kab [50%]; 3.MonteurMU/Kab [50%]; 4.MonteurMU/Kab [50%] | 1020.12h |  | 131,265.14 |  |  |
| 88 | 3.2.1 | Materialisierung |  | 6.25d | 2000-09-16 | 2000-09-21 | 78FS+26.25d, 79FS+26.25d |  |  | 2000-09-16 | 2000-09-21 | 1.25d | 584.25d | 0d |  |  |  |  |  |  |  |
| 89 | 3.2.2 | Kabel, Signale, Magnete usw. bestellen und liefern |  | 26.25d | 2000-09-26 | 2000-10-25 | 88FS+3.75d |  |  | 2000-09-26 | 2000-10-25 | 0d? | 584.25d | 0d |  |  |  |  |  |  |  |
| 90 | 3.2.3 | Kabel ziehen |  | 7.5d | 2000-10-03 | 2000-10-11 | 89SS+6.25d |  |  | 2000-10-03 | 2000-10-11 | 6.25d | 584.25d | 0d | start no earlier than 2000-07-01 |  |  |  |  |  |  |
| 91 | 3.2.4 | Kabelarbeiten |  | 3.75d | 2000-10-11 | 2000-10-16 | 90 |  |  | 2000-10-11 | 2000-10-16 | 17.5d | 614.25d | 0d | start no earlier than 2000-08-06 |  |  |  |  |  |  |
| 92 | 3.2.5 | Magnete montieren |  | 3.75d | 2000-10-16 | 2000-10-19 | 91 |  |  | 2000-10-16 | 2000-10-19 | 2.5d | 614.25d |  |  |  |  |  |  |  |  |
| 93 | 3.2.6 | Signalmasten stellen |  | 2.5d | 2000-10-05 | 2000-10-09 | 88, 89SS+8.75d |  |  | 2000-10-05 | 2000-10-09 | 0d? | 596.75d | 2.5d |  |  |  |  |  |  |  |
| 94 | 3.2.7 | Signale verkabeln |  | 5d | 2000-10-11 | 2000-10-17 | 90, 93 |  |  | 2000-10-11 | 2000-10-17 | 0d? | 594.25d | 10d |  |  |  |  |  |  |  |
| 95 | 3.2.8 | Kabel auf Kabelendverschluß legen |  | 2.5d | 2000-10-11 | 2000-10-13 | 90 |  |  | 2000-10-11 | 2000-10-13 | 0d? | 584.25d | 0d |  |  |  |  |  |  |  |
| 96 | 3.2.9 | Versorgung 50 Hz verdrahten |  | 3.75d | 2000-10-13 | 2000-10-18 | 95 |  |  | 2000-10-13 | 2000-10-18 | 0d? | 584.25d | 0d |  |  |  |  |  |  |  |
| 97 | 3.2.10 | Relaisgruppen montieren und bestücken |  | 5d | 2000-10-18 | 2000-10-24 | 96 |  |  | 2000-10-18 | 2000-10-24 | 0d? | 584.25d | 0d |  |  |  |  |  |  |  |
| 98 | 3.2.11 | Zimmerkabel, Rangiervergrahtung |  | 3.75d | 2000-10-24 | 2000-10-27 | 97 |  |  | 2000-10-24 | 2000-10-27 | 0d? | 584.25d | 0d |  |  |  |  |  |  |  |
| 99 | 3.2.12 | Herstellen der Funktionsfähigkeit, Prüfen |  | 10d | 2000-10-27 | 2000-11-06 | 98, 94 |  |  | 2000-10-27 | 2000-11-06 | 0d? | 584.25d | 11.25d |  |  |  |  |  |  |  |
| 100 | 3.3 | Inbetriebnahme Bz 2.2. Borgsdorf |  | 6.25d | 2000-11-18 | 2000-11-23 | 99 |  |  | 2000-11-18 | 2000-11-19 | 1.25d | 573d | 2d | start no earlier than 2000-11-18 | C-Monteur LST Inb.1; Monteur LST Inb. 1 | 40h |  | 2,400 |  |  |
| 101 | 3.4 | Inbetriebnahme Bz 2.2. Engelsdorf |  | 1.25d | 2000-11-26 | 2000-11-27 | 100 |  |  | 2000-11-26 | 2000-11-27 | 1.25d | 571d | 0d | start no earlier than 2000-11-26 | C-Monteur LST Inb.1; Monteur LST Inb. 1; C-Monteur LST Inb.2; Monteur LST Inb. 2 | 35.6h |  | 2,136 |  |  |

| ID | WBS | Task | Type | Duration | Start | Finish | Predecessors | Complete | Remaining | Baseline start | Baseline finish | Baseline duration | Total slack | Free slack | Constraint | Resources | Work | Cost | Baseline cost |
| --- | --- | --- | --- | --- | --- | --- | --- | --- | --- | --- | --- | --- | --- | --- | --- | --- | --- | --- | --- |
| 102 | 3.5 | **Restarbeiten Bz 2.2.** |  | 5d | 2000-11-27 | 2000-12-01 |  |  |  | 2000-11-27 | 2000-12-01 | 0d? | 571d |  |  | C-Monteur LST Inb.1; Monteur LST Inb. 1 | 18.6h | 1,116 |  |
| 103 | 3.5.1 | Erstellen von handrevidierten Unterlagen |  | 5d | 2000-11-27 | 2000-12-01 | 100, 101 |  |  | 2000-11-27 | 2000-12-01 | 0d? | 571d |  |  |  |  |  |  |
| 104 | 4 | **Bauzustand 0.1.** |  | 171.75d | 2000-06-14 A | 2000-12-13 |  | 18% | 140.84d | 2000-06-14 | 2000-12-13 | 165.75d | 558.75d |  |  | Projektleiter [24%]; Sekretariat Projektbüro [28%]; 1. Bauleiter Sicherungstechn. [28%] | 3111.87h | 286,977.84 |  |
| 105 | 4.1 | **Planung** |  | 137.5d | 2000-06-14 A | 2000-11-09 |  | 28% | 99d | 2000-06-14 | 2000-11-09 | 117.5d | 593d |  |  |  | 1648h | 110,157.5 | 51,000 |
| 106 | 4.1.1 | **Außenanlagen (PT I)** |  | 83.75d | 2000-06-14 A | 2000-09-15 |  | 56% | 36.5d | 2000-06-14 | 2000-09-14 | 81.25d | 646.75d |  |  | Plan PT I Arnhold. 0.1.; Plan PT I ETC 0.1. | 1072h | 20,000 | 27,000 |
| 107 | 4.1.1.1 | Ausarbeitung |  | 16.25d | 2000-06-14 A | 2000-06-30 A |  | 100% |  | 2000-06-14 | 2000-06-30 | 11.25d |  |  |  |  |  |  | 27,000 |
| 108 | 4.1.1.2 | Plausibilitätsprüfung ÖRZ |  | 3.75d | 2000-06-30 A | 2000-07-04 A | 107 | 100% |  | 2000-06-30 | 2000-07-05 | 6.25d |  |  |  |  |  |  |  |
| 109 | 4.1.1.3 | fachtechnische Prüfung |  | 27.5d | 2000-07-06 A | 2000-08-07 | 108 | 99% | 0.25d | 2000-07-07 | 2000-08-04 | 27.5d | 559.25d | 0d | start no earlier than 2000-08-04 |  |  |  |  |
| 110 | 4.1.1.4 | Übergabe und Weiterleitung PBDE |  | 3.75d | 2000-08-09 | 2000-08-14 | 109FS+2.5d |  |  | 2000-08-09 | 2000-08-11 | 3.75d | 559.25d | 0d |  |  |  |  |  |
| 111 | 4.1.1.5 | Prüfung durch EBA |  | 27.5d | 2000-08-11 | 2000-09-12 | 110FS-1.25d |  |  | 2000-08-11 | 2000-09-11 | 26.25d | 559.25d | 0d |  |  |  |  |  |
| 112 | 4.1.1.6 | Weiterleitung und Übergabe PBDE |  | 5d | 2000-09-11 | 2000-09-15 | 111FS-1.25d |  |  | 2000-09-11 | 2000-09-14 | 6.25d | 646.75d |  |  |  |  |  |  |
| 113 | 4.1.1.7 | ETC (PT I EBA - freigegeben) | milestone | 0d | 2000-09-12 | 2000-09-12 | 111 |  |  | 2000-09-11 | 2000-09-11 | 0d | 559.25d | 0d |  |  |  |  |  |
| 114 | 4.1.1.8 | Ing. Büro Arnold (PT I EBA - freigegeben) | milestone | 0d | 2000-09-12 | 2000-09-12 | 111 |  |  | 2000-09-11 | 2000-09-11 | 0d | 559.25d | 0d |  |  |  |  |  |
| 115 | 4.1.2 | **Innenanlagen (PT II)** |  | 88.75d | 2000-08-08 | 2000-11-09 |  |  |  | 2000-08-08 | 2000-11-09 | 73.75d | 593d |  |  | Plan PT II (Siemens) 0.1. | 576h | 90,157.5 | 24,000 |
| 116 | 4.1.2.1 | Ausarbeitung |  | 30d | 2000-08-08 | 2000-09-11 | 109FS+1.25d |  |  | 2000-08-08 | 2000-09-08 | 20d | 593d | 0d |  |  |  |  | 24,000 |
| 117 | 4.1.2.2 | fachtechnische Prüfung |  | 18.75d | 2000-09-12 | 2000-09-29 | 116FS+1.25d |  |  | 2000-09-12 | 2000-09-29 | 20d | 593d | 0d |  |  |  |  |  |
| 118 | 4.1.2.3 | Übergabe und Weiterleitung PBDE |  | 2.5d | 2000-10-03 | 2000-10-05 | 117FS+2.5d |  |  | 2000-10-03 | 2000-10-05 | 1.25d | 593d | 0d |  |  |  |  |  |
| 119 | 4.1.2.4 | Prüfung durch EBA |  | 30d | 2000-10-05 | 2000-11-06 | 118 |  |  | 2000-10-05 | 2000-11-06 | 26.25d | 593d | 0d |  |  |  |  |  |
| 120 | 4.1.2.5 | Weiterleitung und Übergabe PBDE |  | 3.75d | 2000-11-07 | 2000-11-09 | 119 |  |  | 2000-11-06 | 2000-11-09 | 3.75d | 593d |  |  |  |  |  |  |
| 121 | 4.1.2.6 | Siemens (PT II EBA - freigegeben) | milestone | 0d | 2000-11-06 | 2000-11-06 | 119 |  |  | 2000-11-06 | 2000-11-06 | 0d | 596.75d |  |  |  |  |  |  |
| 122 | 4.2 | **Innen- und Außenanlage** |  | 58.75d | 2000-10-09 | 2000-12-07 |  |  |  | 2000-10-09 | 2000-12-05 | 51.25d | 559.25d |  |  | 1.C-Monteur LST [68%]; 1.MonteurMU/Kab [66.7%]; Erstellung BZ 0.1.; 2.C-Monteur LST [50%]; 2.MonteurMU/Kab [68%] | 855.67h | 124,037.94 |  |
| 123 | 4.2.1 | Materialisierung |  | 10d | 2000-10-09 | 2000-10-19 | 113FS+26.25d, 114FS+26.25d |  |  | 2000-10-09 | 2000-10-19 | 1.25d | 559.25d | 0d |  |  |  |  |  |
| 124 | 4.2.2 | Kabel, Signale, Magnete usw. bestellen und liefern |  | 27.5d | 2000-10-24 | 2000-11-20 | 123FS+3.75d |  |  | 2000-10-24 | 2000-11-20 | 0d? | 559.25d | 0d |  |  |  |  |  |
| 125 | 4.2.3 | Kabel ziehen |  | 10d | 2000-10-31 | 2000-11-09 | 124SS+7.5d |  |  | 2000-10-30 | 2000-11-09 | 6.25d | 561.75d | 0d | start no earlier than 2000-07-01 |  |  |  |  |
| 126 | 4.2.4 | Kabelarbeiten |  | 3.75d | 2000-11-10 | 2000-11-14 | 125 |  |  | 2000-11-09 | 2000-11-14 | 17.5d | 585.5d | 0d |  |  |  |  |  |
| 127 | 4.2.5 | Magnete montieren |  | 3.75d | 2000-11-15 | 2000-11-17 | 126 |  |  | 2000-11-14 | 2000-11-17 | 2.5d | 585.5d |  |  |  |  |  |  |
| 128 | 4.2.6 | Signalmasten stellen |  | 3.75d | 2000-11-20 | 2000-11-23 | 123, 124 |  |  | 2000-11-20 | 2000-11-23 | 0d? | 559.25d | 0d |  |  |  |  |  |
| 129 | 4.2.7 | Signale verkabeln |  | 3.75d | 2000-11-23 | 2000-11-27 | 125, 128 |  |  | 2000-11-23 | 2000-11-27 | 0d? | 559.25d | 0d |  |  |  |  |  |
| 130 | 4.2.8 | Kabel auf Kabelendverschluß legen |  | 2.5d | 2000-11-10 | 2000-11-13 | 125 |  |  | 2000-11-09 | 2000-11-13 | 0d? | 561.75d | 0d |  |  |  |  |  |
| 131 | 4.2.9 | Versorgung 50 Hz verdrahten |  | 3.75d | 2000-11-14 | 2000-11-16 | 130 |  |  | 2000-11-13 | 2000-11-16 | 0d? | 561.75d | 0d |  |  |  |  |  |
| 132 | 4.2.10 | Relaisgruppen montieren und bestücken |  | 5d | 2000-11-17 | 2000-11-21 | 131 |  |  | 2000-11-16 | 2000-11-21 | 0d? | 561.75d | 0d |  |  |  |  |  |
| 133 | 4.2.11 | Zimmerkabel, Rangiervergrahtung |  | 3.75d | 2000-11-21 | 2000-11-24 | 132 |  |  | 2000-11-21 | 2000-11-24 | 0d? | 561.75d | 2.5d |  |  |  |  |  |
| 134 | 4.2.12 | Herstellen der Funktionsfähigkeit, Prüfen |  | 10d | 2000-11-27 | 2000-12-07 | 133, 129 |  |  | 2000-11-27 | 2000-12-07 | 0d? | 559.25d | 0.5d |  |  |  |  |  |
| 135 | 4.3 | Inbetriebnahme Bz 0.1. |  | 2.5d | 2000-12-08 | 2000-12-10 | 134 |  |  | 2000-12-08 | 2000-12-10 | 1.25d | 558.75d | 0d | start no earlier than 2000-12-08 | C-Monteur LST Inb.1; Monteur LST Inb. 1; C-Monteur LST Inb.2; Monteur LST Inb. 2 | 58h | 3,480 |  |

| ID | WBS | Task | Type | Duration | Start | Finish | Predecessors | Baseline start | Baseline finish | Baseline duration | Total slack | Free slack | Constraint | Resources | Work | Cost | Baseline cost |
| --- | --- | --- | --- | --- | --- | --- | --- | --- | --- | --- | --- | --- | --- | --- | --- | --- | --- |
| 136 | 4.4 | **Restarbeiten Bz 0.1.** |  | 3.75d | 2000-12-10 | 2000-12-13 |  | 2000-12-10 | 2000-12-13 | 0d? | 558.75d |  |  | C-Monteur LST Inb.1; Monteur LST Inb. 1 | 51h | 3,060 |  |
| 137 | 4.4.1 | Erstellen von handrevidierten Unterlagen |  | 3.75d | 2000-12-10 | 2000-12-13 | 135 | 2000-12-10 | 2000-12-13 | 0d? | 558.75d |  |  |  |  |  |  |
| 138 | 5 | **Bauzustand 3.** |  | 181.25d | 2000-06-19 | 2001-01-10 |  | 2000-06-19 | 2001-01-09 | 165.75d | 545.5d |  |  | Projektleiter [40%]; Sekretariat Projektbüro [28%]; 1. Bauleiter Sicherungstechn. [28%]; 2. Bauleiter Sicherungstechnik [40%] | 3416.4h | 306,189.04 |  |
| 139 | 5.1 | **Planung** |  | 155d | 2000-06-19 | 2000-11-30 |  | 2000-06-19 | 2000-11-30 | 117.5d | 548d |  |  |  | 1674h | 114,457.5 | 51,000 |
| 140 | 5.1.1 | **Außenanlagen (PT I)** |  | 93.75d | 2000-06-19 | 2000-09-28 |  | 2000-06-19 | 2000-09-28 | 81.25d | 548d |  |  | Plan PT I Arnhold. 3.; Plan PT I ETC 3. | 1200h | 24,300 | 27,000 |
| 141 | 5.1.1.1 | Ausarbeitung |  | 26.25d | 2000-06-19 | 2000-07-17 |  | 2000-06-19 | 2000-07-17 | 11.25d | 548d | 0d | start no earlier than 2000-06-19 |  |  |  | 27,000 |
| 142 | 5.1.1.2 | Plausibilitätsprüfung ÖRZ |  | 1.25d | 2000-07-19 | 2000-07-19 | 141FS+1.25d | 2000-07-19 | 2000-07-19 | 6.25d | 548d | 0d |  |  |  |  |  |
| 143 | 5.1.1.3 | fachtechnische Prüfung |  | 28.75d | 2000-07-20 | 2000-08-22 | 142 | 2000-07-20 | 2000-08-21 | 27.5d | 548d | 0d |  |  |  |  |  |
| 144 | 5.1.1.4 | Übergabe und Weiterleitung PBDE |  | 3.75d | 2000-08-23 | 2000-08-28 | 143FS+1.25d | 2000-08-23 | 2000-08-25 | 3.75d | 548d | 0d |  |  |  |  |  |
| 145 | 5.1.1.5 | Prüfung durch EBA |  | 28.75d | 2000-08-25 | 2000-09-25 | 144FS-1.25d | 2000-08-25 | 2000-09-25 | 26.25d | 548d | 0d |  |  |  |  |  |
| 146 | 5.1.1.6 | Weiterleitung und Übergabe PBDE |  | 3.75d | 2000-09-25 | 2000-09-28 | 145 | 2000-09-25 | 2000-09-28 | 6.25d | 633d |  |  |  |  |  |  |
| 147 | 5.1.1.7 | ETC (PT I EBA - freigegeben) | milestone | 0d | 2000-09-25 | 2000-09-25 | 145 | 2000-09-25 | 2000-09-25 | 0d | 548d | 0d |  |  |  |  |  |
| 148 | 5.1.1.8 | Ing. Büro Arnold (PT I EBA - freigegeben) | milestone | 0d | 2000-09-25 | 2000-09-25 | 145 | 2000-09-25 | 2000-09-25 | 0d | 548d | 0d |  |  |  |  |  |
| 149 | 5.1.2 | **Innenanlagen (PT II)** |  | 96.25d | 2000-08-23 | 2000-11-30 |  | 2000-08-23 | 2000-11-30 | 73.75d | 571.75d |  |  | Plan PT II (Siemens) 3. | 474h | 90,157.5 | 24,000 |
| 150 | 5.1.2.1 | Ausarbeitung |  | 30d | 2000-08-23 | 2000-09-22 | 143FS+1.25d | 2000-08-23 | 2000-09-22 | 20d | 571.75d | 0d |  |  |  |  | 24,000 |
| 151 | 5.1.2.2 | fachtechnische Prüfung |  | 26.25d | 2000-09-26 | 2000-10-25 | 150FS+2.5d | 2000-09-26 | 2000-10-25 | 20d | 571.75d | 0d |  |  |  |  |  |
| 152 | 5.1.2.3 | Übergabe und Weiterleitung PBDE |  | 1.25d | 2000-10-26 | 2000-10-27 | 151FS+1.25d | 2000-10-26 | 2000-10-27 | 1.25d | 571.75d | 0d |  |  |  |  |  |
| 153 | 5.1.2.4 | Prüfung durch EBA |  | 31.25d | 2000-10-27 | 2000-11-27 | 152 | 2000-10-27 | 2000-11-27 | 26.25d | 571.75d | 0d |  |  |  |  |  |
| 154 | 5.1.2.5 | Weiterleitung und Übergabe PBDE |  | 3.75d | 2000-11-27 | 2000-11-30 | 153 | 2000-11-27 | 2000-11-30 | 3.75d | 571.75d |  |  |  |  |  |  |
| 155 | 5.1.2.6 | Siemens (PT II EBA - freigegeben) | milestone | 0d | 2000-11-27 | 2000-11-27 | 153 | 2000-11-27 | 2000-11-27 | 0d | 575.5d |  |  |  |  |  |  |
| 156 | 5.2 | **Innen- und Außenanlage** |  | 57.5d | 2000-10-24 | 2000-12-19 |  | 2000-10-24 | 2000-12-19 | 51.25d | 548d |  |  | 1.C-Monteur LST [50%]; 1.MonteurMU/Kab [50%]; Erstellung BZ 3.; 2.MonteurMU/Kab [50%]; 3.MonteurMU/Kab [50%] | 839.12h | 123,285.14 |  |
| 157 | 5.2.1 | Materialisierung |  | 15d | 2000-10-24 | 2000-11-07 | 147FS+26.25d, 148FS+26.25d | 2000-10-24 | 2000-11-07 | 1.25d | 548d | 0d | start no earlier than 2000-08-23 |  |  |  |  |
| 158 | 5.2.2 | Kabel, Signale, Magnete usw. bestellen und liefern |  | 26.25d | 2000-11-13 | 2000-12-07 | 157FS+3.75d | 2000-11-10 | 2000-12-07 | 0d? | 548d | 0d |  |  |  |  |  |
| 159 | 5.2.3 | Kabel ziehen |  | 6.25d | 2000-11-18 | 2000-11-23 | 158SS+6.25d | 2000-11-17 | 2000-11-23 | 6.25d | 554.25d | 0d | start no earlier than 2000-07-01 |  |  |  |  |
| 160 | 5.2.4 | Kabelarbeiten |  | 3.75d | 2000-11-23 | 2000-11-27 | 159 | 2000-11-23 | 2000-11-27 | 17.5d | 571.75d | 0d | start no earlier than 2000-08-06 |  |  |  |  |
| 161 | 5.2.5 | Magnete montieren |  | 3.75d | 2000-11-27 | 2000-11-30 | 160 | 2000-11-27 | 2000-11-30 | 2.5d | 571.75d |  |  |  |  |  |  |
| 162 | 5.2.6 | Signalmasten stellen |  | 2.5d | 2000-12-07 | 2000-12-09 | 157, 158 | 2000-12-07 | 2000-12-09 | 0d? | 548d | 0d |  |  |  |  |  |
| 163 | 5.2.7 | Signale verkabeln |  | 5d | 2000-12-09 | 2000-12-13 | 159, 162 | 2000-12-09 | 2000-12-13 | 0d? | 548d | 0d |  |  |  |  |  |
| 164 | 5.2.8 | Kabel auf Kabelendverschluß legen |  | 2.5d | 2000-11-23 | 2000-11-26 | 159 | 2000-11-23 | 2000-11-26 | 0d? | 554.25d | 0d |  |  |  |  |  |
| 165 | 5.2.9 | Versorgung 50 Hz verdrahten |  | 3.75d | 2000-11-26 | 2000-11-29 | 164 | 2000-11-26 | 2000-11-29 | 0d? | 554.25d | 0d |  |  |  |  |  |
| 166 | 5.2.10 | Relaisgruppen montieren und bestücken |  | 5d | 2000-11-29 | 2000-12-05 | 165 | 2000-11-29 | 2000-12-05 | 0d? | 554.25d | 0d |  |  |  |  |  |
| 167 | 5.2.11 | Zimmerkabel, Rangiervergrahtung |  | 3.75d | 2000-12-05 | 2000-12-08 | 166 | 2000-12-05 | 2000-12-08 | 0d? | 554.25d | 6.25d |  |  |  |  |  |
| 168 | 5.2.12 | Herstellen der Funktionsfähigkeit, Prüfen |  | 5d | 2000-12-14 | 2000-12-19 | 167, 163 | 2000-12-13 | 2000-12-19 | 0d? | 548d | 2.5d |  |  |  |  |  |
| 169 | 5.3 | Inbetriebnahme Bz 3. |  | 1.25d | 2001-01-06 | 2001-01-07 | 168 | 2001-01-06 | 2001-01-07 | 1.25d | 545.5d | 0d | start no earlier than 2001-01-06 | C-Monteur LST Inb.1; Monteur LST Inb. 1 | 13h | 780 |  |

| ID | WBS | Task | Type | Duration | Start | Finish | Predecessors | Baseline start | Baseline finish | Baseline duration | Total slack | Free slack | Constraint | Resources | Work | Cost | Baseline cost |
| --- | --- | --- | --- | --- | --- | --- | --- | --- | --- | --- | --- | --- | --- | --- | --- | --- | --- |
| 170 | 5.4 | **Restarbeiten Bz 3.** |  | 3.75d | 2001-01-07 | 2001-01-10 |  | 2001-01-07 | 2001-01-10 | 0d? | 545.5d |  |  | C-Monteur LST Inb.1 [200%]; Monteur LST Inb. 1 [200%] | 59h | 3,540 |  |
| 171 | 5.4.1 | Erstellen von handrevidierten Unterlagen |  | 3.75d | 2001-01-07 | 2001-01-10 | 169 | 2001-01-07 | 2001-01-10 | 0d? | 545.5d |  |  |  |  |  |  |
| 172 | 6 | **Bauzustand 0.2.** |  | 228.25d | 2000-06-30 | 2001-03-14 |  | 2000-06-30 | 2001-03-06 | 165.75d | 487.25d |  |  | Projektleiter; Sekretariat Projektbüro [24%]; 1. Bauleiter Sicherungstechn. [24%] | 4571.75h | 366,391.17 |  |
| 173 | 6.1 | **Planung** |  | 165d | 2000-06-30 | 2000-12-21 |  | 2000-06-30 | 2000-12-20 | 117.5d | 495.5d |  |  |  | 1148h | 80,132.5 | 51,000 |
| 174 | 6.1.1 | **Außenanlagen (PT I)** |  | 96.25d | 2000-06-30 | 2000-10-13 |  | 2000-06-30 | 2000-10-13 | 81.25d | 495.5d |  |  | Plan PT I Arnhold. 0.2. | 468h | 10,000 | 27,000 |
| 175 | 6.1.1.1 | Ausarbeitung |  | 27.5d | 2000-06-30 | 2000-07-31 |  | 2000-06-30 | 2000-07-31 | 11.25d | 495.5d | 0d | start no earlier than 2000-06-30 |  |  |  | 27,000 |
| 176 | 6.1.1.2 | Plausibilitätsprüfung ÖRZ |  | 3.75d | 2000-08-01 | 2000-08-04 | 175 | 2000-08-01 | 2000-08-03 | 6.25d | 495.5d | 0d |  |  |  |  |  |
| 177 | 6.1.1.3 | fachtechnische Prüfung |  | 28.75d | 2000-08-04 | 2000-09-06 | 176 | 2000-08-04 | 2000-09-05 | 27.5d | 495.5d | 0d |  |  |  |  |  |
| 178 | 6.1.1.4 | Übergabe und Weiterleitung PBDE |  | 2.5d | 2000-09-07 | 2000-09-11 | 177FS+1.25d | 2000-09-07 | 2000-09-08 | 3.75d | 495.5d | 0d |  |  |  |  |  |
| 179 | 6.1.1.5 | Prüfung durch EBA |  | 28.75d | 2000-09-08 | 2000-10-09 | 178FS-1.25d | 2000-09-08 | 2000-10-09 | 26.25d | 495.5d | 0d |  |  |  |  |  |
| 180 | 6.1.1.6 | Weiterleitung und Übergabe PBDE |  | 5d | 2000-10-09 | 2000-10-13 | 179 | 2000-10-09 | 2000-10-13 | 6.25d | 619.25d |  |  |  |  |  |  |
| 181 | 6.1.1.7 | ETC (PT I EBA - freigegeben) | milestone | 0d | 2000-10-09 | 2000-10-09 | 179 | 2000-10-09 | 2000-10-09 | 0d | 495.5d | 0d |  |  |  |  |  |
| 182 | 6.1.1.8 | Ing. Büro Arnold (PT I EBA - freigegeben) | milestone | 0d | 2000-10-09 | 2000-10-09 | 179 | 2000-10-09 | 2000-10-09 | 0d | 495.5d | 0d |  |  |  |  |  |
| 183 | 6.1.2 | **Innenanlagen (PT II)** |  | 103.75d | 2000-09-07 | 2000-12-21 |  | 2000-09-07 | 2000-12-21 | 73.75d | 550.5d |  |  | Plan PT II (Siemens) 0.2. | 680h | 70,132.5 | 24,000 |
| 184 | 6.1.2.1 | Ausarbeitung |  | 30d | 2000-09-07 | 2000-10-09 | 177FS+1.25d | 2000-09-07 | 2000-10-09 | 20d | 550.5d | 0d |  |  |  |  | 24,000 |
| 185 | 6.1.2.2 | fachtechnische Prüfung |  | 30d | 2000-10-11 | 2000-11-10 | 184FS+2.5d | 2000-10-11 | 2000-11-10 | 20d | 550.5d | 0d |  |  |  |  |  |
| 186 | 6.1.2.3 | Übergabe und Weiterleitung PBDE |  | 2.5d | 2000-11-13 | 2000-11-14 | 185 | 2000-11-10 | 2000-11-14 | 1.25d | 550.5d | 0d |  |  |  |  |  |
| 187 | 6.1.2.4 | Prüfung durch EBA |  | 32.5d | 2000-11-17 | 2000-12-18 | 186FS+2.5d | 2000-11-16 | 2000-12-18 | 26.25d | 550.5d | 0d |  |  |  |  |  |
| 188 | 6.1.2.5 | Weiterleitung und Übergabe PBDE |  | 3.75d | 2000-12-19 | 2000-12-21 | 187 | 2000-12-18 | 2000-12-21 | 3.75d | 550.5d |  |  |  |  |  |  |
| 189 | 6.1.2.6 | Siemens (PT II EBA - freigegeben) | milestone | 0d | 2000-12-18 | 2000-12-18 | 187 | 2000-12-18 | 2000-12-18 | 0d | 554.25d |  |  |  |  |  |  |
| 190 | 6.2 | **Innen- und Außenanlage** |  | 85d | 2000-11-18 | 2001-03-01 |  | 2000-11-17 | 2001-03-01 | 51.25d | 495.5d |  |  | 1.C-Monteur LST [75.8%]; 1.MonteurMU/Kab [75.8%]; Erstellung BZ 0.2.; 2.MonteurMU/Kab [80%]; 3.MonteurMU/Kab [80%]; 4.MonteurMU/Kab [80%]; 5.MonteurMU/Kab [80%]; 6.MonteurMU/Kab; 7.MonteurMU/Kab | 2813.43h | 236,463.47 |  |
| 191 | 6.2.1 | Materialisierung |  | 26.25d | 2000-11-18 | 2000-12-12 | 181FS+38.75d, 182FS+38.75d | 2000-11-17 | 2000-12-12 | 1.25d | 495.5d | 0d |  |  |  |  |  |
| 192 | 6.2.2 | Kabel, Signale, Magnete usw. bestellen und liefern |  | 26.25d | 2001-01-07 | 2001-02-05 | 191FS+10d | 2001-01-07 | 2001-02-05 | 0d? | 495.5d | 0d |  |  |  |  |  |
| 193 | 6.2.3 | Kabel ziehen |  | 13.75d | 2001-01-12 | 2001-01-29 | 192SS+6.25d | 2001-01-12 | 2001-01-29 | 6.25d | 495.5d | 0d | start no earlier than 2000-07-01 |  |  |  |  |
| 194 | 6.2.4 | Kabelarbeiten |  | 7.5d | 2001-01-29 | 2001-02-06 | 193 | 2001-01-29 | 2001-02-06 | 17.5d | 516.75d | 0d | start no earlier than 2000-08-06 |  |  |  |  |
| 195 | 6.2.5 | Magnete montieren |  | 5d | 2001-02-06 | 2001-02-12 | 194 | 2001-02-06 | 2001-02-12 | 2.5d | 516.75d |  |  |  |  |  |  |
| 196 | 6.2.6 | Signalmasten stellen |  | 6.25d | 2001-02-05 | 2001-02-12 | 191, 192 | 2001-02-05 | 2001-02-12 | 0d? | 495.5d | 0d |  |  |  |  |  |
| 197 | 6.2.7 | Signale verkabeln |  | 6.25d | 2001-02-12 | 2001-02-19 | 193, 196 | 2001-02-12 | 2001-02-19 | 0d? | 495.5d | 0d |  |  |  |  |  |
| 198 | 6.2.8 | Kabel auf Kabelendverschluß legen |  | 3.75d | 2001-01-29 | 2001-02-01 | 193 | 2001-01-29 | 2001-02-01 | 0d? | 495.5d | 0d |  |  |  |  |  |
| 199 | 6.2.9 | Versorgung 50 Hz verdrahten |  | 3.75d | 2001-02-01 | 2001-02-06 | 198 | 2001-02-01 | 2001-02-06 | 0d? | 495.5d | 0d |  |  |  |  |  |
| 200 | 6.2.10 | Relaisgruppen montieren und bestücken |  | 6.25d | 2001-02-06 | 2001-02-13 | 199 | 2001-02-06 | 2001-02-13 | 0d? | 495.5d | 0d |  |  |  |  |  |
| 201 | 6.2.11 | Zimmerkabel, Rangiervergrahtung |  | 5d | 2001-02-13 | 2001-02-19 | 200 | 2001-02-13 | 2001-02-19 | 0d? | 495.5d | 0d |  |  |  |  |  |
| 202 | 6.2.12 | Herstellen der Funktionsfähigkeit, Prüfen |  | 10d | 2001-02-19 | 2001-03-01 | 201, 197 | 2001-02-19 | 2001-03-01 | 0d? | 495.5d | 8.25d |  |  |  |  |  |
| 203 | 6.3 | Inbetriebnahme Bz 0.2. |  | 1.25d | 2001-03-10 | 2001-03-11 | 202 | 2001-03-10 | 2001-03-11 | 1.25d | 487.25d | 0d | start no earlier than 2001-03-10 | C-Monteur LST Inb.1; Monteur LST Inb. 1; C-Monteur LST Inb.2 | 24h | 1,440 |  |

| ID | WBS | Task | Type | Duration | Start | Finish | Predecessors | Baseline start | Baseline finish | Baseline duration | Total slack | Free slack | Constraint | Resources | Work | Cost | Baseline cost |
| --- | --- | --- | --- | --- | --- | --- | --- | --- | --- | --- | --- | --- | --- | --- | --- | --- | --- |
| 204 | 6.4 | **Restarbeiten Bz 0.2.** |  | 3.75d | 2001-03-11 | 2001-03-14 |  | 2001-03-11 | 2001-03-14 | 0d? | 487.25d |  |  | C-Monteur LST Inb.1 [200%]; Monteur LST Inb. 1 [200%] | 60h | 3,600 |  |
| 205 | 6.4.1 | Erstellen von handrevidierten Unterlagen |  | 3.75d | 2001-03-11 | 2001-03-14 | 203 | 2001-03-11 | 2001-03-14 | 0d? | 487.25d |  |  |  |  |  |  |
| 206 | 7 | **Bauzustand 4.** |  | 210.5d | 2000-08-21 | 2001-04-11 |  | 2000-08-21 | 2001-04-11 | 165.75d | 460.25d |  |  | Projektleiter [22%]; Sekretariat Projektbüro [22%]; 1. Bauleiter Sicherungstechn. [22%] | 3544.08h | 387,625.04 |  |
| 207 | 7.1 | **Planung** |  | 160d | 2000-08-21 | 2001-02-19 |  | 2000-08-21 | 2001-02-19 | 117.5d | 472d |  |  |  | 824h | 143,017.5 | 51,000 |
| 208 | 7.1.1 | **Außenanlagen (PT I)** |  | 101.25d | 2000-08-21 | 2000-12-04 |  | 2000-08-21 | 2000-12-04 | 81.25d | 472d |  |  | Plan PT I ETC 4. | 660h | 18,300 | 27,000 |
| 209 | 7.1.1.1 | Ausarbeitung |  | 27.5d | 2000-08-21 | 2000-09-18 |  | 2000-08-21 | 2000-09-18 | 11.25d | 472d | 0d | start no earlier than 2000-08-21 |  |  |  | 27,000 |
| 210 | 7.1.1.2 | Plausibilitätsprüfung ÖRZ |  | 2.5d | 2000-09-20 | 2000-09-22 | 209FS+2.5d | 2000-09-20 | 2000-09-22 | 6.25d | 472d | 0d |  |  |  |  |  |
| 211 | 7.1.1.3 | fachtechnische Prüfung |  | 26.25d | 2000-09-22 | 2000-10-23 | 210 | 2000-09-22 | 2000-10-23 | 27.5d | 472d | 0d | start no earlier than 2000-08-07 |  |  |  |  |
| 212 | 7.1.1.4 | Übergabe und Weiterleitung PBDE |  | 2.5d | 2000-10-25 | 2000-10-27 | 211FS+2.5d | 2000-10-25 | 2000-10-27 | 3.75d | 472d | 0d |  |  |  |  |  |
| 213 | 7.1.1.5 | Prüfung durch EBA |  | 31.25d | 2000-10-27 | 2000-11-27 | 212 | 2000-10-27 | 2000-11-27 | 26.25d | 472d | 0d |  |  |  |  |  |
| 214 | 7.1.1.6 | Weiterleitung und Übergabe PBDE |  | 6.25d | 2000-11-27 | 2000-12-04 | 213 | 2000-11-27 | 2000-12-04 | 6.25d | 569.5d |  |  |  |  |  |  |
| 215 | 7.1.1.7 | ETC (PT I EBA - freigegeben) | milestone | 0d | 2000-11-27 | 2000-11-27 | 213 | 2000-11-27 | 2000-11-27 | 0d | 472d | 0d |  |  |  |  |  |
| 216 | 7.1.2 | **Innenanlagen (PT II)** |  | 98.75d | 2000-10-25 | 2001-02-19 |  | 2000-10-25 | 2001-02-19 | 73.75d | 510.75d |  |  | Plan PT II (Siemens) 4. | 164h | 124,717.5 | 24,000 |
| 217 | 7.1.2.1 | Ausarbeitung |  | 33.75d | 2000-10-25 | 2000-11-27 | 211FS+2.5d | 2000-10-25 | 2000-11-27 | 20d | 510.75d | 0d |  |  |  |  | 24,000 |
| 218 | 7.1.2.2 | fachtechnische Prüfung |  | 23.75d | 2000-11-29 | 2001-01-06 | 217FS+2.5d | 2000-11-29 | 2001-01-06 | 20d | 510.75d | 0d |  |  |  |  |  |
| 219 | 7.1.2.3 | Übergabe und Weiterleitung PBDE |  | 2.5d | 2001-01-09 | 2001-01-11 | 218FS+2.5d | 2001-01-09 | 2001-01-11 | 1.25d | 510.75d | 0d |  |  |  |  |  |
| 220 | 7.1.2.4 | Prüfung durch EBA |  | 27.5d | 2001-01-11 | 2001-02-12 | 219 | 2001-01-11 | 2001-02-12 | 26.25d | 510.75d | 0d |  |  |  |  |  |
| 221 | 7.1.2.5 | Weiterleitung und Übergabe PBDE |  | 6.25d | 2001-02-12 | 2001-02-19 | 220 | 2001-02-12 | 2001-02-19 | 3.75d | 510.75d |  |  |  |  |  |  |
| 222 | 7.1.2.6 | Siemens (PT II EBA - freigegeben) | milestone | 0d | 2001-02-12 | 2001-02-12 | 220 | 2001-02-12 | 2001-02-12 | 0d | 517d |  |  |  |  |  |  |
| 223 | 7.2 | **Innen- und Außenanlage** |  | 72.5d | 2001-01-07 | 2001-03-26 |  | 2001-01-07 | 2001-03-26 | 51.25d | 472d |  |  | 1.C-Monteur LST [50%]; 1.MonteurMU/Kab [50%]; Erstellung BZ 4.; 2.MonteurMU/Kab [50%]; 3.MonteurMU/Kab [50%]; 4.MonteurMU/Kab [50%]; 5.MonteurMU/Kab [50%]; 6.MonteurMU/Kab [50%]; 7.MonteurMU/Kab [50%] | 2072.56h | 187,571.54 |  |
| 224 | 7.2.1 | Materialisierung |  | 18.75d | 2001-01-07 | 2001-01-26 | 215FS+26.25d | 2001-01-07 | 2001-01-26 | 1.25d | 472d | 0d |  |  |  |  |  |
| 225 | 7.2.2 | Kabel, Signale, Magnete usw. bestellen und liefern |  | 26.25d | 2001-01-31 | 2001-03-01 | 224FS+3.75d | 2001-01-31 | 2001-03-01 | 0d? | 472d | 0d |  |  |  |  |  |
| 226 | 7.2.3 | Kabel ziehen |  | 7.5d | 2001-02-07 | 2001-02-15 | 225SS+6.25d | 2001-02-07 | 2001-02-15 | 6.25d | 478.25d | 0d | start no earlier than 2000-07-01 |  |  |  |  |
| 227 | 7.2.4 | Kabelarbeiten |  | 7.5d | 2001-02-15 | 2001-02-23 | 226 | 2001-02-15 | 2001-02-23 | 17.5d | 502d | 0d | start no earlier than 2000-08-06 |  |  |  |  |
| 228 | 7.2.5 | Magnete montieren |  | 3.75d | 2001-02-23 | 2001-02-28 | 227 | 2001-02-23 | 2001-02-28 | 2.5d | 502d |  |  |  |  |  |  |
| 229 | 7.2.6 | Signalmasten stellen |  | 5d | 2001-03-01 | 2001-03-07 | 224, 225 | 2001-03-01 | 2001-03-07 | 0d? | 472d | 0d |  |  |  |  |  |
| 230 | 7.2.7 | Signale verkabeln |  | 6.25d | 2001-03-07 | 2001-03-12 | 226, 229 | 2001-03-07 | 2001-03-12 | 0d? | 472d | 0d |  |  |  |  |  |
| 231 | 7.2.8 | Kabel auf Kabelendverschluß legen |  | 2.5d | 2001-02-15 | 2001-02-19 | 226 | 2001-02-15 | 2001-02-19 | 0d? | 478.25d | 0d |  |  |  |  |  |
| 232 | 7.2.9 | Versorgung 50 Hz verdrahten |  | 3.75d | 2001-02-19 | 2001-02-22 | 231 | 2001-02-19 | 2001-02-22 | 0d? | 478.25d | 0d |  |  |  |  |  |
| 233 | 7.2.10 | Relaisgruppen montieren und bestücken |  | 6.25d | 2001-02-22 | 2001-03-01 | 232 | 2001-02-22 | 2001-03-01 | 0d? | 478.25d | 0d |  |  |  |  |  |
| 234 | 7.2.11 | Zimmerkabel, Rangiervergrahtung |  | 5d | 2001-03-01 | 2001-03-07 | 233 | 2001-03-01 | 2001-03-07 | 0d? | 478.25d | 6.25d |  |  |  |  |  |
| 235 | 7.2.12 | Herstellen der Funktionsfähigkeit, Prüfen |  | 12.5d | 2001-03-12 | 2001-03-26 | 234, 230 | 2001-03-12 | 2001-03-26 | 0d? | 472d | 11.75d |  |  |  |  |  |
| 236 | 7.3 | Inbetriebnahme Bz 4. |  | 1.25d | 2001-04-07 | 2001-04-08 | 235 | 2001-04-07 | 2001-04-08 | 1.25d | 460.25d | 0d | start no earlier than 2001-04-07 | C-Monteur LST Inb.1; Monteur LST Inb. 1; C-Monteur LST Inb.2; Monteur LST Inb. 2 | 34h | 2,040 |  |

| ID | WBS | Task | Type | Duration | Start | Finish | Predecessors | Baseline start | Baseline finish | Baseline duration | Total slack | Free slack | Constraint | Resources | Work | Cost | Baseline cost |
| --- | --- | --- | --- | --- | --- | --- | --- | --- | --- | --- | --- | --- | --- | --- | --- | --- | --- |
| 237 | 7.4 | **Restarbeiten Bz 4.** |  | 3.75d | 2001-04-08 | 2001-04-11 |  | 2001-04-08 | 2001-04-11 | 0d? | 460.25d |  |  | C-Monteur LST Inb.1 [200%]; Monteur LST Inb. 1 | 56h | 3,360 |  |
| 238 | 7.4.1 | Erstellen von handrevidierten Unterlagen |  | 3.75d | 2001-04-08 | 2001-04-11 | 236 | 2001-04-08 | 2001-04-11 | 0d? | 460.25d |  |  |  |  |  |  |
| 239 | 8 | **Bauzustand 5.1** |  | 266.75d | 2000-09-25 | 2001-07-18 |  | 2000-09-25 | 2001-07-18 | 165.75d | 370.75d |  |  | Projektleiter [16%]; Sekretariat Projektbüro [16%]; 1. Bauleiter Sicherungstechn. [16%]; 2. Bauleiter Sicherungstechnik [34%] | 3820.72h | 332,668.93 |  |
| 240 | 8.1 | **Planung** |  | 162.5d | 2000-09-25 | 2001-03-28 |  | 2000-09-25 | 2001-03-28 | 117.5d | 407.5d |  |  |  | 826h | 86,545 | 51,000 |
| 241 | 8.1.1 | **Außenanlagen (PT I)** |  | 101.25d | 2000-09-25 | 2001-01-19 |  | 2000-09-25 | 2001-01-19 | 81.25d | 407.5d |  |  | Plan PT I ETC 5.1. | 664h | 44,200 | 27,000 |
| 242 | 8.1.1.1 | Ausarbeitung |  | 26.25d | 2000-09-25 | 2000-10-23 |  | 2000-09-25 | 2000-10-23 | 11.25d | 407.5d | 0d | start no earlier than 2000-09-25 |  |  |  | 27,000 |
| 243 | 8.1.1.2 | Plausibilitätsprüfung ÖRZ |  | 2.5d | 2000-10-24 | 2000-10-25 | 242 | 2000-10-24 | 2000-10-25 | 6.25d | 407.5d | 0d |  |  |  |  |  |
| 244 | 8.1.1.3 | fachtechnische Prüfung |  | 32.5d | 2000-10-27 | 2000-11-27 | 243FS+1.25d | 2000-10-27 | 2000-11-27 | 27.5d | 407.5d | 0d | start no earlier than 2000-08-07 |  |  |  |  |
| 245 | 8.1.1.4 | Übergabe und Weiterleitung PBDE |  | 2.5d | 2000-11-29 | 2000-11-30 | 244FS+1.25d | 2000-11-29 | 2000-11-30 | 3.75d | 407.5d | 0d |  |  |  |  |  |
| 246 | 8.1.1.5 | Prüfung durch EBA |  | 28.75d | 2000-12-01 | 2001-01-12 | 245 | 2000-12-01 | 2001-01-12 | 26.25d | 407.5d | 0d |  |  |  |  |  |
| 247 | 8.1.1.6 | Weiterleitung und Übergabe PBDE |  | 6.25d | 2001-01-12 | 2001-01-19 | 246 | 2001-01-12 | 2001-01-19 | 6.25d | 536.25d |  |  |  |  |  |  |
| 248 | 8.1.1.7 | ETC (PT I EBA - freigegeben) | milestone | 0d | 2001-01-12 | 2001-01-12 | 246 | 2001-01-12 | 2001-01-12 | 0d | 407.5d | 0d |  |  |  |  |  |
| 249 | 8.1.2 | **Innenanlagen (PT II)** |  | 98.75d | 2000-11-29 | 2001-03-28 |  | 2000-11-29 | 2001-03-28 | 73.75d | 475d |  |  | Plan PT II (Siemens) 5.1. | 162h | 42,345 | 24,000 |
| 250 | 8.1.2.1 | Ausarbeitung |  | 31.25d | 2000-11-29 | 2001-01-12 | 244FS+1.25d | 2000-11-29 | 2001-01-12 | 20d | 475d | 0d |  |  |  |  | 24,000 |
| 251 | 8.1.2.2 | fachtechnische Prüfung |  | 28.75d | 2001-01-16 | 2001-02-16 | 250FS+2.5d | 2001-01-16 | 2001-02-16 | 20d | 475d | 0d |  |  |  |  |  |
| 252 | 8.1.2.3 | Übergabe und Weiterleitung PBDE |  | 2.5d | 2001-02-19 | 2001-02-21 | 251FS+1.25d | 2001-02-19 | 2001-02-21 | 1.25d | 475d | 0d |  |  |  |  |  |
| 253 | 8.1.2.4 | Prüfung durch EBA |  | 26.25d | 2001-02-21 | 2001-03-21 | 252 | 2001-02-21 | 2001-03-21 | 26.25d | 475d | 0d |  |  |  |  |  |
| 254 | 8.1.2.5 | Weiterleitung und Übergabe PBDE |  | 6.25d | 2001-03-21 | 2001-03-28 | 253 | 2001-03-21 | 2001-03-28 | 3.75d | 475d |  |  |  |  |  |  |
| 255 | 8.1.2.6 | Siemens (PT II EBA - freigegeben) | milestone | 0d | 2001-03-21 | 2001-03-21 | 253 | 2001-03-21 | 2001-03-21 | 0d | 481.25d |  |  |  |  |  |  |
| 256 | 8.2 | **Innen- und Außenanlage** |  | 103.75d | 2001-02-12 | 2001-06-04 |  | 2001-02-12 | 2001-06-04 | 51.25d | 407.5d |  |  | 1.C-Monteur LST [136%]; 1.MonteurMU/Kab [136%]; Erstellung BZ 5.1.; 2.MonteurMU/Kab [136%]; 3.MonteurMU/Kab [136%]; 4.MonteurMU/Kab [136%]; 5.MonteurMU/Kab [136%] | 1832.08h | 155,150.33 |  |
| 257 | 8.2.1 | Materialisierung |  | 31.25d | 2001-02-12 | 2001-03-16 | 248FS+26.25d | 2001-02-12 | 2001-03-16 | 1.25d | 407.5d | 0d |  |  |  |  |  |
| 258 | 8.2.2 | Kabel, Signale, Magnete usw. bestellen und liefern |  | 37.5d | 2001-03-21 | 2001-04-30 | 257FS+3.75d | 2001-03-21 | 2001-04-30 | 0d? | 407.5d | 0d |  |  |  |  |  |
| 259 | 8.2.3 | Kabel ziehen |  | 7.5d | 2001-03-28 | 2001-04-05 | 258SS+6.25d | 2001-03-28 | 2001-04-05 | 6.25d | 426.25d | 0d | start no earlier than 2000-07-01 |  |  |  |  |
| 260 | 8.2.4 | Kabelarbeiten |  | 6.25d | 2001-04-05 | 2001-04-10 | 259 | 2001-04-05 | 2001-04-10 | 17.5d | 455d | 0d | start no earlier than 2000-08-06 |  |  |  |  |
| 261 | 8.2.5 | Magnete montieren |  | 6.25d | 2001-04-10 | 2001-04-17 | 260 | 2001-04-10 | 2001-04-17 | 2.5d | 455d |  |  |  |  |  |  |
| 262 | 8.2.6 | Signalmasten stellen |  | 6.25d | 2001-04-30 | 2001-05-07 | 257, 258 | 2001-04-30 | 2001-05-07 | 0d? | 407.5d | 0d |  |  |  |  |  |
| 263 | 8.2.7 | Signale verkabeln |  | 6.25d | 2001-05-07 | 2001-05-14 | 259, 262 | 2001-05-07 | 2001-05-14 | 0d? | 407.5d | 0d |  |  |  |  |  |
| 264 | 8.2.8 | Kabel auf Kabelendverschluß legen |  | 3.75d | 2001-04-05 | 2001-04-08 | 259 | 2001-04-05 | 2001-04-08 | 0d? | 426.25d | 0d |  |  |  |  |  |
| 265 | 8.2.9 | Versorgung 50 Hz verdrahten |  | 3.75d | 2001-04-08 | 2001-04-11 | 264 | 2001-04-08 | 2001-04-11 | 0d? | 426.25d | 0d |  |  |  |  |  |
| 266 | 8.2.10 | Relaisgruppen montieren und bestücken |  | 6.25d | 2001-04-11 | 2001-04-18 | 265 | 2001-04-11 | 2001-04-18 | 0d? | 426.25d | 0d |  |  |  |  |  |
| 267 | 8.2.11 | Zimmerkabel, Rangiervergrahtung |  | 3.75d | 2001-04-18 | 2001-04-23 | 266 | 2001-04-18 | 2001-04-23 | 0d? | 426.25d | 18.75d |  |  |  |  |  |
| 268 | 8.2.12 | Herstellen der Funktionsfähigkeit, Prüfen |  | 18.75d | 2001-05-14 | 2001-06-04 | 267, 263 | 2001-05-14 | 2001-06-04 | 0d? | 407.5d | 36.75d |  |  |  |  |  |
| 269 | 8.3 | Inbetriebnahme Bz 5.1. |  | 1.25d | 2001-07-14 | 2001-07-15 | 268 | 2001-07-14 | 2001-07-14 | 1.25d | 370.75d | 0d | start no earlier than 2001-07-14 | C-Monteur LST Inb.1; Monteur LST Inb. 1; C-Monteur LST Inb.2 | 24h | 1,440 |  |

| ID | WBS | Task | Type | Duration | Start | Finish | Predecessors | Baseline start | Baseline finish | Baseline duration | Total slack | Free slack | Constraint | Resources | Work | Cost | Baseline cost |
| --- | --- | --- | --- | --- | --- | --- | --- | --- | --- | --- | --- | --- | --- | --- | --- | --- | --- |
| 270 | 8.4 | **Restarbeiten Bz 5.1.** |  | 3.75d | 2001-07-15 | 2001-07-18 |  | 2001-07-15 | 2001-07-18 | 0d? | 370.75d |  |  | C-Monteur LST Inb.1; Monteur LST Inb. 1 [200%] | 56h | 3,360 |  |
| 271 | 8.4.1 | Erstellen von handrevidierten Unterlagen |  | 3.75d | 2001-07-15 | 2001-07-18 | 269 | 2001-07-15 | 2001-07-18 | 0d? | 370.75d |  |  |  |  |  |  |
| 272 | 9 | **Bauzustand 5.2.** |  | 250d | 2000-10-23 | 2001-07-25 |  | 2000-10-23 | 2001-07-25 | 165.75d | 362.5d |  |  | Projektleiter [20%]; 1. Bauleiter Sicherungstechn. [20%]; Sekretariat Projektbüro [20%] | 3164.56h | 251,544.33 |  |
| 273 | 9.1 | **Planung** |  | 172.5d | 2000-10-23 | 2001-05-03 |  | 2000-10-23 | 2001-05-03 | 117.5d | 382.5d |  |  |  | 874h | 67,310 | 51,000 |
| 274 | 9.1.1 | **Außenanlagen (PT I)** |  | 108.75d | 2000-10-23 | 2001-02-26 |  | 2000-10-23 | 2001-02-26 | 81.25d | 382.5d |  |  | Plan PT I ETC 5.2. | 712h | 32,300 | 27,000 |
| 275 | 9.1.1.1 | Ausarbeitung |  | 30d | 2000-10-23 | 2000-11-20 |  | 2000-10-23 | 2000-11-20 | 11.25d | 382.5d | 0d | start no earlier than 2000-10-23 |  |  |  | 27,000 |
| 276 | 9.1.1.2 | Plausibilitätsprüfung ÖRZ |  | 2.5d | 2000-11-22 | 2000-11-24 | 275FS+2.5d | 2000-11-22 | 2000-11-24 | 6.25d | 382.5d | 0d |  |  |  |  |  |
| 277 | 9.1.1.3 | fachtechnische Prüfung |  | 36.25d | 2000-11-24 | 2001-01-15 | 276 | 2000-11-24 | 2001-01-15 | 27.5d | 382.5d | 0d | start no earlier than 2000-08-07 |  |  |  |  |
| 278 | 9.1.1.4 | Übergabe und Weiterleitung PBDE |  | 2.5d | 2001-01-17 | 2001-01-19 | 277FS+2.5d | 2001-01-17 | 2001-01-19 | 3.75d | 382.5d | 0d |  |  |  |  |  |
| 279 | 9.1.1.5 | Prüfung durch EBA |  | 26.25d | 2001-01-19 | 2001-02-19 | 278 | 2001-01-19 | 2001-02-19 | 26.25d | 382.5d | 0d |  |  |  |  |  |
| 280 | 9.1.1.6 | Weiterleitung und Übergabe PBDE |  | 6.25d | 2001-02-19 | 2001-02-26 | 279 | 2001-02-19 | 2001-02-26 | 6.25d | 503.75d |  |  |  |  |  |  |
| 281 | 9.1.1.7 | ETC (PT I EBA - freigegeben) | milestone | 0d | 2001-02-19 | 2001-02-19 | 279 | 2001-02-19 | 2001-02-19 | 0d | 382.5d | 0d |  |  |  |  |  |
| 282 | 9.1.2 | **Innenanlagen (PT II)** |  | 98.75d | 2001-01-17 | 2001-05-03 |  | 2001-01-17 | 2001-05-03 | 73.75d | 440d |  |  | Plan PT II (Siemens) 5.2. | 162h | 35,010 | 24,000 |
| 283 | 9.1.2.1 | Ausarbeitung |  | 28.75d | 2001-01-17 | 2001-02-19 | 277FS+2.5d | 2001-01-17 | 2001-02-19 | 20d | 440d | 0d |  |  |  |  | 24,000 |
| 284 | 9.1.2.2 | fachtechnische Prüfung |  | 26.25d | 2001-02-21 | 2001-03-21 | 283FS+2.5d | 2001-02-21 | 2001-03-21 | 20d | 440d | 0d |  |  |  |  |  |
| 285 | 9.1.2.3 | Übergabe und Weiterleitung PBDE |  | 1.25d | 2001-03-23 | 2001-03-26 | 284FS+2.5d | 2001-03-23 | 2001-03-26 | 1.25d | 440d | 0d |  |  |  |  |  |
| 286 | 9.1.2.4 | Prüfung durch EBA |  | 31.25d | 2001-03-26 | 2001-04-26 | 285 | 2001-03-26 | 2001-04-26 | 26.25d | 440d | 0d |  |  |  |  |  |
| 287 | 9.1.2.5 | Weiterleitung und Übergabe PBDE |  | 6.25d | 2001-04-26 | 2001-05-03 | 286 | 2001-04-26 | 2001-05-03 | 3.75d | 440d |  |  |  |  |  |  |
| 288 | 9.1.2.6 | Siemens (PT II EBA - freigegeben) | milestone | 0d | 2001-04-26 | 2001-04-26 | 286 | 2001-04-26 | 2001-04-26 | 0d | 446.25d |  |  |  |  |  |  |
| 289 | 9.2 | **Innen- und Außenanlage** |  | 96.25d | 2001-03-19 | 2001-07-02 |  | 2001-03-19 | 2001-07-02 | 51.25d | 382.5d |  |  | 1.C-Monteur LST [40%]; 1.MonteurMU/Kab [40%]; Erstellung BZ 5.2.; 2.MonteurMU/Kab [50%]; 3.MonteurMU/Kab [50%]; 4.MonteurMU/Kab [50%] | 1620.8h | 124,593.53 |  |
| 290 | 9.2.1 | Materialisierung |  | 26.25d | 2001-03-19 | 2001-04-13 | 281FS+26.25d | 2001-03-19 | 2001-04-13 | 1.25d | 382.5d | 0d |  |  |  |  |  |
| 291 | 9.2.2 | Kabel, Signale, Magnete usw. bestellen und liefern |  | 26.25d | 2001-04-18 | 2001-05-17 | 290FS+3.75d | 2001-04-18 | 2001-05-17 | 0d? | 382.5d | 0d |  |  |  |  |  |
| 292 | 9.2.3 | Kabel ziehen |  | 12.5d | 2001-04-25 | 2001-05-09 | 291SS+6.25d | 2001-04-25 | 2001-05-09 | 6.25d | 382.5d | 0d | start no earlier than 2000-07-01 |  |  |  |  |
| 293 | 9.2.4 | Kabelarbeiten |  | 6.25d | 2001-05-09 | 2001-05-16 | 292 | 2001-05-09 | 2001-05-16 | 17.5d | 422.5d | 0d | start no earlier than 2000-08-06 |  |  |  |  |
| 294 | 9.2.5 | Magnete montieren |  | 6.25d | 2001-05-16 | 2001-05-23 | 293 | 2001-05-16 | 2001-05-23 | 2.5d | 422.5d |  |  |  |  |  |  |
| 295 | 9.2.6 | Signalmasten stellen |  | 6.25d | 2001-05-17 | 2001-05-24 | 290, 291 | 2001-05-17 | 2001-05-24 | 0d? | 391.25d | 0d |  |  |  |  |  |
| 296 | 9.2.7 | Signale verkabeln |  | 6.25d | 2001-05-24 | 2001-05-31 | 292, 295 | 2001-05-24 | 2001-05-31 | 0d? | 391.25d | 8.75d |  |  |  |  |  |
| 297 | 9.2.8 | Kabel auf Kabelendverschluß legen |  | 3.75d | 2001-05-09 | 2001-05-14 | 292 | 2001-05-09 | 2001-05-14 | 0d? | 382.5d | 0d |  |  |  |  |  |
| 298 | 9.2.9 | Versorgung 50 Hz verdrahten |  | 6.25d | 2001-05-14 | 2001-05-21 | 297 | 2001-05-14 | 2001-05-21 | 0d? | 382.5d | 0d |  |  |  |  |  |
| 299 | 9.2.10 | Relaisgruppen montieren und bestücken |  | 12.5d | 2001-05-21 | 2001-06-04 | 298 | 2001-05-21 | 2001-06-04 | 0d? | 382.5d | 0d |  |  |  |  |  |
| 300 | 9.2.11 | Zimmerkabel, Rangiervergrahtung |  | 6.25d | 2001-06-04 | 2001-06-11 | 299 | 2001-06-04 | 2001-06-11 | 0d? | 382.5d | 0d |  |  |  |  |  |
| 301 | 9.2.12 | Herstellen der Funktionsfähigkeit, Prüfen |  | 18.75d | 2001-06-11 | 2001-07-02 | 300, 296 | 2001-06-11 | 2001-07-02 | 0d? | 382.5d | 20d |  |  |  |  |  |
| 302 | 9.3 | Inbetriebnahme Bz 5.2. |  | 1.25d | 2001-07-21 | 2001-07-22 | 301 | 2001-07-21 | 2001-07-22 | 1.25d | 362.5d | 0d | start no earlier than 2001-07-21 | C-Monteur LST Inb.1; Monteur LST Inb. 1; C-Monteur LST Inb.2; Monteur LST Inb. 2 | 34h | 2,040 |  |

| ID | WBS | Task | Type | Duration | Start | Finish | Predecessors | Baseline start | Baseline finish | Baseline duration | Total slack | Free slack | Constraint | Resources | Work | Cost | Baseline cost |
| --- | --- | --- | --- | --- | --- | --- | --- | --- | --- | --- | --- | --- | --- | --- | --- | --- | --- |
| 303 | 9.4 | **Restarbeiten Bz 5.2.** |  | 3.75d | 2001-07-22 | 2001-07-25 |  | 2001-07-22 | 2001-07-25 | 0d? | 362.5d |  |  | C-Monteur LST Inb.1; Monteur LST Inb. 1 | 52h | 3,120 |  |
| 304 | 9.4.1 | Erstellen von handrevidierten Unterlagen |  | 3.75d | 2001-07-22 | 2001-07-25 | 302 | 2001-07-22 | 2001-07-25 | 0d? | 362.5d |  |  |  |  |  |  |
| 305 | 10 | **Bauzustand 5.3.** |  | 212.75d | 2000-11-20 | 2001-07-18 |  | 2000-11-20 | 2001-07-18 | 165.75d | 370.75d |  |  | Projektleiter [16%]; Sekretariat Projektbüro [16%]; 1. Bauleiter Sicherungstechn. [16%] | 1332.32h | 125,852.73 |  |
| 306 | 10.1 | **Planung** |  | 165d | 2000-11-20 | 2001-05-28 |  | 2000-11-20 | 2001-05-28 | 117.5d | 373.5d |  |  |  |  |  | 51,000 |
| 307 | 10.1.1 | **Außenanlagen (PT I)** |  | 93.75d | 2000-11-20 | 2001-03-12 |  | 2000-11-20 | 2001-03-12 | 81.25d | 373.5d |  |  |  |  |  | 27,000 |
| 308 | 10.1.1.1 | Ausarbeitung |  | 28.75d | 2000-11-20 | 2000-12-18 |  | 2000-11-20 | 2000-12-18 | 11.25d | 373.5d | 0d | start no earlier than 2000-11-20 |  |  |  | 27,000 |
| 309 | 10.1.1.2 | Plausibilitätsprüfung ÖRZ |  | 2.5d | 2000-12-18 | 2000-12-20 | 308 | 2000-12-18 | 2000-12-20 | 6.25d | 373.5d | 0d |  |  |  |  |  |
| 310 | 10.1.1.3 | fachtechnische Prüfung |  | 25d | 2000-12-20 | 2001-01-30 | 309 | 2000-12-20 | 2001-01-30 | 27.5d | 373.5d | 0d | start no earlier than 2000-08-07 |  |  |  |  |
| 311 | 10.1.1.4 | Übergabe und Weiterleitung PBDE |  | 1.25d | 2001-02-01 | 2001-02-01 | 310FS+1.25d | 2001-02-01 | 2001-02-01 | 3.75d | 373.5d | 0d |  |  |  |  |  |
| 312 | 10.1.1.5 | Prüfung durch EBA |  | 27.5d | 2001-02-02 | 2001-03-05 | 311 | 2001-02-02 | 2001-03-05 | 26.25d | 373.5d | 0d |  |  |  |  |  |
| 313 | 10.1.1.6 | Weiterleitung und Übergabe PBDE |  | 7.5d | 2001-03-06 | 2001-03-12 | 312 | 2001-03-06 | 2001-03-12 | 6.25d | 489.75d |  |  |  |  |  |  |
| 314 | 10.1.1.7 | ETC (PT I EBA - freigegeben) | milestone | 0d | 2001-03-05 | 2001-03-05 | 312 | 2001-03-05 | 2001-03-05 | 0d | 373.5d | 0d |  |  |  |  |  |
| 315 | 10.1.2 | **Innenanlagen (PT II)** |  | 107.5d | 2001-02-01 | 2001-05-28 |  | 2001-02-01 | 2001-05-28 | 73.75d | 418.5d |  |  |  |  |  | 24,000 |
| 316 | 10.1.2.1 | Ausarbeitung |  | 36.25d | 2001-02-01 | 2001-03-12 | 310FS+1.25d | 2001-02-01 | 2001-03-12 | 20d | 418.5d | 0d |  |  |  |  | 24,000 |
| 317 | 10.1.2.2 | fachtechnische Prüfung |  | 31.25d | 2001-03-14 | 2001-04-16 | 316FS+2.5d | 2001-03-14 | 2001-04-16 | 20d | 418.5d | 0d |  |  |  |  |  |
| 318 | 10.1.2.3 | Übergabe und Weiterleitung PBDE |  | 1.25d | 2001-04-17 | 2001-04-18 | 317FS+1.25d | 2001-04-17 | 2001-04-18 | 1.25d | 418.5d | 0d |  |  |  |  |  |
| 319 | 10.1.2.4 | Prüfung durch EBA |  | 26.25d | 2001-04-20 | 2001-05-21 | 318FS+2.5d | 2001-04-20 | 2001-05-21 | 26.25d | 418.5d | 0d |  |  |  |  |  |
| 320 | 10.1.2.5 | Weiterleitung und Übergabe PBDE |  | 6.25d | 2001-05-21 | 2001-05-28 | 319 | 2001-05-21 | 2001-05-28 | 3.75d | 418.5d |  |  |  |  |  |  |
| 321 | 10.1.2.6 | Siemens (PT II EBA - freigegeben) | milestone | 0d | 2001-05-21 | 2001-05-21 | 319 | 2001-05-21 | 2001-05-21 | 0d | 424.75d |  |  |  |  |  |  |
| 322 | 10.2 | **Innen- und Außenanlage** |  | 92.5d | 2001-04-02 | 2001-07-11 |  | 2001-04-02 | 2001-07-11 | 51.25d | 373.5d |  |  | 1.C-Monteur LST [45.3%]; 1.MonteurMU/Kab [45.3%]; Erstellung BZ 5.3. | 764.08h | 74,270.33 |  |
| 323 | 10.2.1 | Materialisierung |  | 26.25d | 2001-04-02 | 2001-04-27 | 314FS+26.25d | 2001-04-02 | 2001-04-27 | 1.25d | 373.5d | 0d |  |  |  |  |  |
| 324 | 10.2.2 | Kabel, Signale, Magnete usw. bestellen und liefern |  | 37.5d | 2001-05-02 | 2001-06-13 | 323FS+3.75d | 2001-05-02 | 2001-06-13 | 0d? | 373.5d | 0d |  |  |  |  |  |
| 325 | 10.2.3 | Kabel ziehen |  | 12.5d | 2001-05-09 | 2001-05-23 | 324SS+6.25d | 2001-05-09 | 2001-05-23 | 6.25d | 384.75d | 0d | start no earlier than 2000-07-01 |  |  |  |  |
| 326 | 10.2.4 | Kabelarbeiten |  | 6.25d | 2001-05-23 | 2001-05-30 | 325 | 2001-05-23 | 2001-05-30 | 17.5d | 409.75d | 0d | start no earlier than 2000-08-06 |  |  |  |  |
| 327 | 10.2.5 | Magnete montieren |  | 6.25d | 2001-05-30 | 2001-06-06 | 326 | 2001-05-30 | 2001-06-06 | 2.5d | 409.75d |  |  |  |  |  |  |
| 328 | 10.2.6 | Signalmasten stellen |  | 6.25d | 2001-06-13 | 2001-06-20 | 323, 324 | 2001-06-13 | 2001-06-20 | 0d? | 373.5d | 0d |  |  |  |  |  |
| 329 | 10.2.7 | Signale verkabeln |  | 6.25d | 2001-06-20 | 2001-06-27 | 325, 328 | 2001-06-20 | 2001-06-27 | 0d? | 373.5d | 0d |  |  |  |  |  |
| 330 | 10.2.8 | Kabel auf Kabelendverschluß legen |  | 3.75d | 2001-05-23 | 2001-05-28 | 325 | 2001-05-23 | 2001-05-28 | 0d? | 384.75d | 0d |  |  |  |  |  |
| 331 | 10.2.9 | Versorgung 50 Hz verdrahten |  | 3.75d | 2001-05-28 | 2001-05-31 | 330 | 2001-05-28 | 2001-05-31 | 0d? | 384.75d | 0d |  |  |  |  |  |
| 332 | 10.2.10 | Relaisgruppen montieren und bestücken |  | 6.25d | 2001-05-31 | 2001-06-07 | 331 | 2001-05-31 | 2001-06-07 | 0d? | 384.75d | 0d |  |  |  |  |  |
| 333 | 10.2.11 | Zimmerkabel, Rangiervergrahtung |  | 6.25d | 2001-06-07 | 2001-06-14 | 332 | 2001-06-07 | 2001-06-14 | 0d? | 384.75d | 11.25d |  |  |  |  |  |
| 334 | 10.2.12 | Herstellen der Funktionsfähigkeit, Prüfen |  | 12.5d | 2001-06-27 | 2001-07-11 | 333, 329 | 2001-06-27 | 2001-07-11 | 0d? | 373.5d | 2.75d |  |  |  |  |  |
| 335 | 10.3 | Inbetriebnahme Bz 5.3. |  | 1.25d | 2001-07-14 | 2001-07-15 | 334 | 2001-07-14 | 2001-07-15 | 1.25d | 370.75d | 0d | start no earlier than 2001-07-14 | C-Monteur LST Inb.3; Monteur LST Inb. 3 | 16h | 1,140 |  |

| ID | WBS | Task | Type | Duration | Start | Finish | Predecessors | Baseline start | Baseline finish | Baseline duration | Total slack | Free slack | Constraint | Resources | Work | Cost | Baseline cost |
| --- | --- | --- | --- | --- | --- | --- | --- | --- | --- | --- | --- | --- | --- | --- | --- | --- | --- |
| 336 | 10.4 | **Restarbeiten Bz 5.3.** |  | 3.75d | 2001-07-15 | 2001-07-18 |  | 2001-07-15 | 2001-07-18 | 0d? | 370.75d |  |  | C-Monteur LST Inb.3 [200%]; Monteur LST Inb. 3 [200%] | 60h | 4,500 |  |
| 337 | 10.4.1 | Erstellen von handrevidierten Unterlagen |  | 3.75d | 2001-07-15 | 2001-07-18 | 335 | 2001-07-15 | 2001-07-18 | 0d? | 370.75d |  |  |  |  |  |  |
| 338 | 11 | **Bauzustand 6.1.** |  | 201.25d | 2000-12-18 | 2001-08-01 |  | 2000-12-18 | 2001-08-01 | 165.75d | 354.25d |  |  | Projektleiter [22%]; Sekretariat Projektbüro [22%]; 1. Bauleiter Sicherungstechn. [22%] | 1490.16h | 126,923.13 |  |
| 339 | 11.1 | **Planung** |  | 148.75d | 2000-12-18 | 2001-06-11 |  | 2000-12-18 | 2001-06-11 | 117.5d | 354.25d |  |  |  |  |  | 51,000 |
| 340 | 11.1.1 | **Außenanlagen (PT I)** |  | 92.5d | 2000-12-18 | 2001-04-09 |  | 2000-12-18 | 2001-04-09 | 81.25d | 354.25d |  |  |  |  |  | 27,000 |
| 341 | 11.1.1.1 | Ausarbeitung |  | 20d | 2000-12-18 | 2001-01-22 |  | 2000-12-18 | 2001-01-22 | 11.25d | 354.25d | 0d | start no earlier than 2000-12-18 |  |  |  | 27,000 |
| 342 | 11.1.1.2 | Plausibilitätsprüfung ÖRZ |  | 2.5d | 2001-01-22 | 2001-01-24 | 341 | 2001-01-22 | 2001-01-24 | 6.25d | 354.25d | 0d |  |  |  |  |  |
| 343 | 11.1.1.3 | fachtechnische Prüfung |  | 26.25d | 2001-01-26 | 2001-02-26 | 342FS+2.5d | 2001-01-26 | 2001-02-26 | 27.5d | 354.25d | 0d | start no earlier than 2000-08-07 |  |  |  |  |
| 344 | 11.1.1.4 | Übergabe und Weiterleitung PBDE |  | 2.5d | 2001-02-28 | 2001-03-02 | 343FS+2.5d | 2001-02-28 | 2001-03-02 | 3.75d | 354.25d | 0d |  |  |  |  |  |
| 345 | 11.1.1.5 | Prüfung durch EBA |  | 28.75d | 2001-03-02 | 2001-04-02 | 344 | 2001-03-02 | 2001-04-02 | 26.25d | 354.25d | 0d |  |  |  |  |  |
| 346 | 11.1.1.6 | Weiterleitung und Übergabe PBDE |  | 7.5d | 2001-04-02 | 2001-04-09 | 345 | 2001-04-02 | 2001-04-09 | 6.25d | 463d |  |  |  |  |  |  |
| 347 | 11.1.1.7 | ETC (PT I EBA - freigegeben) | milestone | 0d | 2001-04-02 | 2001-04-02 | 345 | 2001-04-02 | 2001-04-02 | 0d | 354.25d | 0d |  |  |  |  |  |
| 348 | 11.1.2 | **Innenanlagen (PT II)** |  | 95d | 2001-02-28 | 2001-06-11 |  | 2001-02-28 | 2001-06-11 | 73.75d | 406.75d |  |  |  |  |  | 24,000 |
| 349 | 11.1.2.1 | Ausarbeitung |  | 27.5d | 2001-02-28 | 2001-03-28 | 343FS+2.5d | 2001-02-28 | 2001-03-28 | 20d | 406.75d | 0d |  |  |  |  | 24,000 |
| 350 | 11.1.2.2 | fachtechnische Prüfung |  | 27.5d | 2001-03-30 | 2001-04-30 | 349FS+2.5d | 2001-03-30 | 2001-04-30 | 20d | 406.75d | 0d |  |  |  |  |  |
| 351 | 11.1.2.3 | Übergabe und Weiterleitung PBDE |  | 2.5d | 2001-05-02 | 2001-05-04 | 350FS+2.5d | 2001-05-02 | 2001-05-04 | 1.25d | 406.75d | 0d |  |  |  |  |  |
| 352 | 11.1.2.4 | Prüfung durch EBA |  | 26.25d | 2001-05-04 | 2001-06-04 | 351 | 2001-05-04 | 2001-06-04 | 26.25d | 406.75d | 0d |  |  |  |  |  |
| 353 | 11.1.2.5 | Weiterleitung und Übergabe PBDE |  | 6.25d | 2001-06-04 | 2001-06-11 | 352 | 2001-06-04 | 2001-06-11 | 3.75d | 406.75d |  |  |  |  |  |  |
| 354 | 11.1.2.6 | Siemens (PT II EBA - freigegeben) | milestone | 0d | 2001-06-04 | 2001-06-04 | 352 | 2001-06-04 | 2001-06-04 | 0d | 413d |  |  |  |  |  |  |
| 355 | 11.2 | **Innen- und Außenanlage** |  | 85d | 2001-04-30 | 2001-07-27 |  | 2001-04-30 | 2001-07-27 | 51.25d | 354.25d |  |  | 1.C-Monteur LST [25%]; 1.MonteurMU/Kab [25%]; Erstellung BZ 6.1.; 2.MonteurMU/Kab [34%] | 965.92h | 80,260.73 |  |
| 356 | 11.2.1 | Materialisierung |  | 26.25d | 2001-04-30 | 2001-05-29 | 347FS+26.25d | 2001-04-30 | 2001-05-29 | 1.25d | 354.25d | 0d | start no earlier than 2000-07-31 |  |  |  |  |
| 357 | 11.2.2 | Kabel, Signale, Magnete usw. bestellen und liefern |  | 26.25d | 2001-06-01 | 2001-07-02 | 356FS+3.75d | 2001-06-01 | 2001-07-02 | 0d? | 354.25d | 0d |  |  |  |  |  |
| 358 | 11.2.3 | Kabel ziehen |  | 12.5d | 2001-06-08 | 2001-06-22 | 357SS+6.25d | 2001-06-08 | 2001-06-22 | 6.25d | 354.25d | 0d | start no earlier than 2000-07-01 |  |  |  |  |
| 359 | 11.2.4 | Kabelarbeiten |  | 6.25d | 2001-06-22 | 2001-06-29 | 358 | 2001-06-22 | 2001-06-29 | 17.5d | 383d | 0d | start no earlier than 2000-08-06 |  |  |  |  |
| 360 | 11.2.5 | Magnete montieren |  | 6.25d | 2001-06-29 | 2001-07-06 | 359 | 2001-06-29 | 2001-07-06 | 2.5d | 383d |  |  |  |  |  |  |
| 361 | 11.2.6 | Signalmasten stellen |  | 6.25d | 2001-07-02 | 2001-07-09 | 356, 357 | 2001-07-02 | 2001-07-09 | 0d? | 358d | 0d |  |  |  |  |  |
| 362 | 11.2.7 | Signale verkabeln |  | 6.25d | 2001-07-09 | 2001-07-14 | 358, 361 | 2001-07-09 | 2001-07-14 | 0d? | 358d | 3.75d |  |  |  |  |  |
| 363 | 11.2.8 | Kabel auf Kabelendverschluß legen |  | 6.25d | 2001-06-22 | 2001-06-29 | 358 | 2001-06-22 | 2001-06-29 | 0d? | 354.25d | 0d |  |  |  |  |  |
| 364 | 11.2.9 | Versorgung 50 Hz verdrahten |  | 6.25d | 2001-06-29 | 2001-07-06 | 363 | 2001-06-29 | 2001-07-06 | 0d? | 354.25d | 0d |  |  |  |  |  |
| 365 | 11.2.10 | Relaisgruppen montieren und bestücken |  | 6.25d | 2001-07-06 | 2001-07-13 | 364 | 2001-07-06 | 2001-07-13 | 0d? | 354.25d | 0d |  |  |  |  |  |
| 366 | 11.2.11 | Zimmerkabel, Rangiervergrahtung |  | 5d | 2001-07-13 | 2001-07-17 | 365 | 2001-07-13 | 2001-07-17 | 0d? | 354.25d | 0d |  |  |  |  |  |
| 367 | 11.2.12 | Herstellen der Funktionsfähigkeit, Prüfen |  | 12.5d | 2001-07-17 | 2001-07-27 | 366, 362 | 2001-07-17 | 2001-07-27 | 0d? | 354.25d | 0d |  |  |  |  |  |
| 368 | 11.3 | Inbetriebnahme Bz 6.1. |  | 1.25d | 2001-07-28 | 2001-07-29 | 367 | 2001-07-28 | 2001-07-29 | 1.25d | 354.25d | 0d | start no earlier than 2000-11-18 | C-Monteur LST Inb.1; Monteur LST Inb. 1 | 16h | 960 |  |

| ID | WBS | Task | Type | Duration | Start | Finish | Predecessors | Baseline start | Baseline finish | Baseline duration | Total slack | Free slack | Constraint | Resources | Work | Cost | Baseline cost |
| --- | --- | --- | --- | --- | --- | --- | --- | --- | --- | --- | --- | --- | --- | --- | --- | --- | --- |
| 369 | 11.4 | **Restarbeiten Bz 6.1.** |  | 3.75d | 2001-07-29 | 2001-08-01 |  | 2001-07-29 | 2001-08-01 | 0d? | 354.25d |  |  | C-Monteur LST Inb.1; Monteur LST Inb. 1 | 52h | 3,120 |  |
| 370 | 11.4.1 | Erstellen von handrevidierten Unterlagen |  | 3.75d | 2001-07-29 | 2001-08-01 | 368 | 2001-07-29 | 2001-08-01 | 0d? | 354.25d |  |  |  |  |  |  |
| 371 | 12 | **Bauzustand 6.2.** |  | 190d | 2001-01-22 | 2001-08-08 |  | 2001-01-22 | 2001-08-08 | 165.75d | 346d |  |  | Projektleiter [24%]; Sekretariat Projektbüro [24%]; 1. Bauleiter Sicherungstechn. [24%]; 2. Bauleiter Sicherungstechnik [20%] | 1614.16h | 159,555.13 |  |
| 372 | 12.1 | **Planung** |  | 158.75d | 2001-01-22 | 2001-07-12 |  | 2001-01-22 | 2001-07-12 | 117.5d | 346d |  |  |  |  |  | 51,000 |
| 373 | 12.1.1 | **Außenanlagen (PT I)** |  | 98.75d | 2001-01-22 | 2001-05-07 |  | 2001-01-22 | 2001-05-07 | 81.25d | 346d |  |  |  |  |  | 27,000 |
| 374 | 12.1.1.1 | Ausarbeitung |  | 26.25d | 2001-01-22 | 2001-02-19 |  | 2001-01-22 | 2001-02-19 | 11.25d | 346d | 0d | start no earlier than 2001-01-22 |  |  |  | 27,000 |
| 375 | 12.1.1.2 | Plausibilitätsprüfung ÖRZ |  | 2.5d | 2001-02-20 | 2001-02-21 | 374 | 2001-02-20 | 2001-02-21 | 6.25d | 346d | 0d |  |  |  |  |  |
| 376 | 12.1.1.3 | fachtechnische Prüfung |  | 27.5d | 2001-02-23 | 2001-03-23 | 375FS+1.25d | 2001-02-23 | 2001-03-23 | 27.5d | 346d | 0d |  |  |  |  |  |
| 377 | 12.1.1.4 | Übergabe und Weiterleitung PBDE |  | 2.5d | 2001-03-26 | 2001-03-28 | 376FS+1.25d | 2001-03-26 | 2001-03-28 | 3.75d | 346d | 0d |  |  |  |  |  |
| 378 | 12.1.1.5 | Prüfung durch EBA |  | 31.25d | 2001-03-28 | 2001-04-30 | 377 | 2001-03-28 | 2001-04-30 | 26.25d | 346d | 0d |  |  |  |  |  |
| 379 | 12.1.1.6 | Weiterleitung und Übergabe PBDE |  | 6.25d | 2001-04-30 | 2001-05-07 | 378 | 2001-04-30 | 2001-05-07 | 6.25d | 437.25d |  |  |  |  |  |  |
| 380 | 12.1.1.7 | ETC (PT I EBA - freigegeben) | milestone | 0d | 2001-04-30 | 2001-04-30 | 378 | 2001-04-30 | 2001-04-30 | 0d | 346d | 0d |  |  |  |  |  |
| 381 | 12.1.2 | **Innenanlagen (PT II)** |  | 100d | 2001-03-26 | 2001-07-12 |  | 2001-03-26 | 2001-07-12 | 73.75d | 377.25d |  |  |  |  |  | 24,000 |
| 382 | 12.1.2.1 | Ausarbeitung |  | 31.25d | 2001-03-26 | 2001-04-26 | 376FS+1.25d | 2001-03-26 | 2001-04-26 | 20d | 377.25d | 0d |  |  |  |  | 24,000 |
| 383 | 12.1.2.2 | fachtechnische Prüfung |  | 27.5d | 2001-04-30 | 2001-05-30 | 382FS+2.5d | 2001-04-30 | 2001-05-30 | 20d | 377.25d | 0d |  |  |  |  |  |
| 384 | 12.1.2.3 | Übergabe und Weiterleitung PBDE |  | 2.5d | 2001-06-01 | 2001-06-05 | 383FS+2.5d | 2001-06-01 | 2001-06-05 | 1.25d | 377.25d | 0d |  |  |  |  |  |
| 385 | 12.1.2.4 | Prüfung durch EBA |  | 27.5d | 2001-06-05 | 2001-07-05 | 384 | 2001-06-05 | 2001-07-05 | 26.25d | 377.25d | 0d |  |  |  |  |  |
| 386 | 12.1.2.5 | Weiterleitung und Übergabe PBDE |  | 6.25d | 2001-07-05 | 2001-07-12 | 385 | 2001-07-05 | 2001-07-12 | 3.75d | 377.25d |  |  |  |  |  |  |
| 387 | 12.1.2.6 | Siemens (PT II EBA - freigegeben) | milestone | 0d | 2001-07-05 | 2001-07-05 | 385 | 2001-07-05 | 2001-07-05 | 0d | 383.5d |  |  |  |  |  |  |
| 388 | 12.2 | **Innen- und Außenanlage** |  | 66.25d | 2001-05-29 | 2001-08-03 |  | 2001-05-29 | 2001-08-03 | 51.25d | 346d |  |  | 1.C-Monteur LST [80%]; 1.MonteurMU/Kab [80%]; Erstellung BZ 6.2.; 2.MonteurMU/Kab; 3.MonteurMU/Kab [136%]; 4.MonteurMU/Kab [136%] | 825.76h | 98,371.13 |  |
| 389 | 12.2.1 | Materialisierung |  | 12.5d | 2001-05-29 | 2001-06-12 | 380FS+26.25d | 2001-05-29 | 2001-06-12 | 1.25d | 346d | 0d |  |  |  |  |  |
| 390 | 12.2.2 | Kabel, Signale, Magnete usw. bestellen und liefern |  | 26.25d | 2001-06-15 | 2001-07-14 | 389FS+3.75d | 2001-06-15 | 2001-07-14 | 0d? | 346d | 0d |  |  |  |  |  |
| 391 | 12.2.3 | Kabel ziehen |  | 6.25d | 2001-06-22 | 2001-06-29 | 390SS+6.25d | 2001-06-22 | 2001-06-29 | 6.25d | 346d | 0d | start no earlier than 2000-07-01 |  |  |  |  |
| 392 | 12.2.4 | Kabelarbeiten |  | 5d | 2001-06-29 | 2001-07-05 | 391 | 2001-06-29 | 2001-07-05 | 17.5d | 377.25d | 0d | start no earlier than 2000-08-06 |  |  |  |  |
| 393 | 12.2.5 | Magnete montieren |  | 6.25d | 2001-07-05 | 2001-07-12 | 392 | 2001-07-05 | 2001-07-12 | 2.5d | 377.25d |  |  |  |  |  |  |
| 394 | 12.2.6 | Signalmasten stellen |  | 3.75d | 2001-07-15 | 2001-07-18 | 389, 390 | 2001-07-15 | 2001-07-18 | 0d? | 347.25d | 0d |  |  |  |  |  |
| 395 | 12.2.7 | Signale verkabeln |  | 6.25d | 2001-07-18 | 2001-07-23 | 391, 394 | 2001-07-18 | 2001-07-23 | 0d? | 347.25d | 1.25d |  |  |  |  |  |
| 396 | 12.2.8 | Kabel auf Kabelendverschluß legen |  | 6.25d | 2001-06-29 | 2001-07-06 | 391 | 2001-06-29 | 2001-07-06 | 0d? | 346d | 0d |  |  |  |  |  |
| 397 | 12.2.9 | Versorgung 50 Hz verdrahten |  | 6.25d | 2001-07-06 | 2001-07-13 | 396 | 2001-07-06 | 2001-07-13 | 0d? | 346d | 0d |  |  |  |  |  |
| 398 | 12.2.10 | Relaisgruppen montieren und bestücken |  | 6.25d | 2001-07-13 | 2001-07-19 | 397 | 2001-07-13 | 2001-07-19 | 0d? | 346d | 0d |  |  |  |  |  |
| 399 | 12.2.11 | Zimmerkabel, Rangiervergrahtung |  | 6.25d | 2001-07-19 | 2001-07-24 | 398 | 2001-07-19 | 2001-07-24 | 0d? | 346d | 0d |  |  |  |  |  |
| 400 | 12.2.12 | Herstellen der Funktionsfähigkeit, Prüfen |  | 12.5d | 2001-07-24 | 2001-08-03 | 399, 395 | 2001-07-24 | 2001-08-03 | 0d? | 346d | 0d |  |  |  |  |  |
| 401 | 12.3 | Inbetriebnahme Bz 6.2. |  | 1.25d | 2001-08-04 | 2001-08-05 | 400 | 2001-08-04 | 2001-08-05 | 1.25d | 346d | 0d | start no earlier than 2000-11-18 | C-Monteur LST Inb.1; Monteur LST Inb. 1 [200%] | 18h | 1,080 |  |

| ID | WBS | Task | Type | Duration | Start | Finish | Predecessors | Baseline start | Baseline finish | Baseline duration | Total slack | Free slack | Constraint | Resources | Work | Cost | Baseline cost |
| --- | --- | --- | --- | --- | --- | --- | --- | --- | --- | --- | --- | --- | --- | --- | --- | --- | --- |
| 402 | 12.4 | **Restarbeiten Bz 6.2.** |  | 3.75d | 2001-08-05 | 2001-08-08 |  | 2001-08-05 | 2001-08-08 | 0d? | 346d |  |  | C-Monteur LST Inb.1; Monteur LST Inb. 1 | 50h | 3,000 |  |
| 403 | 12.4.1 | Erstellen von handrevidierten Unterlagen |  | 3.75d | 2001-08-05 | 2001-08-08 | 401 | 2001-08-05 | 2001-08-08 | 0d? | 346d |  |  |  |  |  |  |
| 404 | 13 | **Bauzustand 8.** |  | 173.25d | 2001-02-19 | 2001-08-15 |  | 2001-02-19 | 2001-08-15 | 165.75d | 337.75d |  |  | Projektleiter [28%]; Sekretariat Projektbüro [28%]; 1. Bauleiter Sicherungstechn. [28%] | 1525.2h | 153,681.53 |  |
| 405 | 13.1 | **Planung** |  | 142.5d | 2001-02-19 | 2001-07-20 |  | 2001-02-19 | 2001-07-20 | 117.5d | 339.75d |  |  |  |  |  | 51,000 |
| 406 | 13.1.1 | **Außenanlagen (PT I)** |  | 92.5d | 2001-02-19 | 2001-05-28 |  | 2001-02-19 | 2001-05-28 | 81.25d | 339.75d |  |  |  |  |  | 27,000 |
| 407 | 13.1.1.1 | Ausarbeitung |  | 27.5d | 2001-02-19 | 2001-03-19 |  | 2001-02-19 | 2001-03-19 | 11.25d | 339.75d | 0d | start no earlier than 2001-02-19 |  |  |  | 27,000 |
| 408 | 13.1.1.2 | Plausibilitätsprüfung ÖRZ |  | 2.5d | 2001-03-19 | 2001-03-21 | 407 | 2001-03-19 | 2001-03-21 | 6.25d | 339.75d | 0d |  |  |  |  |  |
| 409 | 13.1.1.3 | fachtechnische Prüfung |  | 22.5d | 2001-03-23 | 2001-04-16 | 408FS+2.5d | 2001-03-23 | 2001-04-16 | 27.5d | 339.75d | 0d | start no earlier than 2000-08-07 |  |  |  |  |
| 410 | 13.1.1.4 | Übergabe und Weiterleitung PBDE |  | 2.5d | 2001-04-18 | 2001-04-20 | 409FS+2.5d | 2001-04-18 | 2001-04-20 | 3.75d | 339.75d | 0d |  |  |  |  |  |
| 411 | 13.1.1.5 | Prüfung durch EBA |  | 26.25d | 2001-04-20 | 2001-05-21 | 410 | 2001-04-20 | 2001-05-21 | 26.25d | 339.75d | 0d |  |  |  |  |  |
| 412 | 13.1.1.6 | Weiterleitung und Übergabe PBDE |  | 6.25d | 2001-05-21 | 2001-05-28 | 411 | 2001-05-21 | 2001-05-28 | 6.25d | 418.5d |  |  |  |  |  |  |
| 413 | 13.1.1.7 | ETC (PT I EBA - freigegeben) | milestone | 0d | 2001-05-21 | 2001-05-21 | 411 | 2001-05-21 | 2001-05-21 | 0d | 339.75d | 0d |  |  |  |  |  |
| 414 | 13.1.2 | **Innenanlagen (PT II)** |  | 85d | 2001-04-18 | 2001-07-20 |  | 2001-04-18 | 2001-07-20 | 73.75d | 368.5d |  |  |  |  |  | 24,000 |
| 415 | 13.1.2.1 | Ausarbeitung |  | 27.5d | 2001-04-18 | 2001-05-18 | 409FS+2.5d | 2001-04-18 | 2001-05-18 | 20d | 368.5d | 0d |  |  |  |  | 24,000 |
| 416 | 13.1.2.2 | fachtechnische Prüfung |  | 18.75d | 2001-05-21 | 2001-06-11 | 415FS+1.25d | 2001-05-21 | 2001-06-11 | 20d | 368.5d | 0d |  |  |  |  |  |
| 417 | 13.1.2.3 | Übergabe und Weiterleitung PBDE |  | 2.5d | 2001-06-13 | 2001-06-15 | 416FS+2.5d | 2001-06-13 | 2001-06-15 | 1.25d | 368.5d | 0d |  |  |  |  |  |
| 418 | 13.1.2.4 | Prüfung durch EBA |  | 27.5d | 2001-06-15 | 2001-07-16 | 417 | 2001-06-15 | 2001-07-16 | 26.25d | 368.5d | 0d |  |  |  |  |  |
| 419 | 13.1.2.5 | Weiterleitung und Übergabe PBDE |  | 5d | 2001-07-16 | 2001-07-20 | 418 | 2001-07-16 | 2001-07-20 | 3.75d | 368.5d |  |  |  |  |  |  |
| 420 | 13.1.2.6 | Siemens (PT II EBA - freigegeben) | milestone | 0d | 2001-07-16 | 2001-07-16 | 418 | 2001-07-16 | 2001-07-16 | 0d | 373.5d |  |  |  |  |  |  |
| 421 | 13.2 | **Innen- und Außenanlage** |  | 53.75d | 2001-06-19 | 2001-08-09 |  | 2001-06-19 | 2001-08-09 | 51.25d | 339.75d |  |  | 1.C-Monteur LST [80%]; 1.MonteurMU/Kab [80%]; Erstellung BZ 8.; 2.MonteurMU/Kab; 3.MonteurMU/Kab [136%]; 4.MonteurMU/Kab [136%]; 5.MonteurMU/Kab | 1071.28h | 114,182.33 |  |
| 422 | 13.2.1 | Materialisierung |  | 6.25d | 2001-06-19 | 2001-06-26 | 413FS+26.25d | 2001-06-19 | 2001-06-26 | 1.25d | 339.75d | 0d |  |  |  |  |  |
| 423 | 13.2.2 | Kabel, Signale, Magnete usw. bestellen und liefern |  | 26.25d | 2001-06-29 | 2001-07-25 | 422FS+3.75d | 2001-06-29 | 2001-07-25 | 0d? | 339.75d | 0d |  |  |  |  |  |
| 424 | 13.2.3 | Kabel ziehen |  | 7.5d | 2001-07-06 | 2001-07-14 | 423SS+6.25d | 2001-07-06 | 2001-07-14 | 6.25d | 344.75d | 0d | start no earlier than 2000-07-01 |  |  |  |  |
| 425 | 13.2.4 | Kabelarbeiten |  | 3.75d | 2001-07-15 | 2001-07-18 | 424 | 2001-07-15 | 2001-07-18 | 17.5d | 367.25d | 0d | start no earlier than 2000-08-06 |  |  |  |  |
| 426 | 13.2.5 | Magnete montieren |  | 3.75d | 2001-07-18 | 2001-07-21 | 425 | 2001-07-18 | 2001-07-21 | 2.5d | 367.25d |  |  |  |  |  |  |
| 427 | 13.2.6 | Signalmasten stellen |  | 2.5d | 2001-07-25 | 2001-07-27 | 422, 423 | 2001-07-25 | 2001-07-27 | 0d? | 339.75d | 0d |  |  |  |  |  |
| 428 | 13.2.7 | Signale verkabeln |  | 5d | 2001-07-27 | 2001-07-31 | 424, 427 | 2001-07-27 | 2001-07-31 | 0d? | 339.75d | 0d |  |  |  |  |  |
| 429 | 13.2.8 | Kabel auf Kabelendverschluß legen |  | 2.5d | 2001-07-15 | 2001-07-17 | 424 | 2001-07-15 | 2001-07-17 | 0d? | 344.75d | 0d |  |  |  |  |  |
| 430 | 13.2.9 | Versorgung 50 Hz verdrahten |  | 3.75d | 2001-07-17 | 2001-07-20 | 429 | 2001-07-17 | 2001-07-20 | 0d? | 344.75d | 0d |  |  |  |  |  |
| 431 | 13.2.10 | Relaisgruppen montieren und bestücken |  | 5d | 2001-07-20 | 2001-07-24 | 430 | 2001-07-20 | 2001-07-24 | 0d? | 344.75d | 0d |  |  |  |  |  |
| 432 | 13.2.11 | Zimmerkabel, Rangiervergrahtung |  | 3.75d | 2001-07-24 | 2001-07-27 | 431 | 2001-07-24 | 2001-07-27 | 0d? | 344.75d | 5d |  |  |  |  |  |
| 433 | 13.2.12 | Herstellen der Funktionsfähigkeit, Prüfen |  | 10d | 2001-08-01 | 2001-08-09 | 432, 428 | 2001-08-01 | 2001-08-09 | 0d? | 339.75d | 2d |  |  |  |  |  |
| 434 | 13.3 | Inbetriebnahme Bz 8. |  | 1.25d | 2001-08-11 | 2001-08-12 | 433 | 2001-08-11 | 2001-08-12 | 1.25d | 337.75d | 0d | start no earlier than 2001-08-11 | C-Monteur LST Inb.1; Monteur LST Inb. 1 [200%]; C-Monteur LST Inb.2; Monteur LST Inb. 2 | 36h | 2,160 |  |

| ID | WBS | Task | Type | Duration | Start | Finish | Predecessors | Baseline start | Baseline finish | Baseline duration | Total slack | Free slack | Constraint | Resources | Work | Cost | Baseline cost |
| --- | --- | --- | --- | --- | --- | --- | --- | --- | --- | --- | --- | --- | --- | --- | --- | --- | --- |
| 435 | 13.4 | **Restarbeiten Bz 8.** |  | 3.75d | 2001-08-12 | 2001-08-15 |  | 2001-08-12 | 2001-08-15 | 0d? | 337.75d |  |  | C-Monteur LST Inb.1; Monteur LST Inb. 1 | 50h | 3,000 |  |
| 436 | 13.4.1 | Erstellen von handrevidierten Unterlagen |  | 3.75d | 2001-08-12 | 2001-08-15 | 434 | 2001-08-12 | 2001-08-15 | 0d? | 337.75d |  |  |  |  |  |  |
| 437 | 14 | **Bauzustand 9.** |  | 184.5d | 2001-03-19 | 2001-09-26 |  | 2001-03-19 | 2001-09-26 | 165.75d | 299.5d |  |  | Projektleiter [14%]; Sekretariat Projektbüro [14%]; 1. Bauleiter Sicherungstechn. [14%] | 825.36h | 107,179.13 |  |
| 438 | 14.1 | **Planung** |  | 146.25d | 2001-03-19 | 2001-08-15 |  | 2001-03-19 | 2001-08-15 | 117.5d | 326.5d |  |  |  |  |  | 51,000 |
| 439 | 14.1.1 | **Außenanlagen (PT I)** |  | 76.25d | 2001-03-19 | 2001-06-08 |  | 2001-03-19 | 2001-06-08 | 81.25d | 326.5d |  |  |  |  |  | 27,000 |
| 440 | 14.1.1.1 | Ausarbeitung |  | 13.75d | 2001-03-19 | 2001-04-02 |  | 2001-03-19 | 2001-04-02 | 11.25d | 326.5d | 0d | start no earlier than 2001-03-19 |  |  |  | 27,000 |
| 441 | 14.1.1.2 | Plausibilitätsprüfung ÖRZ |  | 2.5d | 2001-04-03 | 2001-04-04 | 440 | 2001-04-03 | 2001-04-04 | 6.25d | 326.5d | 0d |  |  |  |  |  |
| 442 | 14.1.1.3 | fachtechnische Prüfung |  | 22.5d | 2001-04-06 | 2001-04-30 | 441FS+1.25d | 2001-04-06 | 2001-04-30 | 27.5d | 326.5d | 0d | start no earlier than 2000-08-07 |  |  |  |  |
| 443 | 14.1.1.4 | Übergabe und Weiterleitung PBDE |  | 2.5d | 2001-05-02 | 2001-05-04 | 442FS+2.5d | 2001-05-02 | 2001-05-04 | 3.75d | 326.5d | 0d |  |  |  |  |  |
| 444 | 14.1.1.5 | Prüfung durch EBA |  | 26.25d | 2001-05-04 | 2001-06-04 | 443 | 2001-05-04 | 2001-06-04 | 26.25d | 326.5d | 0d |  |  |  |  |  |
| 445 | 14.1.1.6 | Weiterleitung und Übergabe PBDE |  | 5d | 2001-06-04 | 2001-06-08 | 444 | 2001-06-04 | 2001-06-08 | 6.25d | 407.75d |  |  |  |  |  |  |
| 446 | 14.1.1.7 | ETC (PT I EBA - freigegeben) | milestone | 0d | 2001-06-04 | 2001-06-04 | 444 | 2001-06-04 | 2001-06-04 | 0d | 326.5d | 0d |  |  |  |  |  |
| 447 | 14.1.2 | **Innenanlagen (PT II)** |  | 105d | 2001-05-01 | 2001-08-15 |  | 2001-05-01 | 2001-08-15 | 73.75d | 337.75d |  |  |  |  |  | 24,000 |
| 448 | 14.1.2.1 | Ausarbeitung |  | 28.75d | 2001-05-01 | 2001-06-01 | 442FS+1.25d | 2001-05-01 | 2001-06-01 | 20d | 337.75d | 0d |  |  |  |  | 24,000 |
| 449 | 14.1.2.2 | fachtechnische Prüfung |  | 27.5d | 2001-06-04 | 2001-07-04 | 448FS+1.25d | 2001-06-04 | 2001-07-04 | 20d | 337.75d | 0d |  |  |  |  |  |
| 450 | 14.1.2.3 | Übergabe und Weiterleitung PBDE |  | 1.25d | 2001-07-06 | 2001-07-09 | 449FS+2.5d | 2001-07-06 | 2001-07-09 | 1.25d | 337.75d | 0d |  |  |  |  |  |
| 451 | 14.1.2.4 | Prüfung durch EBA |  | 37.5d | 2001-07-09 | 2001-08-09 | 450 | 2001-07-09 | 2001-08-09 | 26.25d | 337.75d | 0d |  |  |  |  |  |
| 452 | 14.1.2.5 | Weiterleitung und Übergabe PBDE |  | 7.5d | 2001-08-09 | 2001-08-15 | 451FS-1.25d | 2001-08-09 | 2001-08-15 | 3.75d | 337.75d |  |  |  |  |  |  |
| 453 | 14.1.2.6 | Siemens (PT II EBA - freigegeben) | milestone | 0d | 2001-08-09 | 2001-08-09 | 451 | 2001-08-09 | 2001-08-09 | 0d | 344d |  |  |  |  |  |  |
| 454 | 14.2 | **Innen- und Außenanlage** |  | 53.75d | 2001-07-03 | 2001-08-21 |  | 2001-07-03 | 2001-08-21 | 51.25d | 326.5d |  |  | 1.C-Monteur LST [50%]; 1.MonteurMU/Kab [50%]; Erstellung BZ 9. | 347.2h | 65,217.53 |  |
| 455 | 14.2.1 | Materialisierung |  | 6.25d | 2001-07-03 | 2001-07-10 | 446FS+26.25d | 2001-07-03 | 2001-07-10 | 1.25d | 326.5d | 0d |  |  |  |  |  |
| 456 | 14.2.2 | Kabel, Signale, Magnete usw. bestellen und liefern |  | 26.25d | 2001-07-13 | 2001-08-04 | 455FS+3.75d | 2001-07-13 | 2001-08-04 | 0d? | 326.5d | 0d |  |  |  |  |  |
| 457 | 14.2.3 | Kabel ziehen |  | 7.5d | 2001-07-18 | 2001-07-25 | 456SS+6.25d | 2001-07-18 | 2001-07-25 | 6.25d | 331.5d | 0d | start no earlier than 2000-07-01 |  |  |  |  |
| 458 | 14.2.4 | Kabelarbeiten |  | 3.75d | 2001-07-25 | 2001-07-28 | 457 | 2001-07-25 | 2001-07-28 | 17.5d | 355.25d | 0d | start no earlier than 2000-08-06 |  |  |  |  |
| 459 | 14.2.5 | Magnete montieren |  | 3.75d | 2001-07-28 | 2001-07-31 | 458 | 2001-07-28 | 2001-07-31 | 2.5d | 355.25d |  |  |  |  |  |  |
| 460 | 14.2.6 | Signalmasten stellen |  | 2.5d | 2001-08-04 | 2001-08-06 | 455, 456 | 2001-08-04 | 2001-08-06 | 0d? | 326.5d | 0d |  |  |  |  |  |
| 461 | 14.2.7 | Signale verkabeln |  | 5d | 2001-08-07 | 2001-08-10 | 457, 460 | 2001-08-07 | 2001-08-10 | 0d? | 326.5d | 0d |  |  |  |  |  |
| 462 | 14.2.8 | Kabel auf Kabelendverschluß legen |  | 2.5d | 2001-07-25 | 2001-07-27 | 457 | 2001-07-25 | 2001-07-27 | 0d? | 331.5d | 0d |  |  |  |  |  |
| 463 | 14.2.9 | Versorgung 50 Hz verdrahten |  | 3.75d | 2001-07-27 | 2001-07-30 | 462 | 2001-07-27 | 2001-07-30 | 0d? | 331.5d | 0d |  |  |  |  |  |
| 464 | 14.2.10 | Relaisgruppen montieren und bestücken |  | 5d | 2001-07-30 | 2001-08-03 | 463 | 2001-07-30 | 2001-08-03 | 0d? | 331.5d | 0d |  |  |  |  |  |
| 465 | 14.2.11 | Zimmerkabel, Rangiervergrahtung |  | 3.75d | 2001-08-03 | 2001-08-06 | 464 | 2001-08-03 | 2001-08-06 | 0d? | 331.5d | 5d |  |  |  |  |  |
| 466 | 14.2.12 | Herstellen der Funktionsfähigkeit, Prüfen |  | 10d | 2001-08-11 | 2001-08-21 | 465, 461 | 2001-08-11 | 2001-08-21 | 0d? | 326.5d | 27d |  |  |  |  |  |
| 467 | 14.3 | Inbetriebnahme Bz 9. |  | 2.5d | 2001-09-20 | 2001-09-21 | 466 | 2001-09-20 | 2001-09-21 | 1.25d | 299.5d | 0d | start no earlier than 2001-09-20 | C-Monteur LST Inb.1 [80%]; Monteur LST Inb. 1 [80%] | 32h | 1,920 |  |

| ID | WBS | Task | Type | Duration | Start | Finish | Predecessors | Baseline start | Baseline finish | Baseline duration | Total slack | Free slack | Constraint | Resources | Work | Cost | Baseline cost |
| --- | --- | --- | --- | --- | --- | --- | --- | --- | --- | --- | --- | --- | --- | --- | --- | --- | --- |
| 468 | 14.4 | **Restarbeiten Bz 9.** |  | 3.75d | 2001-09-24 | 2001-09-26 |  | 2001-09-24 | 2001-09-26 | 0d? | 299.5d |  |  | C-Monteur LST Inb.1 [80%]; Monteur LST Inb. 1 [80%] | 48h | 2,880 |  |
| 469 | 14.4.1 | Erstellen von handrevidierten Unterlagen |  | 3.75d | 2001-09-24 | 2001-09-26 | 467 | 2001-09-24 | 2001-09-26 | 0d? | 299.5d |  |  |  |  |  |  |
| 470 | 15 | **Bauzustand 10.** |  | 177.5d | 2001-04-02 | 2001-10-03 |  | 2001-04-02 | 2001-10-03 | 165.75d | 294d |  |  | Projektleiter [28%]; Sekretariat Projektbüro [28%]; 1. Bauleiter Sicherungstechn. [28%] | 1032.16h | 122,667.13 |  |
| 471 | 15.1 | **Planung** |  | 148.75d | 2001-04-02 | 2001-08-31 |  | 2001-04-02 | 2001-08-31 | 117.5d | 294d |  |  |  |  |  | 51,000 |
| 472 | 15.1.1 | **Außenanlagen (PT I)** |  | 76.25d | 2001-04-02 | 2001-06-22 |  | 2001-04-02 | 2001-06-22 | 81.25d | 294d |  |  |  |  |  | 27,000 |
| 473 | 15.1.1.1 | Ausarbeitung |  | 15d | 2001-04-02 | 2001-04-16 |  | 2001-04-02 | 2001-04-16 | 11.25d | 294d | 0d | start no earlier than 2001-04-02 |  |  |  | 27,000 |
| 474 | 15.1.1.2 | Plausibilitätsprüfung ÖRZ |  | 2.5d | 2001-04-18 | 2001-04-20 | 473FS+2.5d | 2001-04-18 | 2001-04-20 | 6.25d | 294d | 0d |  |  |  |  |  |
| 475 | 15.1.1.3 | fachtechnische Prüfung |  | 20d | 2001-04-20 | 2001-05-14 | 474 | 2001-04-20 | 2001-05-14 | 27.5d | 294d | 0d | start no earlier than 2000-08-07 |  |  |  |  |
| 476 | 15.1.1.4 | Übergabe und Weiterleitung PBDE |  | 2.5d | 2001-05-16 | 2001-05-18 | 475FS+2.5d | 2001-05-16 | 2001-05-18 | 3.75d | 294d | 0d |  |  |  |  |  |
| 477 | 15.1.1.5 | Prüfung durch EBA |  | 26.25d | 2001-05-18 | 2001-06-18 | 476 | 2001-05-18 | 2001-06-18 | 26.25d | 294d | 0d |  |  |  |  |  |
| 478 | 15.1.1.6 | Weiterleitung und Übergabe PBDE |  | 5d | 2001-06-18 | 2001-06-22 | 477 | 2001-06-18 | 2001-06-22 | 6.25d | 395.25d |  |  |  |  |  |  |
| 479 | 15.1.1.7 | ETC (PT I EBA - freigegeben) | milestone | 0d | 2001-06-18 | 2001-06-18 | 477 | 2001-06-18 | 2001-06-18 | 0d | 294d | 0d |  |  |  |  |  |
| 480 | 15.1.2 | **Innenanlagen (PT II)** |  | 106.25d | 2001-05-16 | 2001-08-31 |  | 2001-05-16 | 2001-08-31 | 73.75d | 322.75d |  |  |  |  |  | 24,000 |
| 481 | 15.1.2.1 | Ausarbeitung |  | 28.75d | 2001-05-16 | 2001-06-18 | 475FS+2.5d | 2001-05-16 | 2001-06-18 | 20d | 322.75d | 0d |  |  |  |  | 24,000 |
| 482 | 15.1.2.2 | fachtechnische Prüfung |  | 30d | 2001-06-20 | 2001-07-20 | 481FS+2.5d | 2001-06-20 | 2001-07-20 | 20d | 322.75d | 0d |  |  |  |  |  |
| 483 | 15.1.2.3 | Übergabe und Weiterleitung PBDE |  | 2.5d | 2001-07-23 | 2001-07-25 | 482FS+2.5d | 2001-07-23 | 2001-07-25 | 1.25d | 322.75d | 0d |  |  |  |  |  |
| 484 | 15.1.2.4 | Prüfung durch EBA |  | 35d | 2001-07-25 | 2001-08-27 | 483 | 2001-07-25 | 2001-08-27 | 26.25d | 322.75d | 0d |  |  |  |  |  |
| 485 | 15.1.2.5 | Weiterleitung und Übergabe PBDE |  | 5d | 2001-08-27 | 2001-08-31 | 484 | 2001-08-27 | 2001-08-31 | 3.75d | 322.75d |  |  |  |  |  |  |
| 486 | 15.1.2.6 | Siemens (PT II EBA - freigegeben) | milestone | 0d | 2001-08-27 | 2001-08-27 | 484 | 2001-08-27 | 2001-08-27 | 0d | 327.75d |  |  |  |  |  |  |
| 487 | 15.2 | **Innen- und Außenanlage** |  | 75d | 2001-07-15 | 2001-09-27 |  | 2001-07-15 | 2001-09-27 | 51.25d | 294d |  |  | 1.C-Monteur LST; 1.MonteurMU/Kab; Erstellung BZ 10.; 2.MonteurMU/Kab | 560h | 81,465.53 |  |
| 488 | 15.2.1 | Materialisierung |  | 15d | 2001-07-15 | 2001-07-28 | 479FS+26.25d | 2001-07-15 | 2001-07-28 | 1.25d | 294d | 0d |  |  |  |  |  |
| 489 | 15.2.2 | Kabel, Signale, Magnete usw. bestellen und liefern |  | 26.25d | 2001-07-31 | 2001-08-24 | 488FS+3.75d | 2001-07-31 | 2001-08-24 | 0d? | 294d | 0d |  |  |  |  |  |
| 490 | 15.2.3 | Kabel ziehen |  | 7.5d | 2001-08-06 | 2001-08-12 | 489SS+6.25d | 2001-08-06 | 2001-08-12 | 6.25d | 294d | 0d | start no earlier than 2000-07-01 |  |  |  |  |
| 491 | 15.2.4 | Kabelarbeiten |  | 6.25d | 2001-08-12 | 2001-08-17 | 490 | 2001-08-12 | 2001-08-17 | 17.5d | 329d | 0d | start no earlier than 2000-08-06 |  |  |  |  |
| 492 | 15.2.5 | Magnete montieren |  | 6.25d | 2001-08-17 | 2001-08-24 | 491 | 2001-08-17 | 2001-08-24 | 2.5d | 329d |  |  |  |  |  |  |
| 493 | 15.2.6 | Signalmasten stellen |  | 2.5d | 2001-08-24 | 2001-08-28 | 488, 489 | 2001-08-24 | 2001-08-28 | 0d? | 306.5d | 0d |  |  |  |  |  |
| 494 | 15.2.7 | Signale verkabeln |  | 5d | 2001-08-28 | 2001-09-03 | 490, 493 | 2001-08-28 | 2001-09-03 | 0d? | 306.5d | 12.5d |  |  |  |  |  |
| 495 | 15.2.8 | Kabel auf Kabelendverschluß legen |  | 6.25d | 2001-08-12 | 2001-08-17 | 490 | 2001-08-12 | 2001-08-17 | 0d? | 294d | 0d |  |  |  |  |  |
| 496 | 15.2.9 | Versorgung 50 Hz verdrahten |  | 6.25d | 2001-08-17 | 2001-08-24 | 495 | 2001-08-17 | 2001-08-24 | 0d? | 294d | 0d |  |  |  |  |  |
| 497 | 15.2.10 | Relaisgruppen montieren und bestücken |  | 6.25d | 2001-08-24 | 2001-08-31 | 496 | 2001-08-24 | 2001-08-31 | 0d? | 294d | 0d |  |  |  |  |  |
| 498 | 15.2.11 | Zimmerkabel, Rangiervergrahtung |  | 13.75d | 2001-08-31 | 2001-09-17 | 497 | 2001-08-31 | 2001-09-17 | 0d? | 294d | 0d |  |  |  |  |  |
| 499 | 15.2.12 | Herstellen der Funktionsfähigkeit, Prüfen |  | 10d | 2001-09-17 | 2001-09-27 | 498, 494 | 2001-09-17 | 2001-09-27 | 0d? | 294d | 0d |  |  |  |  |  |
| 500 | 15.3 | Inbetriebnahme Bz 10. |  | 1.25d | 2001-09-27 | 2001-09-28 | 499 | 2001-09-27 | 2001-09-28 | 1.25d | 294d | 0d | start no earlier than 2001-09-27 | C-Monteur LST Inb.1; Monteur LST Inb. 1; C-Monteur LST Inb.2 | 26.8h | 1,608 |  |

| ID | WBS | Task | Type | Duration | Start | Finish | Predecessors | Baseline start | Baseline finish | Baseline duration | Total slack | Free slack | Constraint | Resources | Work | Cost | Baseline cost |
| --- | --- | --- | --- | --- | --- | --- | --- | --- | --- | --- | --- | --- | --- | --- | --- | --- | --- |
| 501 | 15.4 | **Restarbeiten Bz 10.** |  | 3.75d | 2001-09-28 | 2001-10-03 |  | 2001-09-28 | 2001-10-03 | 0d? | 294d |  |  | C-Monteur LST Inb.1 [200%]; Monteur LST Inb. 1 [200%] | 59.2h | 3,552 |  |
| 502 | 15.4.1 | Erstellen von handrevidierten Unterlagen |  | 3.75d | 2001-09-28 | 2001-10-03 | 500 | 2001-09-28 | 2001-10-03 | 0d? | 294d |  |  |  |  |  |  |
| 503 | 16 | **Bauzustand 11.** |  | 166.25d | 2001-04-16 | 2001-10-05 |  | 2001-04-16 | 2001-10-05 | 165.75d | 290.75d |  |  | Projektleiter [14%]; Sekretariat Projektbüro [14%]; 1. Bauleiter Sicherungstechn. [14%] | 1125.6h | 114,569.53 |  |
| 504 | 16.1 | **Planung** |  | 153.75d | 2001-04-16 | 2001-09-21 |  | 2001-04-16 | 2001-09-21 | 117.5d | 294.5d |  |  |  |  |  | 51,000 |
| 505 | 16.1.1 | **Außenanlagen (PT I)** |  | 83.75d | 2001-04-16 | 2001-07-16 |  | 2001-04-16 | 2001-07-16 | 81.25d | 294.5d |  |  |  |  |  | 27,000 |
| 506 | 16.1.1.1 | Ausarbeitung |  | 20d | 2001-04-16 | 2001-05-07 |  | 2001-04-16 | 2001-05-07 | 11.25d | 294.5d | 0d | start no earlier than 2001-04-16 |  |  |  | 27,000 |
| 507 | 16.1.1.2 | Plausibilitätsprüfung ÖRZ |  | 2.5d | 2001-05-09 | 2001-05-10 | 506FS+1.25d | 2001-05-09 | 2001-05-10 | 6.25d | 294.5d | 0d |  |  |  |  |  |
| 508 | 16.1.1.3 | fachtechnische Prüfung |  | 21.25d | 2001-05-11 | 2001-06-04 | 507 | 2001-05-11 | 2001-06-04 | 27.5d | 294.5d | 0d | start no earlier than 2000-08-07 |  |  |  |  |
| 509 | 16.1.1.4 | Übergabe und Weiterleitung PBDE |  | 3.75d | 2001-06-06 | 2001-06-08 | 508FS+1.25d | 2001-06-06 | 2001-06-08 | 3.75d | 294.5d | 0d |  |  |  |  |  |
| 510 | 16.1.1.5 | Prüfung durch EBA |  | 27.5d | 2001-06-08 | 2001-07-09 | 509FS-1.25d | 2001-06-08 | 2001-07-09 | 26.25d | 294.5d | 0d |  |  |  |  |  |
| 511 | 16.1.1.6 | Weiterleitung und Übergabe PBDE |  | 8.75d | 2001-07-09 | 2001-07-16 | 510FS-1.25d | 2001-07-09 | 2001-07-16 | 6.25d | 373.25d |  |  |  |  |  |  |
| 512 | 16.1.1.7 | ETC (PT I EBA - freigegeben) | milestone | 0d | 2001-07-09 | 2001-07-09 | 510 | 2001-07-09 | 2001-07-09 | 0d | 294.5d | 0d |  |  |  |  |  |
| 513 | 16.1.2 | **Innenanlagen (PT II)** |  | 108.75d | 2001-06-05 | 2001-09-21 |  | 2001-06-05 | 2001-09-21 | 73.75d | 303.25d |  |  |  |  |  | 24,000 |
| 514 | 16.1.2.1 | Ausarbeitung |  | 30d | 2001-06-05 | 2001-07-06 | 508 | 2001-06-05 | 2001-07-06 | 20d | 303.25d | 0d |  |  |  |  | 24,000 |
| 515 | 16.1.2.2 | fachtechnische Prüfung |  | 37.5d | 2001-07-09 | 2001-08-09 | 514 | 2001-07-09 | 2001-08-09 | 20d | 303.25d | 0d |  |  |  |  |  |
| 516 | 16.1.2.3 | Übergabe und Weiterleitung PBDE |  | 3.75d | 2001-08-10 | 2001-08-13 | 515FS+1.25d | 2001-08-10 | 2001-08-13 | 1.25d | 303.25d | 0d |  |  |  |  |  |
| 517 | 16.1.2.4 | Prüfung durch EBA |  | 31.25d | 2001-08-14 | 2001-09-17 | 516 | 2001-08-14 | 2001-09-17 | 26.25d | 303.25d | 0d |  |  |  |  |  |
| 518 | 16.1.2.5 | Weiterleitung und Übergabe PBDE |  | 5d | 2001-09-18 | 2001-09-21 | 517 | 2001-09-18 | 2001-09-21 | 3.75d | 303.25d |  |  |  |  |  |  |
| 519 | 16.1.2.6 | Siemens (PT II EBA - freigegeben) | milestone | 0d | 2001-09-17 | 2001-09-17 | 517 | 2001-09-17 | 2001-09-17 | 0d | 308.25d |  |  |  |  |  |  |
| 520 | 16.2 | **Innen- und Außenanlage** |  | 53.75d | 2001-08-01 | 2001-09-25 |  | 2001-08-01 | 2001-09-25 | 51.25d | 294.5d |  |  | 1.C-Monteur LST [26.4%]; 1.MonteurMU/Kab [26.4%]; Erstellung BZ 11.; 2.MonteurMU/Kab [34%] | 667.76h | 74,371.13 |  |
| 521 | 16.2.1 | Materialisierung |  | 6.25d | 2001-08-01 | 2001-08-06 | 512FS+26.25d | 2001-08-01 | 2001-08-06 | 1.25d | 294.5d | 0d |  |  |  |  |  |
| 522 | 16.2.2 | Kabel, Signale, Magnete usw. bestellen und liefern |  | 26.25d | 2001-08-09 | 2001-09-05 | 521FS+3.75d | 2001-08-09 | 2001-09-05 | 0d? | 294.5d | 0d |  |  |  |  |  |
| 523 | 16.2.3 | Kabel ziehen |  | 7.5d | 2001-08-15 | 2001-08-22 | 522SS+6.25d | 2001-08-15 | 2001-08-22 | 6.25d | 299.5d | 0d | start no earlier than 2000-07-01 |  |  |  |  |
| 524 | 16.2.4 | Kabelarbeiten |  | 3.75d | 2001-08-23 | 2001-08-27 | 523 | 2001-08-23 | 2001-08-27 | 17.5d | 323.25d | 0d | start no earlier than 2000-08-06 |  |  |  |  |
| 525 | 16.2.5 | Magnete montieren |  | 3.75d | 2001-08-28 | 2001-08-30 | 524 | 2001-08-28 | 2001-08-30 | 2.5d | 323.25d |  |  |  |  |  |  |
| 526 | 16.2.6 | Signalmasten stellen |  | 2.5d | 2001-09-06 | 2001-09-07 | 521, 522 | 2001-09-06 | 2001-09-07 | 0d? | 294.5d | 0d |  |  |  |  |  |
| 527 | 16.2.7 | Signale verkabeln |  | 5d | 2001-09-10 | 2001-09-13 | 523, 526 | 2001-09-10 | 2001-09-13 | 0d? | 294.5d | 0d |  |  |  |  |  |
| 528 | 16.2.8 | Kabel auf Kabelendverschluß legen |  | 2.5d | 2001-08-23 | 2001-08-24 | 523 | 2001-08-23 | 2001-08-24 | 0d? | 299.5d | 0d |  |  |  |  |  |
| 529 | 16.2.9 | Versorgung 50 Hz verdrahten |  | 3.75d | 2001-08-27 | 2001-08-29 | 528 | 2001-08-27 | 2001-08-29 | 0d? | 299.5d | 0d |  |  |  |  |  |
| 530 | 16.2.10 | Relaisgruppen montieren und bestücken |  | 5d | 2001-08-30 | 2001-09-04 | 529 | 2001-08-30 | 2001-09-04 | 0d? | 299.5d | 0d |  |  |  |  |  |
| 531 | 16.2.11 | Zimmerkabel, Rangiervergrahtung |  | 3.75d | 2001-09-05 | 2001-09-07 | 530 | 2001-09-05 | 2001-09-07 | 0d? | 299.5d | 5d |  |  |  |  |  |
| 532 | 16.2.12 | Herstellen der Funktionsfähigkeit, Prüfen |  | 10d | 2001-09-14 | 2001-09-25 | 531, 527 | 2001-09-14 | 2001-09-25 | 0d? | 294.5d | 3.75d |  |  |  |  |  |
| 533 | 16.3 | Inbetriebnahme Bz 11. |  | 2.5d | 2001-10-01 | 2001-10-02 | 532 | 2001-10-01 | 2001-10-02 | 1.25d | 290.75d | 0d | start no earlier than 2001-10-01 | C-Monteur LST Inb.2 [66.7%]; Monteur LST Inb. 2 [66.7%]; C-Monteur LST Inb.3 [66.7%] | 40h | 2,800 |  |

| ID | WBS | Task | Type | Duration | Start | Finish | Predecessors | Baseline start | Baseline finish | Baseline duration | Total slack | Free slack | Constraint | Resources | Work | Cost | Baseline cost |
| --- | --- | --- | --- | --- | --- | --- | --- | --- | --- | --- | --- | --- | --- | --- | --- | --- | --- |
| 534 | 16.4 | **Restarbeiten Bz 11.** |  | 3.75d | 2001-10-03 | 2001-10-05 |  | 2001-10-03 | 2001-10-05 | 0d? | 290.75d |  |  | C-Monteur LST Inb.2 [80%]; Monteur LST Inb. 2 [80%] | 48h | 2,880 |  |
| 535 | 16.4.1 | Erstellen von handrevidierten Unterlagen |  | 3.75d | 2001-10-03 | 2001-10-05 | 533 | 2001-10-03 | 2001-10-05 | 0d? | 290.75d |  |  |  |  |  |  |
| 536 | 17 | **Bauzustand 12.** |  | 148.75d | 2001-05-07 | 2001-10-08 |  | 2001-05-07 | 2001-10-08 | 165.75d | 289.5d |  |  | Projektleiter [16%]; Sekretariat Projektbüro [16%]; 1. Bauleiter Sicherungstechn. [16%] | 1091.57h | 112,247.93 |  |
| 537 | 17.1 | **Planung** |  | 135d | 2001-05-07 | 2001-09-21 |  | 2001-05-07 | 2001-09-21 | 117.5d | 290.75d |  |  |  |  |  | 51,000 |
| 538 | 17.1.1 | **Außenanlagen (PT I)** |  | 73.75d | 2001-05-07 | 2001-07-23 |  | 2001-05-07 | 2001-07-23 | 81.25d | 290.75d |  |  |  |  |  | 27,000 |
| 539 | 17.1.1.1 | Ausarbeitung |  | 13.75d | 2001-05-07 | 2001-05-21 |  | 2001-05-07 | 2001-05-21 | 11.25d | 290.75d | 0d | start no earlier than 2001-05-07 |  |  |  | 27,000 |
| 540 | 17.1.1.2 | Plausibilitätsprüfung ÖRZ |  | 2.5d | 2001-05-23 | 2001-05-24 | 539FS+1.25d | 2001-05-23 | 2001-05-24 | 6.25d | 290.75d | 0d |  |  |  |  |  |
| 541 | 17.1.1.3 | fachtechnische Prüfung |  | 15d | 2001-05-25 | 2001-06-11 | 540 | 2001-05-25 | 2001-06-11 | 27.5d | 290.75d | 0d | start no earlier than 2000-08-07 |  |  |  |  |
| 542 | 17.1.1.4 | Übergabe und Weiterleitung PBDE |  | 3.75d | 2001-06-13 | 2001-06-15 | 541FS+1.25d | 2001-06-13 | 2001-06-15 | 3.75d | 290.75d | 0d |  |  |  |  |  |
| 543 | 17.1.1.5 | Prüfung durch EBA |  | 28.75d | 2001-06-15 | 2001-07-16 | 542FS-1.25d | 2001-06-15 | 2001-07-16 | 26.25d | 290.75d | 0d |  |  |  |  |  |
| 544 | 17.1.1.6 | Weiterleitung und Übergabe PBDE |  | 8.75d | 2001-07-16 | 2001-07-23 | 543 | 2001-07-16 | 2001-07-23 | 6.25d | 364.5d |  |  |  |  |  |  |
| 545 | 17.1.1.7 | ETC (PT I EBA - freigegeben) | milestone | 0d | 2001-07-16 | 2001-07-16 | 543 | 2001-07-16 | 2001-07-16 | 0d | 290.75d | 0d |  |  |  |  |  |
| 546 | 17.1.2 | **Innenanlagen (PT II)** |  | 102.5d | 2001-06-12 | 2001-09-21 |  | 2001-06-12 | 2001-09-21 | 73.75d | 303.25d |  |  |  |  |  | 24,000 |
| 547 | 17.1.2.1 | Ausarbeitung |  | 23.75d | 2001-06-12 | 2001-07-06 | 541 | 2001-06-12 | 2001-07-06 | 20d | 303.25d | 0d |  |  |  |  | 24,000 |
| 548 | 17.1.2.2 | fachtechnische Prüfung |  | 37.5d | 2001-07-09 | 2001-08-09 | 547 | 2001-07-09 | 2001-08-09 | 20d | 303.25d | 0d |  |  |  |  |  |
| 549 | 17.1.2.3 | Übergabe und Weiterleitung PBDE |  | 3.75d | 2001-08-10 | 2001-08-13 | 548FS+1.25d | 2001-08-10 | 2001-08-13 | 1.25d | 303.25d | 0d |  |  |  |  |  |
| 550 | 17.1.2.4 | Prüfung durch EBA |  | 31.25d | 2001-08-14 | 2001-09-17 | 549 | 2001-08-14 | 2001-09-17 | 26.25d | 303.25d | 0d |  |  |  |  |  |
| 551 | 17.1.2.5 | Weiterleitung und Übergabe PBDE |  | 5d | 2001-09-18 | 2001-09-21 | 550 | 2001-09-18 | 2001-09-21 | 3.75d | 303.25d |  |  |  |  |  |  |
| 552 | 17.1.2.6 | Siemens (PT II EBA - freigegeben) | milestone | 0d | 2001-09-17 | 2001-09-17 | 550 | 2001-09-17 | 2001-09-17 | 0d | 308.25d |  |  |  |  |  |  |
| 553 | 17.2 | **Innen- und Außenanlage** |  | 51.25d | 2001-08-07 | 2001-10-01 |  | 2001-08-07 | 2001-10-01 | 51.25d | 290.75d |  |  | 1.C-Monteur LST [80%]; 1.MonteurMU/Kab [80%]; Erstellung BZ 12.; 2.MonteurMU/Kab [80%] | 690.8h | 76,953.53 |  |
| 554 | 17.2.1 | Materialisierung |  | 12.5d | 2001-08-07 | 2001-08-17 | 545FS+26.25d | 2001-08-07 | 2001-08-17 | 1.25d | 290.75d | 0d |  |  |  |  |  |
| 555 | 17.2.2 | Kabel, Signale, Magnete usw. bestellen und liefern |  | 26.25d | 2001-08-23 | 2001-09-20 | 554FS+3.75d | 2001-08-23 | 2001-09-20 | 0d? | 290.75d | 0d |  |  |  |  |  |
| 556 | 17.2.3 | Kabel ziehen |  | 3.75d | 2001-08-30 | 2001-09-03 | 555SS+6.25d | 2001-08-30 | 2001-09-03 | 6.25d | 297d | 0d | start no earlier than 2000-07-01 |  |  |  |  |
| 557 | 17.2.4 | Kabelarbeiten |  | 3.75d | 2001-09-04 | 2001-09-06 | 556 | 2001-09-04 | 2001-09-06 | 17.5d | 313.25d | 0d | start no earlier than 2000-08-06 |  |  |  |  |
| 558 | 17.2.5 | Magnete montieren |  | 3.75d | 2001-09-07 | 2001-09-11 | 557 | 2001-09-07 | 2001-09-11 | 2.5d | 313.25d |  |  |  |  |  |  |
| 559 | 17.2.6 | Signalmasten stellen |  | 2.5d | 2001-09-21 | 2001-09-24 | 554, 555 | 2001-09-21 | 2001-09-24 | 0d? | 290.75d | 0d |  |  |  |  |  |
| 560 | 17.2.7 | Signale verkabeln |  | 2.5d | 2001-09-25 | 2001-09-26 | 556, 559 | 2001-09-25 | 2001-09-26 | 0d? | 290.75d | 0d |  |  |  |  |  |
| 561 | 17.2.8 | Kabel auf Kabelendverschluß legen |  | 2.5d | 2001-09-04 | 2001-09-05 | 556 | 2001-09-04 | 2001-09-05 | 0d? | 297d | 0d |  |  |  |  |  |
| 562 | 17.2.9 | Versorgung 50 Hz verdrahten |  | 3.75d | 2001-09-06 | 2001-09-10 | 561 | 2001-09-06 | 2001-09-10 | 0d? | 297d | 0d |  |  |  |  |  |
| 563 | 17.2.10 | Relaisgruppen montieren und bestücken |  | 5d | 2001-09-11 | 2001-09-14 | 562 | 2001-09-11 | 2001-09-14 | 0d? | 297d | 0d |  |  |  |  |  |
| 564 | 17.2.11 | Zimmerkabel, Rangiervergrahtung |  | 3.75d | 2001-09-17 | 2001-09-19 | 563 | 2001-09-17 | 2001-09-19 | 0d? | 297d | 6.25d |  |  |  |  |  |
| 565 | 17.2.12 | Herstellen der Funktionsfähigkeit, Prüfen |  | 3.75d | 2001-09-27 | 2001-10-01 | 564, 560 | 2001-09-27 | 2001-10-01 | 0d? | 290.75d | 1.25d |  |  |  |  |  |
| 566 | 17.3 | Inbetriebnahme Bz 12. |  | 1.25d | 2001-10-03 | 2001-10-03 | 565 | 2001-10-03 | 2001-10-03 | 1.25d | 289.5d | 0d | start no earlier than 2001-10-03 | C-Monteur LST Inb.3 [66.7%]; Monteur LST Inb. 3 [66.7%]; C-Monteur LST Inb.4 [80%] | 21.33h | 1,480 |  |

| ID | WBS | Task | Type | Duration | Start | Finish | Predecessors | Baseline start | Baseline finish | Baseline duration | Total slack | Free slack | Constraint | Resources | Work | Cost | Baseline cost |
| --- | --- | --- | --- | --- | --- | --- | --- | --- | --- | --- | --- | --- | --- | --- | --- | --- | --- |
| 567 | 17.4 | **Restarbeiten Bz 12.** |  | 3.75d | 2001-10-04 | 2001-10-08 |  | 2001-10-04 | 2001-10-08 | 0d? | 289.5d |  |  | C-Monteur LST Inb.1 [80%]; Monteur LST Inb. 1 [80%] | 48h | 2,880 |  |
| 568 | 17.4.1 | Erstellen von handrevidierten Unterlagen |  | 3.75d | 2001-10-04 | 2001-10-08 | 566 | 2001-10-04 | 2001-10-08 | 0d? | 289.5d |  |  |  |  |  |  |
| 569 | 18 | **Bauzustand 13.1.** |  | 218.75d | 2001-05-21 | 2002-01-09 |  | 2001-05-21 | 2002-01-09 | 165.75d | 207d |  |  | Projektleiter [32%]; Sekretariat Projektbüro [32%]; 1. Bauleiter Sicherungstechn. [32%] | 2221.88h | 171,089.22 |  |
| 570 | 18.1 | **Planung** |  | 172.5d | 2001-05-21 | 2001-11-16 |  | 2001-05-21 | 2001-11-16 | 117.5d | 218.25d |  |  |  |  |  | 51,000 |
| 571 | 18.1.1 | **Außenanlagen (PT I)** |  | 111.25d | 2001-05-21 | 2001-09-10 |  | 2001-05-21 | 2001-09-10 | 81.25d | 218.25d |  |  |  |  |  | 27,000 |
| 572 | 18.1.1.1 | Ausarbeitung |  | 30d | 2001-05-21 | 2001-06-21 |  | 2001-05-21 | 2001-06-21 | 11.25d | 218.25d | 0d | start no earlier than 2001-05-21 |  |  |  | 27,000 |
| 573 | 18.1.1.2 | Plausibilitätsprüfung ÖRZ |  | 2.5d | 2001-06-25 | 2001-06-26 | 572FS+1.25d | 2001-06-25 | 2001-06-26 | 6.25d | 218.25d | 0d |  |  |  |  |  |
| 574 | 18.1.1.3 | fachtechnische Prüfung |  | 32.5d | 2001-06-27 | 2001-07-27 | 573 | 2001-06-27 | 2001-07-27 | 27.5d | 218.25d | 0d | start no earlier than 2000-08-07 |  |  |  |  |
| 575 | 18.1.1.4 | Übergabe und Weiterleitung PBDE |  | 2.5d | 2001-07-30 | 2001-08-01 | 574FS+2.5d | 2001-07-30 | 2001-08-01 | 3.75d | 218.25d | 0d |  |  |  |  |  |
| 576 | 18.1.1.5 | Prüfung durch EBA |  | 33.75d | 2001-08-01 | 2001-09-03 | 575 | 2001-08-01 | 2001-09-03 | 26.25d | 218.25d | 0d |  |  |  |  |  |
| 577 | 18.1.1.6 | Weiterleitung und Übergabe PBDE |  | 7.5d | 2001-09-03 | 2001-09-10 | 576FS-1.25d | 2001-09-03 | 2001-09-10 | 6.25d | 314.5d |  |  |  |  |  |  |
| 578 | 18.1.1.7 | ETC (PT I EBA - freigegeben) | milestone | 0d | 2001-09-03 | 2001-09-03 | 576 | 2001-09-03 | 2001-09-03 | 0d | 218.25d | 0d |  |  |  |  |  |
| 579 | 18.1.2 | **Innenanlagen (PT II)** |  | 103.75d | 2001-07-30 | 2001-11-16 |  | 2001-07-30 | 2001-11-16 | 73.75d | 253.25d |  |  |  |  |  | 24,000 |
| 580 | 18.1.2.1 | Ausarbeitung |  | 33.75d | 2001-07-30 | 2001-08-30 | 574FS+2.5d | 2001-07-30 | 2001-08-30 | 20d | 253.25d | 0d |  |  |  |  | 24,000 |
| 581 | 18.1.2.2 | fachtechnische Prüfung |  | 28.75d | 2001-09-03 | 2001-10-03 | 580FS+1.25d | 2001-09-03 | 2001-10-03 | 20d | 253.25d | 0d |  |  |  |  |  |
| 582 | 18.1.2.3 | Übergabe und Weiterleitung PBDE |  | 1.25d | 2001-10-05 | 2001-10-05 | 581FS+1.25d | 2001-10-05 | 2001-10-05 | 1.25d | 253.25d | 0d |  |  |  |  |  |
| 583 | 18.1.2.4 | Prüfung durch EBA |  | 30d | 2001-10-08 | 2001-11-08 | 582 | 2001-10-08 | 2001-11-08 | 26.25d | 253.25d | 0d |  |  |  |  |  |
| 584 | 18.1.2.5 | Weiterleitung und Übergabe PBDE |  | 8.75d | 2001-11-08 | 2001-11-16 | 583FS-1.25d | 2001-11-08 | 2001-11-16 | 3.75d | 253.25d |  |  |  |  |  |  |
| 585 | 18.1.2.6 | Siemens (PT II EBA - freigegeben) | milestone | 0d | 2001-11-08 | 2001-11-08 | 583 | 2001-11-08 | 2001-11-08 | 0d | 260.75d |  |  |  |  |  |  |
| 586 | 18.2 | **Innen- und Außenanlage** |  | 71.25d | 2001-10-03 | 2001-12-20 |  | 2001-10-03 | 2001-12-20 | 51.25d | 218.25d |  |  | 1.C-Monteur LST [80%]; 1.MonteurMU/Kab [80%]; Erstellung BZ 13.1. [80%]; 2.MonteurMU/Kab [80%] | 1528h | 108,660.42 |  |
| 587 | 18.2.1 | Materialisierung |  | 18.75d | 2001-10-03 | 2001-10-23 | 578FS+26.25d | 2001-10-03 | 2001-10-23 | 1.25d | 218.25d | 0d |  |  |  |  |  |
| 588 | 18.2.2 | Kabel, Signale, Magnete usw. bestellen und liefern |  | 26.25d | 2001-10-29 | 2001-11-26 | 587FS+3.75d | 2001-10-29 | 2001-11-26 | 0d? | 218.25d | 0d |  |  |  |  |  |
| 589 | 18.2.3 | Kabel ziehen |  | 7.5d | 2001-11-05 | 2001-11-12 | 588SS+6.25d | 2001-11-05 | 2001-11-12 | 6.25d | 218.25d | 0d | start no earlier than 2000-07-01 |  |  |  |  |
| 590 | 18.2.4 | Kabelarbeiten |  | 6.25d | 2001-11-13 | 2001-11-19 | 589 | 2001-11-13 | 2001-11-19 | 17.5d | 245.75d | 0d | start no earlier than 2000-08-06 |  |  |  |  |
| 591 | 18.2.5 | Magnete montieren |  | 6.25d | 2001-11-20 | 2001-11-26 | 590 | 2001-11-20 | 2001-11-26 | 2.5d | 245.75d |  |  |  |  |  |  |
| 592 | 18.2.6 | Signalmasten stellen |  | 3.75d | 2001-11-27 | 2001-11-29 | 587, 588 | 2001-11-27 | 2001-11-29 | 0d? | 218.25d | 0d |  |  |  |  |  |
| 593 | 18.2.7 | Signale verkabeln |  | 6.25d | 2001-11-30 | 2001-12-06 | 589, 592 | 2001-11-30 | 2001-12-06 | 0d? | 218.25d | 0d |  |  |  |  |  |
| 594 | 18.2.8 | Kabel auf Kabelendverschluß legen |  | 6.25d | 2001-11-13 | 2001-11-19 | 589 | 2001-11-13 | 2001-11-19 | 0d? | 218.25d | 0d |  |  |  |  |  |
| 595 | 18.2.9 | Versorgung 50 Hz verdrahten |  | 3.75d | 2001-11-20 | 2001-11-22 | 594 | 2001-11-20 | 2001-11-22 | 0d? | 218.25d | 0d |  |  |  |  |  |
| 596 | 18.2.10 | Relaisgruppen montieren und bestücken |  | 6.25d | 2001-11-23 | 2001-11-29 | 595 | 2001-11-23 | 2001-11-29 | 0d? | 218.25d | 0d |  |  |  |  |  |
| 597 | 18.2.11 | Zimmerkabel, Rangiervergrahtung |  | 6.25d | 2001-11-30 | 2001-12-06 | 596 | 2001-11-30 | 2001-12-06 | 0d? | 218.25d | 0d |  |  |  |  |  |
| 598 | 18.2.12 | Herstellen der Funktionsfähigkeit, Prüfen |  | 12.5d | 2001-12-07 | 2001-12-20 | 597, 593 | 2001-12-07 | 2001-12-20 | 0d? | 218.25d | 11.25d |  |  |  |  |  |
| 599 | 18.3 | Inbetriebnahme Bz 13.1. |  | 1.25d | 2002-01-05 | 2002-01-06 | 598 | 2002-01-05 | 2002-01-06 | 1.25d | 207d | 0d | start no earlier than 2002-01-05 | C-Monteur LST Inb.2; Monteur LST Inb. 1; C-Monteur LST Inb.3 | 21h | 1,560 |  |

| ID | WBS | Task | Type | Duration | Start | Finish | Predecessors | Baseline start | Baseline finish | Baseline duration | Total slack | Free slack | Constraint | Resources | Work | Cost | Baseline cost |
| --- | --- | --- | --- | --- | --- | --- | --- | --- | --- | --- | --- | --- | --- | --- | --- | --- | --- |
| 600 | 18.4 | **Restarbeiten Bz 13.1.** |  | 3.75d | 2002-01-06 | 2002-01-09 |  | 2002-01-06 | 2002-01-09 | 0d? | 207d |  |  | C-Monteur LST Inb.1 [200%]; Monteur LST Inb. 1 | 58h | 3,480 |  |
| 601 | 18.4.1 | Erstellen von handrevidierten Unterlagen |  | 3.75d | 2002-01-06 | 2002-01-09 | 599 | 2002-01-06 | 2002-01-09 | 0d? | 207d |  |  |  |  |  |  |
| 602 | 19 | **Bauzustand 13.2.** |  | 249.25d | 2001-06-21 | 2002-03-14 |  | 2001-06-21 | 2002-03-14 | 165.75d | 147.75d |  |  | Projektleiter [80%]; Sekretariat Projektbüro [80%]; 1. Bauleiter Sicherungstechn. [80%] | 2036.48h | 175,758.33 |  |
| 603 | 19.1 | **Planung** |  | 170d | 2001-06-21 | 2001-12-17 |  | 2001-06-21 | 2001-12-17 | 117.5d | 167d |  |  |  |  |  | 51,000 |
| 604 | 19.1.1 | **Außenanlagen (PT I)** |  | 107.5d | 2001-06-21 | 2001-10-08 |  | 2001-06-21 | 2001-10-08 | 81.25d | 167d |  |  |  |  |  | 27,000 |
| 605 | 19.1.1.1 | Ausarbeitung |  | 32.5d | 2001-06-21 | 2001-07-23 |  | 2001-06-21 | 2001-07-23 | 11.25d | 167d | 0d | start no earlier than 2001-06-21 |  |  |  | 27,000 |
| 606 | 19.1.1.2 | Plausibilitätsprüfung ÖRZ |  | 2.5d | 2001-07-25 | 2001-07-27 | 605FS+2.5d | 2001-07-25 | 2001-07-27 | 6.25d | 167d | 0d |  |  |  |  |  |
| 607 | 19.1.1.3 | fachtechnische Prüfung |  | 32.5d | 2001-07-27 | 2001-08-27 | 606 | 2001-07-27 | 2001-08-27 | 27.5d | 167d | 0d | start no earlier than 2000-08-07 |  |  |  |  |
| 608 | 19.1.1.4 | Übergabe und Weiterleitung PBDE |  | 2.5d | 2001-08-29 | 2001-08-30 | 607FS+1.25d | 2001-08-29 | 2001-08-30 | 3.75d | 167d | 0d |  |  |  |  |  |
| 609 | 19.1.1.5 | Prüfung durch EBA |  | 27.5d | 2001-08-31 | 2001-10-01 | 608 | 2001-08-31 | 2001-10-01 | 26.25d | 167d | 0d |  |  |  |  |  |
| 610 | 19.1.1.6 | Weiterleitung und Übergabe PBDE |  | 7.5d | 2001-10-01 | 2001-10-08 | 609FS-1.25d | 2001-10-01 | 2001-10-08 | 6.25d | 289.5d |  |  |  |  |  |  |
| 611 | 19.1.1.7 | ETC (PT I EBA - freigegeben) | milestone | 0d | 2001-10-01 | 2001-10-01 | 609 | 2001-10-01 | 2001-10-01 | 0d | 167d | 0d |  |  |  |  |  |
| 612 | 19.1.2 | **Innenanlagen (PT II)** |  | 98.75d | 2001-08-29 | 2001-12-17 |  | 2001-08-29 | 2001-12-17 | 73.75d | 227d |  |  |  |  |  | 24,000 |
| 613 | 19.1.2.1 | Ausarbeitung |  | 30d | 2001-08-29 | 2001-10-01 | 607FS+1.25d | 2001-08-29 | 2001-10-01 | 20d | 227d | 0d |  |  |  |  | 24,000 |
| 614 | 19.1.2.2 | fachtechnische Prüfung |  | 30d | 2001-10-03 | 2001-11-05 | 613FS+1.25d | 2001-10-03 | 2001-11-05 | 20d | 227d | 0d |  |  |  |  |  |
| 615 | 19.1.2.3 | Übergabe und Weiterleitung PBDE |  | 3.75d | 2001-11-07 | 2001-11-09 | 614FS+1.25d | 2001-11-07 | 2001-11-09 | 1.25d | 227d | 0d |  |  |  |  |  |
| 616 | 19.1.2.4 | Prüfung durch EBA |  | 27.5d | 2001-11-09 | 2001-12-10 | 615FS-1.25d | 2001-11-09 | 2001-12-10 | 26.25d | 227d | 0d |  |  |  |  |  |
| 617 | 19.1.2.5 | Weiterleitung und Übergabe PBDE |  | 7.5d | 2001-12-10 | 2001-12-17 | 616FS-1.25d | 2001-12-10 | 2001-12-17 | 3.75d | 227d |  |  |  |  |  |  |
| 618 | 19.1.2.6 | Siemens (PT II EBA - freigegeben) | milestone | 0d | 2001-12-10 | 2001-12-10 | 616 | 2001-12-10 | 2001-12-10 | 0d | 233.25d |  |  |  |  |  |  |
| 619 | 19.2 | **Innen- und Außenanlage** |  | 97.5d | 2001-10-31 | 2002-02-15 |  | 2001-10-31 | 2002-02-15 | 51.25d | 167d |  |  | 1.C-Monteur LST [80%]; 1.MonteurMU/Kab [80%]; Erstellung BZ 13.2. | 1150.96h | 96,043.13 |  |
| 620 | 19.2.1 | Materialisierung |  | 25d | 2001-10-31 | 2001-11-27 | 611FS+26.25d | 2001-10-31 | 2001-11-27 | 1.25d | 167d | 0d |  |  |  |  |  |
| 621 | 19.2.2 | Kabel, Signale, Magnete usw. bestellen und liefern |  | 37.5d | 2001-12-03 | 2002-01-14 | 620FS+3.75d | 2001-12-03 | 2002-01-14 | 0d? | 167d | 0d |  |  |  |  |  |
| 622 | 19.2.3 | Kabel ziehen |  | 12.5d | 2001-12-10 | 2001-12-21 | 621SS+6.25d | 2001-12-10 | 2001-12-21 | 6.25d | 175.75d | 0d | start no earlier than 2000-07-01 |  |  |  |  |
| 623 | 19.2.4 | Kabelarbeiten |  | 6.25d | 2001-12-26 | 2002-01-01 | 622 | 2001-12-26 | 2002-01-01 | 17.5d | 209.5d | 0d | start no earlier than 2000-08-06 |  |  |  |  |
| 624 | 19.2.5 | Magnete montieren |  | 6.25d | 2002-01-02 | 2002-01-07 | 623 | 2002-01-02 | 2002-01-07 | 2.5d | 209.5d |  |  |  |  |  |  |
| 625 | 19.2.6 | Signalmasten stellen |  | 6.25d | 2002-01-14 | 2002-01-21 | 620, 621 | 2002-01-14 | 2002-01-21 | 0d? | 167d | 0d |  |  |  |  |  |
| 626 | 19.2.7 | Signale verkabeln |  | 6.25d | 2002-01-21 | 2002-01-28 | 622, 625 | 2002-01-21 | 2002-01-28 | 0d? | 167d | 0d |  |  |  |  |  |
| 627 | 19.2.8 | Kabel auf Kabelendverschluß legen |  | 3.75d | 2001-12-26 | 2001-12-28 | 622 | 2001-12-26 | 2001-12-28 | 0d? | 175.75d | 0d |  |  |  |  |  |
| 628 | 19.2.9 | Versorgung 50 Hz verdrahten |  | 6.25d | 2001-12-31 | 2002-01-04 | 627 | 2001-12-31 | 2002-01-04 | 0d? | 175.75d | 0d |  |  |  |  |  |
| 629 | 19.2.10 | Relaisgruppen montieren und bestücken |  | 6.25d | 2002-01-05 | 2002-01-10 | 628 | 2002-01-05 | 2002-01-10 | 0d? | 175.75d | 0d |  |  |  |  |  |
| 630 | 19.2.11 | Zimmerkabel, Rangiervergrahtung |  | 6.25d | 2002-01-10 | 2002-01-17 | 629 | 2002-01-10 | 2002-01-17 | 0d? | 175.75d | 8.75d |  |  |  |  |  |
| 631 | 19.2.12 | Herstellen der Funktionsfähigkeit, Prüfen |  | 18.75d | 2002-01-28 | 2002-02-15 | 630, 626 | 2002-01-28 | 2002-02-18 | 0d? | 167d | 19.25d |  |  |  |  |  |
| 632 | 19.3 | Inbetriebnahme Bz 13.2. |  | 1.25d | 2002-03-10 | 2002-03-11 | 631 | 2002-03-10 | 2002-03-11 | 1.25d | 147.75d | 0d | start no earlier than 2002-03-10 | C-Monteur LST Inb.2 [400%]; Monteur LST Inb. 2 [400%] | 28h | 1,680 |  |

| ID | WBS | Task | Type | Duration | Start | Finish | Predecessors | Baseline start | Baseline finish | Baseline duration | Total slack | Free slack | Constraint | Resources | Work | Cost | Baseline cost |
| --- | --- | --- | --- | --- | --- | --- | --- | --- | --- | --- | --- | --- | --- | --- | --- | --- | --- |
| 633 | 19.4 | **Restarbeiten Bz 13.2.** |  | 3.75d | 2002-03-11 | 2002-03-14 |  | 2002-03-11 | 2002-03-14 | 0d? | 147.75d |  |  | C-Monteur LST Inb.1 [400%]; Monteur LST Inb. 1 [400%] | 60h | 3,600 |  |
| 634 | 19.4.1 | Erstellen von handrevidierten Unterlagen |  | 3.75d | 2002-03-11 | 2002-03-14 | 632 | 2002-03-11 | 2002-03-14 | 0d? | 147.75d |  |  |  |  |  |  |
| 635 | 20 | **Bauzustand 14.** |  | 188.75d | 2001-08-20 | 2002-03-15 |  | 2001-08-20 | 2002-03-15 | 165.75d | 145.75d |  |  | Projektleiter [25%]; Sekretariat Projektbüro [25%]; 1. Bauleiter Sicherungstechn. [25%] | 2684.4h | 237,157.53 |  |
| 636 | 20.1 | **Planung** |  | 163.75d | 2001-08-20 | 2002-02-18 |  | 2001-08-20 | 2002-02-18 | 117.5d | 145.75d |  |  |  | 1134h | 89,540 | 51,000 |
| 637 | 20.1.1 | **Außenanlagen (PT I)** |  | 101.25d | 2001-08-20 | 2001-12-10 |  | 2001-08-20 | 2001-12-10 | 81.25d | 145.75d |  |  | Plan PT I ETC 14. [80%] | 648h | 15,360 | 27,000 |
| 638 | 20.1.1.1 | Ausarbeitung |  | 31.25d | 2001-08-20 | 2001-09-21 |  | 2001-08-20 | 2001-09-21 | 11.25d | 145.75d | 0d | start no earlier than 2001-08-20 |  |  |  | 27,000 |
| 639 | 20.1.1.2 | Plausibilitätsprüfung ÖRZ |  | 2.5d | 2001-09-25 | 2001-09-26 | 638FS+1.25d | 2001-09-25 | 2001-09-26 | 6.25d | 145.75d | 0d |  |  |  |  |  |
| 640 | 20.1.1.3 | fachtechnische Prüfung |  | 28.75d | 2001-09-27 | 2001-10-29 | 639 | 2001-09-27 | 2001-10-29 | 27.5d | 145.75d | 0d | start no earlier than 2000-08-07 |  |  |  |  |
| 641 | 20.1.1.4 | Übergabe und Weiterleitung PBDE |  | 2.5d | 2001-10-31 | 2001-11-01 | 640FS+1.25d | 2001-10-31 | 2001-11-01 | 3.75d | 145.75d | 0d |  |  |  |  |  |
| 642 | 20.1.1.5 | Prüfung durch EBA |  | 27.5d | 2001-11-02 | 2001-12-03 | 641 | 2001-11-02 | 2001-12-03 | 26.25d | 145.75d | 0d |  |  |  |  |  |
| 643 | 20.1.1.6 | Weiterleitung und Übergabe PBDE |  | 7.5d | 2001-12-03 | 2001-12-10 | 642FS-1.25d | 2001-12-03 | 2001-12-10 | 6.25d | 233.25d |  |  |  |  |  |  |
| 644 | 20.1.1.7 | ETC (PT I EBA - freigegeben) | milestone | 0d | 2001-12-03 | 2001-12-03 | 642 | 2001-12-03 | 2001-12-03 | 0d | 145.75d | 0d |  |  |  |  |  |
| 645 | 20.1.2 | **Innenanlagen (PT II)** |  | 100d | 2001-10-30 | 2002-02-18 |  | 2001-10-30 | 2002-02-18 | 73.75d | 170.75d |  |  | Plan PT II (Siemens) 14. | 486h | 74,180 | 24,000 |
| 646 | 20.1.2.1 | Ausarbeitung |  | 30d | 2001-10-30 | 2001-11-30 | 640 | 2001-10-30 | 2001-11-30 | 20d | 170.75d | 0d |  |  |  |  | 24,000 |
| 647 | 20.1.2.2 | fachtechnische Prüfung |  | 28.75d | 2001-12-03 | 2002-01-04 | 646 | 2001-12-03 | 2002-01-04 | 20d | 170.75d | 0d |  |  |  |  |  |
| 648 | 20.1.2.3 | Übergabe und Weiterleitung PBDE |  | 2.5d | 2002-01-07 | 2002-01-09 | 647FS+2.5d | 2002-01-07 | 2002-01-09 | 1.25d | 170.75d | 0d |  |  |  |  |  |
| 649 | 20.1.2.4 | Prüfung durch EBA |  | 28.75d | 2002-01-09 | 2002-02-10 | 648 | 2002-01-09 | 2002-02-10 | 26.25d | 170.75d | 0d |  |  |  |  |  |
| 650 | 20.1.2.5 | Weiterleitung und Übergabe PBDE |  | 7.5d | 2002-02-10 | 2002-02-18 | 649 | 2002-02-10 | 2002-02-18 | 3.75d | 170.75d |  |  |  |  |  |  |
| 651 | 20.1.2.6 | Siemens (PT II EBA - freigegeben) | milestone | 0d | 2002-02-10 | 2002-02-10 | 649 | 2002-02-10 | 2002-02-10 | 0d | 178.25d |  |  |  |  |  |  |
| 652 | 20.2 | **Innen- und Außenanlage** |  | 62.5d | 2002-01-04 | 2002-03-11 |  | 2002-01-04 | 2002-03-11 | 51.25d | 145.75d |  |  | 1.C-Monteur LST [50%]; 1.MonteurMU/Kab [50%]; Erstellung BZ 14. | 796.96h | 78,763.13 |  |
| 653 | 20.2.1 | Materialisierung |  | 15d | 2002-01-04 | 2002-01-18 | 644FS+26.25d | 2002-01-04 | 2002-01-18 | 1.25d | 145.75d | 0d |  |  |  |  |  |
| 654 | 20.2.2 | Kabel, Signale, Magnete usw. bestellen und liefern |  | 26.25d | 2002-01-23 | 2002-02-20 | 653FS+3.75d | 2002-01-23 | 2002-02-20 | 0d? | 145.75d | 0d |  |  |  |  |  |
| 655 | 20.2.3 | Kabel ziehen |  | 7.5d | 2002-01-30 | 2002-02-07 | 654SS+6.25d | 2002-01-30 | 2002-02-07 | 6.25d | 145.75d | 0d | start no earlier than 2000-07-01 |  |  |  |  |
| 656 | 20.2.4 | Kabelarbeiten |  | 6.25d | 2002-02-07 | 2002-02-13 | 655 | 2002-02-07 | 2002-02-13 | 17.5d | 168.25d | 0d | start no earlier than 2000-08-06 |  |  |  |  |
| 657 | 20.2.5 | Magnete montieren |  | 6.25d | 2002-02-13 | 2002-02-20 | 656 | 2002-02-13 | 2002-02-20 | 2.5d | 168.25d |  |  |  |  |  |  |
| 658 | 20.2.6 | Signalmasten stellen |  | 6.25d | 2002-02-20 | 2002-02-27 | 653, 654 | 2002-02-20 | 2002-02-27 | 0d? | 155.75d | 0d |  |  |  |  |  |
| 659 | 20.2.7 | Signale verkabeln |  | 6.25d | 2002-02-27 | 2002-03-06 | 655, 658 | 2002-02-27 | 2002-03-06 | 0d? | 155.75d |  |  |  |  |  |  |
| 660 | 20.2.8 | Kabel auf Kabelendverschluß legen |  | 3.75d | 2002-02-07 | 2002-02-11 | 655 | 2002-02-07 | 2002-02-11 | 0d? | 145.75d | 0d |  |  |  |  |  |
| 661 | 20.2.9 | Versorgung 50 Hz verdrahten |  | 6.25d | 2002-02-11 | 2002-02-18 | 660 | 2002-02-11 | 2002-02-18 | 0d? | 145.75d | 0d |  |  |  |  |  |
| 662 | 20.2.10 | Relaisgruppen montieren und bestücken |  | 6.25d | 2002-02-18 | 2002-02-25 | 661 | 2002-02-18 | 2002-02-25 | 0d? | 145.75d | 0d |  |  |  |  |  |
| 663 | 20.2.11 | Zimmerkabel, Rangiervergrahtung |  | 3.75d | 2002-02-25 | 2002-02-28 | 662 | 2002-02-25 | 2002-02-28 | 0d? | 145.75d | 0d |  |  |  |  |  |
| 664 | 20.2.12 | Herstellen der Funktionsfähigkeit, Prüfen |  | 10d | 2002-02-28 | 2002-03-11 | 663 | 2002-02-28 | 2002-03-11 | 0d? | 145.75d | 0d |  |  |  |  |  |
| 665 | 20.3 | Inbetriebnahme Bz 14. |  | 1.25d | 2002-03-11 | 2002-03-12 | 664 | 2002-03-11 | 2002-03-12 | 1.25d | 145.75d | 0d | start no earlier than 2002-03-11 | C-Monteur LST Inb.3 [400%]; Monteur LST Inb. 3 [400%] | 26h | 1,980 |  |

| ID | WBS | Task | Type | Duration | Start | Finish | Predecessors | Baseline start | Baseline finish | Baseline duration | Total slack | Free slack | Constraint | Resources | Work | Cost | Baseline cost |
| --- | --- | --- | --- | --- | --- | --- | --- | --- | --- | --- | --- | --- | --- | --- | --- | --- | --- |
| 666 | 20.4 | **Restarbeiten Bz 14.** |  | 3.75d | 2002-03-12 | 2002-03-15 |  | 2002-03-12 | 2002-03-15 | 0d? | 145.75d |  |  | C-Monteur LST Inb.3; Monteur LST Inb. 3 [200%] | 54h | 4,020 |  |
| 667 | 20.4.1 | Erstellen von handrevidierten Unterlagen |  | 3.75d | 2002-03-12 | 2002-03-15 | 665 | 2002-03-12 | 2002-03-15 | 0d? | 145.75d |  |  |  |  |  |  |
| 668 | 21 | **Bauzustand 15.1.** |  | 226.5d | 2001-09-21 | 2002-05-30 |  | 2001-09-21 | 2002-05-30 | 165.75d | 78d |  |  | Projektleiter [132%]; Sekretariat Projektbüro [132%]; 1. Bauleiter Sicherungstechn. [132%] | 3436.56h | 323,832.13 |  |
| 669 | 21.1 | **Planung** |  | 162.5d | 2001-09-21 | 2002-03-20 |  | 2001-09-21 | 2002-03-20 | 117.5d | 83.25d |  |  |  | 1348h | 135,645 | 51,000 |
| 670 | 21.1.1 | **Außenanlagen (PT I)** |  | 105d | 2001-09-21 | 2002-01-17 |  | 2001-09-21 | 2002-01-17 | 81.25d | 83.25d |  |  | Plan PT I ETC 15.1. | 676h | 25,800 | 27,000 |
| 671 | 21.1.1.1 | Ausarbeitung |  | 27.5d | 2001-09-21 | 2001-10-22 |  | 2001-09-21 | 2001-10-22 | 11.25d | 83.25d | 0d | start no earlier than 2001-09-21 |  |  |  | 27,000 |
| 672 | 21.1.1.2 | Plausibilitätsprüfung ÖRZ |  | 2.5d | 2001-10-24 | 2001-10-25 | 671FS+1.25d | 2001-10-24 | 2001-10-25 | 6.25d | 83.25d | 0d |  |  |  |  |  |
| 673 | 21.1.1.3 | fachtechnische Prüfung |  | 27.5d | 2001-10-26 | 2001-11-26 | 672 | 2001-10-26 | 2001-11-26 | 27.5d | 83.25d | 0d | start no earlier than 2000-08-07 |  |  |  |  |
| 674 | 21.1.1.4 | Übergabe und Weiterleitung PBDE |  | 2.5d | 2001-11-28 | 2001-11-29 | 673FS+1.25d | 2001-11-28 | 2001-11-29 | 3.75d | 83.25d | 0d |  |  |  |  |  |
| 675 | 21.1.1.5 | Prüfung durch EBA |  | 36.25d | 2001-11-30 | 2002-01-10 | 674 | 2001-11-30 | 2002-01-10 | 26.25d | 83.25d | 0d |  |  |  |  |  |
| 676 | 21.1.1.6 | Weiterleitung und Übergabe PBDE |  | 6.25d | 2002-01-10 | 2002-01-17 | 675 | 2002-01-10 | 2002-01-17 | 6.25d | 199.5d |  |  |  |  |  |  |
| 677 | 21.1.1.7 | ETC (PT I EBA - freigegeben) | milestone | 0d | 2002-01-10 | 2002-01-10 | 675 | 2002-01-10 | 2002-01-10 | 0d | 83.25d | 0d |  |  |  |  |  |
| 678 | 21.1.2 | **Innenanlagen (PT II)** |  | 103.75d | 2001-11-27 | 2002-03-20 |  | 2001-11-27 | 2002-03-20 | 73.75d | 142d |  |  | Plan PT II (Siemens) 15.1. | 672h | 109,845 | 24,000 |
| 679 | 21.1.2.1 | Ausarbeitung |  | 33.75d | 2001-11-27 | 2002-01-04 | 673 | 2001-11-27 | 2002-01-04 | 20d | 142d | 0d |  |  |  |  | 24,000 |
| 680 | 21.1.2.2 | fachtechnische Prüfung |  | 28.75d | 2002-01-07 | 2002-02-07 | 679FS+2.5d | 2002-01-07 | 2002-02-07 | 20d | 142d | 0d |  |  |  |  |  |
| 681 | 21.1.2.3 | Übergabe und Weiterleitung PBDE |  | 2.5d | 2002-02-11 | 2002-02-13 | 680FS+3.75d | 2002-02-11 | 2002-02-13 | 1.25d | 142d | 0d |  |  |  |  |  |
| 682 | 21.1.2.4 | Prüfung durch EBA |  | 26.25d | 2002-02-13 | 2002-03-13 | 681 | 2002-02-13 | 2002-03-13 | 26.25d | 142d | 0d |  |  |  |  |  |
| 683 | 21.1.2.5 | Weiterleitung und Übergabe PBDE |  | 6.25d | 2002-03-13 | 2002-03-20 | 682 | 2002-03-13 | 2002-03-20 | 3.75d | 142d |  |  |  |  |  |  |
| 684 | 21.1.2.6 | Siemens (PT II EBA - freigegeben) | milestone | 0d | 2002-03-13 | 2002-03-13 | 682 | 2002-03-13 | 2002-03-13 | 0d | 148.25d |  |  |  |  |  |  |
| 685 | 21.2 | **Innen- und Außenanlage** |  | 91.25d | 2002-02-08 | 2002-05-20 |  | 2002-02-08 | 2002-05-20 | 51.25d | 83.25d |  |  | 1.C-Monteur LST [80%]; 1.MonteurMU/Kab [80%]; Erstellung BZ 15.1. | 965.92h | 86,740.73 |  |
| 686 | 21.2.1 | Materialisierung |  | 18.75d | 2002-02-08 | 2002-02-28 | 677FS+26.25d | 2002-02-08 | 2002-02-28 | 1.25d | 83.25d | 0d |  |  |  |  |  |
| 687 | 21.2.2 | Kabel, Signale, Magnete usw. bestellen und liefern |  | 37.5d | 2002-03-05 | 2002-04-15 | 686FS+3.75d | 2002-03-05 | 2002-04-15 | 0d? | 83.25d | 0d |  |  |  |  |  |
| 688 | 21.2.3 | Kabel ziehen |  | 12.5d | 2002-03-25 | 2002-04-08 | 687SS+18.75d | 2002-03-25 | 2002-04-08 | 6.25d | 83.25d | 0d | start no earlier than 2000-07-01 |  |  |  |  |
| 689 | 21.2.4 | Kabelarbeiten |  | 6.25d | 2002-04-08 | 2002-04-15 | 688 | 2002-04-08 | 2002-04-15 | 17.5d | 113.25d | 0d | start no earlier than 2000-08-06 |  |  |  |  |
| 690 | 21.2.5 | Magnete montieren |  | 6.25d | 2002-04-15 | 2002-04-22 | 689 | 2002-04-15 | 2002-04-22 | 2.5d | 113.25d |  |  |  |  |  |  |
| 691 | 21.2.6 | Signalmasten stellen |  | 6.25d | 2002-04-15 | 2002-04-22 | 686, 687 | 2002-04-15 | 2002-04-22 | 0d? | 87d | 0d |  |  |  |  |  |
| 692 | 21.2.7 | Signale verkabeln |  | 6.25d | 2002-04-22 | 2002-04-29 | 688, 691 | 2002-04-22 | 2002-04-29 | 0d? | 87d | 3.75d |  |  |  |  |  |
| 693 | 21.2.8 | Kabel auf Kabelendverschluß legen |  | 6.25d | 2002-04-08 | 2002-04-15 | 688 | 2002-04-08 | 2002-04-15 | 0d? | 83.25d | 0d |  |  |  |  |  |
| 694 | 21.2.9 | Versorgung 50 Hz verdrahten |  | 3.75d | 2002-04-15 | 2002-04-18 | 693 | 2002-04-15 | 2002-04-18 | 0d? | 83.25d | 0d |  |  |  |  |  |
| 695 | 21.2.10 | Relaisgruppen montieren und bestücken |  | 6.25d | 2002-04-18 | 2002-04-25 | 694 | 2002-04-18 | 2002-04-25 | 0d? | 83.25d | 0d |  |  |  |  |  |
| 696 | 21.2.11 | Zimmerkabel, Rangiervergrahtung |  | 6.25d | 2002-04-25 | 2002-05-02 | 695 | 2002-04-25 | 2002-05-02 | 0d? | 83.25d | 0d |  |  |  |  |  |
| 697 | 21.2.12 | Herstellen der Funktionsfähigkeit, Prüfen |  | 15d | 2002-05-02 | 2002-05-20 | 696, 692 | 2002-05-02 | 2002-05-20 | 0d? | 83.25d | 5.25d |  |  |  |  |  |
| 698 | 21.3 | Inbetriebnahme Bz 15.1. |  | 1.25d | 2002-05-26 | 2002-05-27 | 697 | 2002-05-26 | 2002-05-27 | 1.25d | 78d | 0d | start no earlier than 2002-05-26 | C-Monteur LST Inb.1 [125%]; Monteur LST Inb. 1 [125%] | 24h | 1,440 |  |

| ID | WBS | Task | Type | Duration | Start | Finish | Predecessors | Baseline start | Baseline finish | Baseline duration | Total slack | Free slack | Constraint | Resources | Work | Cost | Baseline cost |
| --- | --- | --- | --- | --- | --- | --- | --- | --- | --- | --- | --- | --- | --- | --- | --- | --- | --- |
| 699 | 21.4 | **Restarbeiten Bz 15.1.** |  | 3.75d | 2002-05-27 | 2002-05-30 |  | 2002-05-27 | 2002-05-30 | 0d? | 78d |  |  | C-Monteur LST Inb.1 [500%]; Monteur LST Inb. 1 [500%] | 76h | 4,560 |  |
| 700 | 21.4.1 | Erstellen von handrevidierten Unterlagen |  | 3.75d | 2002-05-27 | 2002-05-30 | 698 | 2002-05-27 | 2002-05-30 | 0d? | 78d |  |  |  |  |  |  |
| 701 | 22 | **Bauzustand 15.2.** |  | 238.75d | 2001-10-22 | 2002-07-10 |  | 2001-10-22 | 2002-07-10 | 165.75d | 39.5d |  |  | Projektleiter; Sekretariat Projektbüro; 1. Bauleiter Sicherungstechn. | 2585.04h | 291,800.43 |  |
| 702 | 22.1 | **Planung** |  | 171.25d | 2001-10-22 | 2002-04-29 |  | 2001-10-22 | 2002-04-29 | 117.5d | 49.5d |  |  |  | 468h | 74,992.5 | 51,000 |
| 703 | 22.1.1 | **Außenanlagen (PT I)** |  | 112.5d | 2001-10-22 | 2002-02-22 |  | 2001-10-22 | 2002-02-22 | 81.25d | 49.5d |  |  |  |  |  | 27,000 |
| 704 | 22.1.1.1 | Ausarbeitung |  | 30d | 2001-10-22 | 2001-11-22 |  | 2001-10-22 | 2001-11-22 | 11.25d | 49.5d | 0d | start no earlier than 2001-10-22 |  |  |  | 27,000 |
| 705 | 22.1.1.2 | Plausibilitätsprüfung ÖRZ |  | 2.5d | 2001-11-26 | 2001-11-27 | 704FS+1.25d | 2001-11-26 | 2001-11-27 | 6.25d | 49.5d | 0d |  |  |  |  |  |
| 706 | 22.1.1.3 | fachtechnische Prüfung |  | 40d | 2001-11-28 | 2002-01-11 | 705 | 2001-11-28 | 2002-01-11 | 27.5d | 49.5d | 0d | start no earlier than 2000-08-07 |  |  |  |  |
| 707 | 22.1.1.4 | Übergabe und Weiterleitung PBDE |  | 1.25d | 2002-01-14 | 2002-01-15 | 706FS+1.25d | 2002-01-14 | 2002-01-15 | 3.75d | 49.5d | 0d |  |  |  |  |  |
| 708 | 22.1.1.5 | Prüfung durch EBA |  | 30d | 2002-01-15 | 2002-02-15 | 707 | 2002-01-15 | 2002-02-15 | 26.25d | 49.5d | 0d |  |  |  |  |  |
| 709 | 22.1.1.6 | Weiterleitung und Übergabe PBDE |  | 6.25d | 2002-02-15 | 2002-02-22 | 708 | 2002-02-15 | 2002-02-22 | 6.25d | 165.75d |  |  |  |  |  |  |
| 710 | 22.1.1.7 | ETC (PT I EBA - freigegeben) | milestone | 0d | 2002-02-15 | 2002-02-15 | 708 | 2002-02-15 | 2002-02-15 | 0d | 49.5d | 0d |  |  |  |  |  |
| 711 | 22.1.2 | **Innenanlagen (PT II)** |  | 96.25d | 2002-01-14 | 2002-04-29 |  | 2002-01-14 | 2002-04-29 | 73.75d | 107d |  |  | Plan PT II (Siemens) 15.2. | 468h | 74,992.5 | 24,000 |
| 712 | 22.1.2.1 | Ausarbeitung |  | 30d | 2002-01-14 | 2002-02-14 | 706FS+1.25d | 2002-01-14 | 2002-02-14 | 20d | 107d | 0d |  |  |  |  | 24,000 |
| 713 | 22.1.2.2 | fachtechnische Prüfung |  | 26.25d | 2002-02-18 | 2002-03-18 | 712FS+2.5d | 2002-02-18 | 2002-03-18 | 20d | 107d | 0d |  |  |  |  |  |
| 714 | 22.1.2.3 | Übergabe und Weiterleitung PBDE |  | 2.5d | 2002-03-20 | 2002-03-22 | 713FS+2.5d | 2002-03-20 | 2002-03-22 | 1.25d | 107d | 0d |  |  |  |  |  |
| 715 | 22.1.2.4 | Prüfung durch EBA |  | 26.25d | 2002-03-22 | 2002-04-22 | 714 | 2002-03-22 | 2002-04-22 | 26.25d | 107d | 0d |  |  |  |  |  |
| 716 | 22.1.2.5 | Weiterleitung und Übergabe PBDE |  | 6.25d | 2002-04-22 | 2002-04-29 | 715 | 2002-04-22 | 2002-04-29 | 3.75d | 107d |  |  |  |  |  |  |
| 717 | 22.1.2.6 | Siemens (PT II EBA - freigegeben) | milestone | 0d | 2002-04-22 | 2002-04-22 | 715 | 2002-04-22 | 2002-04-22 | 0d | 113.25d |  |  |  |  |  |  |
| 718 | 22.2 | **Innen- und Außenanlage** |  | 91.25d | 2002-03-15 | 2002-06-25 |  | 2002-03-15 | 2002-06-25 | 51.25d | 49.5d |  |  | 1.C-Monteur LST [200%]; 1.MonteurMU/Kab [200%]; Erstellung BZ 15.2. | 751.84h | 91,655.93 |  |
| 719 | 22.2.1 | Materialisierung |  | 18.75d | 2002-03-15 | 2002-04-05 | 710FS+26.25d | 2002-03-15 | 2002-04-05 | 1.25d | 49.5d | 0d |  |  |  |  |  |
| 720 | 22.2.2 | Kabel, Signale, Magnete usw. bestellen und liefern |  | 37.5d | 2002-04-10 | 2002-05-22 | 719FS+3.75d | 2002-04-10 | 2002-05-22 | 0d? | 49.5d | 0d |  |  |  |  |  |
| 721 | 22.2.3 | Kabel ziehen |  | 12.5d | 2002-04-17 | 2002-05-01 | 720SS+6.25d | 2002-04-17 | 2002-05-01 | 6.25d | 58.25d | 0d | start no earlier than 2000-07-01 |  |  |  |  |
| 722 | 22.2.4 | Kabelarbeiten |  | 6.25d | 2002-05-01 | 2002-05-08 | 721 | 2002-05-01 | 2002-05-08 | 17.5d | 92d | 0d | start no earlier than 2000-08-06 |  |  |  |  |
| 723 | 22.2.5 | Magnete montieren |  | 6.25d | 2002-05-08 | 2002-05-15 | 722 | 2002-05-08 | 2002-05-15 | 2.5d | 92d |  |  |  |  |  |  |
| 724 | 22.2.6 | Signalmasten stellen |  | 6.25d | 2002-05-22 | 2002-05-28 | 719, 720 | 2002-05-22 | 2002-05-28 | 0d? | 49.5d | 0d |  |  |  |  |  |
| 725 | 22.2.7 | Signale verkabeln |  | 6.25d | 2002-05-29 | 2002-06-04 | 721, 724 | 2002-05-29 | 2002-06-04 | 0d? | 49.5d | 0d |  |  |  |  |  |
| 726 | 22.2.8 | Kabel auf Kabelendverschluß legen |  | 3.75d | 2002-05-01 | 2002-05-06 | 721 | 2002-05-01 | 2002-05-06 | 0d? | 58.25d | 0d |  |  |  |  |  |
| 727 | 22.2.9 | Versorgung 50 Hz verdrahten |  | 6.25d | 2002-05-06 | 2002-05-13 | 726 | 2002-05-06 | 2002-05-13 | 0d? | 58.25d | 0d |  |  |  |  |  |
| 728 | 22.2.10 | Relaisgruppen montieren und bestücken |  | 6.25d | 2002-05-13 | 2002-05-20 | 727 | 2002-05-13 | 2002-05-20 | 0d? | 58.25d | 0d |  |  |  |  |  |
| 729 | 22.2.11 | Zimmerkabel, Rangiervergrahtung |  | 6.25d | 2002-05-20 | 2002-05-26 | 728 | 2002-05-20 | 2002-05-26 | 0d? | 58.25d | 8.75d |  |  |  |  |  |
| 730 | 22.2.12 | Herstellen der Funktionsfähigkeit, Prüfen |  | 18.75d | 2002-06-05 | 2002-06-25 | 729, 725 | 2002-06-05 | 2002-06-25 | 0d? | 49.5d | 10d |  |  |  |  |  |
| 731 | 22.3 | Inbetriebnahme Bz 15.2. |  | 1.25d | 2002-07-06 | 2002-07-07 | 730 | 2002-07-06 | 2002-07-07 | 1.25d | 39.5d | 0d | start no earlier than 2002-07-06 | C-Monteur LST Inb.1; Monteur LST Inb. 1 | 18h | 1,080 |  |

| ID | WBS | Task | Type | Duration | Start | Finish | Predecessors | Baseline start | Baseline finish | Baseline duration | Total slack | Free slack | Constraint | Resources | Work | Cost | Baseline cost |
| --- | --- | --- | --- | --- | --- | --- | --- | --- | --- | --- | --- | --- | --- | --- | --- | --- | --- |
| 732 | 22.4 | **Restarbeiten Bz 15.2.** |  | 3.75d | 2002-07-07 | 2002-07-10 |  | 2002-07-07 | 2002-07-10 | 0d? | 39.5d |  |  | C-Monteur LST Inb.1; Monteur LST Inb. 1 | 50h | 3,000 |  |
| 733 | 22.4.1 | Erstellen von handrevidierten Unterlagen |  | 3.75d | 2002-07-07 | 2002-07-10 | 731 | 2002-07-07 | 2002-07-10 | 0d? | 39.5d |  |  |  |  |  |  |
| 734 | 23 | **Bauzustand 16.** |  | 249.5d | 2001-11-22 | 2002-08-21 |  | 2001-11-22 | 2002-08-21 | 165.75d | 0d |  |  | Projektleiter; Sekretariat Projektbüro; 1. Bauleiter Sicherungstechn. | 3746.32h | 447,584.73 |  |
| 735 | 23.1 | **Planung** |  | 168.75d | 2001-11-22 | 2002-05-27 |  | 2001-11-22 | 2002-05-27 | 117.5d | 63.25d |  |  |  | 1008h | 167,940 | 51,000 |
| 736 | 23.1.1 | **Außenanlagen (PT I)** |  | 107.5d | 2001-11-22 | 2002-03-20 |  | 2001-11-22 | 2002-03-20 | 81.25d | 63.25d |  |  | Plan PT I ETC 16. | 696h | 34,200 | 27,000 |
| 737 | 23.1.1.1 | Ausarbeitung |  | 37.5d | 2001-11-22 | 2002-01-04 |  | 2001-11-22 | 2002-01-04 | 11.25d | 63.25d | 0d | start no earlier than 2001-11-22 |  |  |  | 27,000 |
| 738 | 23.1.1.2 | Plausibilitätsprüfung ÖRZ |  | 3.75d | 2002-01-05 | 2002-01-08 | 737 | 2002-01-05 | 2002-01-08 | 6.25d | 63.25d | 0d |  |  |  |  |  |
| 739 | 23.1.1.3 | fachtechnische Prüfung |  | 28.75d | 2002-01-08 | 2002-02-08 | 738 | 2002-01-08 | 2002-02-08 | 27.5d | 63.25d | 0d | start no earlier than 2000-08-07 |  |  |  |  |
| 740 | 23.1.1.4 | Übergabe und Weiterleitung PBDE |  | 2.5d | 2002-02-11 | 2002-02-13 | 739FS+2.5d | 2002-02-11 | 2002-02-13 | 3.75d | 63.25d | 0d |  |  |  |  |  |
| 741 | 23.1.1.5 | Prüfung durch EBA |  | 26.25d | 2002-02-13 | 2002-03-13 | 740 | 2002-02-13 | 2002-03-13 | 26.25d | 63.25d | 0d |  |  |  |  |  |
| 742 | 23.1.1.6 | Weiterleitung und Übergabe PBDE |  | 6.25d | 2002-03-13 | 2002-03-20 | 741 | 2002-03-13 | 2002-03-20 | 6.25d | 142d |  |  |  |  |  |  |
| 743 | 23.1.1.7 | ETC (PT I EBA - freigegeben) | milestone | 0d | 2002-03-13 | 2002-03-13 | 741 | 2002-03-13 | 2002-03-13 | 0d | 63.25d | 0d |  |  |  |  |  |
| 744 | 23.1.2 | **Innenanlagen (PT II)** |  | 96.25d | 2002-02-11 | 2002-05-27 |  | 2002-02-11 | 2002-05-27 | 73.75d | 80.75d |  |  | Plan PT II (Siemens) 16. | 312h | 133,740 | 24,000 |
| 745 | 23.1.2.1 | Ausarbeitung |  | 26.25d | 2002-02-11 | 2002-03-11 | 739FS+2.5d | 2002-02-11 | 2002-03-11 | 20d | 80.75d | 0d |  |  |  |  | 24,000 |
| 746 | 23.1.2.2 | fachtechnische Prüfung |  | 28.75d | 2002-03-13 | 2002-04-15 | 745FS+2.5d | 2002-03-13 | 2002-04-15 | 20d | 80.75d | 0d |  |  |  |  |  |
| 747 | 23.1.2.3 | Übergabe und Weiterleitung PBDE |  | 2.5d | 2002-04-17 | 2002-04-19 | 746FS+2.5d | 2002-04-17 | 2002-04-19 | 1.25d | 80.75d | 0d |  |  |  |  |  |
| 748 | 23.1.2.4 | Prüfung durch EBA |  | 26.25d | 2002-04-19 | 2002-05-20 | 747 | 2002-04-19 | 2002-05-20 | 26.25d | 80.75d | 0d |  |  |  |  |  |
| 749 | 23.1.2.5 | Weiterleitung und Übergabe PBDE |  | 7.5d | 2002-05-20 | 2002-05-27 | 748 | 2002-05-20 | 2002-05-27 | 3.75d | 80.75d |  |  |  |  |  |  |
| 750 | 23.1.2.6 | Siemens (PT II EBA - freigegeben) | milestone | 0d | 2002-05-20 | 2002-05-20 | 748 | 2002-05-20 | 2002-05-20 | 0d | 88.25d |  |  |  |  |  |  |
| 751 | 23.2 | **Innen- und Außenanlage** |  | 53.75d | 2002-04-11 | 2002-06-10 |  | 2002-04-11 | 2002-06-10 | 51.25d | 63.25d |  |  | 1.C-Monteur LST [136%]; 1.MonteurMU/Kab [136%]; Erstellung BZ 16; 2.MonteurMU/Kab | 714.32h | 93,004.73 |  |
| 752 | 23.2.1 | Materialisierung |  | 6.25d | 2002-04-11 | 2002-04-18 | 743FS+26.25d | 2002-04-11 | 2002-04-18 | 1.25d | 63.25d | 0d |  |  |  |  |  |
| 753 | 23.2.2 | Kabel, Signale, Magnete usw. bestellen und liefern |  | 26.25d | 2002-04-23 | 2002-05-22 | 752FS+3.75d | 2002-04-23 | 2002-05-22 | 0d? | 63.25d | 0d |  |  |  |  |  |
| 754 | 23.2.3 | Kabel ziehen |  | 7.5d | 2002-04-30 | 2002-05-08 | 753SS+6.25d | 2002-04-30 | 2002-05-08 | 6.25d | 68.25d | 0d | start no earlier than 2000-07-01 |  |  |  |  |
| 755 | 23.2.4 | Kabelarbeiten |  | 3.75d | 2002-05-08 | 2002-05-13 | 754 | 2002-05-08 | 2002-05-13 | 17.5d | 90.75d | 0d | start no earlier than 2000-08-06 |  |  |  |  |
| 756 | 23.2.5 | Magnete montieren |  | 3.75d | 2002-05-13 | 2002-05-16 | 755 | 2002-05-13 | 2002-05-16 | 2.5d | 90.75d |  |  |  |  |  |  |
| 757 | 23.2.6 | Signalmasten stellen |  | 2.5d | 2002-05-22 | 2002-05-24 | 752, 753 | 2002-05-22 | 2002-05-24 | 0d? | 63.25d | 0d |  |  |  |  |  |
| 758 | 23.2.7 | Signale verkabeln |  | 5d | 2002-05-24 | 2002-05-29 | 754, 757 | 2002-05-24 | 2002-05-29 | 0d? | 63.25d | 0d |  |  |  |  |  |
| 759 | 23.2.8 | Kabel auf Kabelendverschluß legen |  | 2.5d | 2002-05-08 | 2002-05-10 | 754 | 2002-05-08 | 2002-05-10 | 0d? | 68.25d | 0d |  |  |  |  |  |
| 760 | 23.2.9 | Versorgung 50 Hz verdrahten |  | 3.75d | 2002-05-10 | 2002-05-15 | 759 | 2002-05-10 | 2002-05-15 | 0d? | 68.25d | 0d |  |  |  |  |  |
| 761 | 23.2.10 | Relaisgruppen montieren und bestücken |  | 5d | 2002-05-15 | 2002-05-21 | 760 | 2002-05-15 | 2002-05-21 | 0d? | 68.25d | 0d |  |  |  |  |  |
| 762 | 23.2.11 | Zimmerkabel, Rangiervergrahtung |  | 3.75d | 2002-05-21 | 2002-05-24 | 761 | 2002-05-21 | 2002-05-24 | 0d? | 68.25d | 5d |  |  |  |  |  |
| 763 | 23.2.12 | Herstellen der Funktionsfähigkeit, Prüfen |  | 10d | 2002-05-30 | 2002-06-10 | 762, 758 | 2002-05-30 | 2002-06-10 | 0d? | 63.25d |  |  |  |  |  |  |
| 764 | 23.3 | Inbetriebnahme Bz 16. |  | 1.25d | 2002-08-17 | 2002-08-18 | 763 | 2002-08-17 | 2002-08-18 | 1.25d | 0d |  | start no earlier than 2002-08-17 | C-Monteur LST Inb.1; Monteur LST Inb. 1 | 16h | 960 |  |

| ID | WBS | Task | Type | Duration | Start | Finish | Predecessors | Baseline start | Baseline finish | Baseline duration | Total slack | Resources | Work | Cost |
| --- | --- | --- | --- | --- | --- | --- | --- | --- | --- | --- | --- | --- | --- | --- |
| 765 | 23.4 | **Restarbeiten Bz 16.** |  | 3.75d | 2002-08-18 | 2002-08-21 | 764 | 2002-08-18 | 2002-08-21 | 0d? | 0d | C-Monteur LST Inb.1; Monteur LST Inb. 1 | 52h | 3,120 |
| 766 | 23.4.1 | Erstellen von handrevidierten Unterlagen |  | 3.75d | 2002-08-18 | 2002-08-21 | 764 | 2002-08-18 | 2002-08-21 | 0d? | 0d |  |  |  |
| 767 | 24 | Bauende | milestone | 0d | 2002-08-21 | 2002-08-21 | 34, 103, 171, 238, 304, 370, 436, 502, 568, 700, 766, 137, 205, 271, 403, 469, 535, 601, 667, 733, 634, 337, 68 | 2002-08-21 | 2002-08-21 | 0d? | 0d | Erstellung Restarbeiten |  | 591,205.6 |
